# Projet X

Schedule from MS Project, 2008-04-17 to 2008-08-01.
X

## Calendars

- Standard: Mon-Fri 08:00-12:00, 13:00-17:00; Sat-Sun off.

## Schedule

| ID | WBS | Task | Type | Duration | Start | Finish | Predecessors | Total slack | Free slack | Work |
| --- | --- | --- | --- | --- | --- | --- | --- | --- | --- | --- |
| 1 | 1 | Début du projet | milestone | 0d | 2008-04-17 | 2008-04-17 |  | 67.35d |  |  |
| 2 | 2 | **GESTION DU PROJET** |  | 7.35d | 2008-04-17 | 2008-04-29 |  | 0d |  | 42.35h |
| 3 | 2.1 | **Initialiser le projet** |  | 1.75d | 2008-04-17 | 2008-04-18 |  | 0d |  | 5h |
| 4 | 2.1.1 | **Réception** |  | 0.5d | 2008-04-17 | 2008-04-17 |  | 0d |  | 4h |
| 5 | 2.1.1.1 | Réceptionner la demande de projet du commanditaire |  | 0.25d | 2008-04-17 | 2008-04-17 |  | 0d |  | 2h |
| 6 | 2.1.1.2 | Demande de projet du commanditaire | milestone | 0d | 2008-04-17 | 2008-04-17 | 5 | 0d |  |  |
| 7 | 2.1.1.3 | Examiner la demande du commanditaire |  | 0.25d | 2008-04-17 | 2008-04-17 | 6 | 0d |  | 2h |
| 8 | 2.1.1.4 | Réponse à la demande de projet | milestone | 0d | 2008-04-17 | 2008-04-17 | 7 | 66.85d |  |  |
| 9 | 2.1.2 | **Affectation** |  | 1.25d | 2008-04-17 | 2008-04-18 |  | 0d |  | 1h |
| 10 | 2.1.2.1 | Officialiser la nomination du chef de projet |  | 0.25d | 2008-04-17 | 2008-04-17 | 7 | 0d |  | 1h |
| 11 | 2.1.2.2 | Note d’affectation du chef de projet | milestone | 0d | 2008-04-18 | 2008-04-18 | 10FS+1d | 0d |  |  |
| 12 | 2.2 | **Préparer le projet** |  | 4d | 2008-04-21 | 2008-04-25 |  | 0d |  | 26h |
| 13 | 2.2.1 | **Objet** |  | 0.25d | 2008-04-21 | 2008-04-21 |  | 0d |  | 2h |
| 14 | 2.2.1.1 | Définir l’objet précis du projet |  | 0.25d | 2008-04-21 | 2008-04-21 | 11 | 65.35d | 0d | 1h |
| 15 | 2.2.1.2 | Note de cadrage | milestone | 0d | 2008-04-21 | 2008-04-21 | 14 | 65.35d |  |  |
| 16 | 2.2.1.3 | Lister les motifs et définir le contexte |  | 0.25d | 2008-04-21 | 2008-04-21 | 11 | 0d |  | 1h |
| 17 | 2.2.1.4 | Note de cadrage (suite) | milestone | 0d | 2008-04-21 | 2008-04-21 | 16 | 0d |  |  |
| 18 | 2.2.2 | **Objectifs** |  | 0.75d | 2008-04-22 | 2008-04-23 |  | 0d |  | 10h |
| 19 | 2.2.2.1 | Définir les objectifs de qualité |  | 0.25d | 2008-04-22 | 2008-04-22 | 17FS+1d | 64.1d | 0d | 4h |
| 20 | 2.2.2.2 | Note de cadrage (suite) | milestone | 0d | 2008-04-22 | 2008-04-22 | 19 | 64.1d |  |  |
| 21 | 2.2.2.3 | Définir les objectifs de temps |  | 0.25d | 2008-04-22 | 2008-04-22 | 17FS+1d | 64.1d | 0d | 1h |
| 22 | 2.2.2.4 | macro-planning | milestone | 0d | 2008-04-22 | 2008-04-22 | 21 | 64.1d |  |  |
| 23 | 2.2.2.5 | Définir les objectifs de charge et de coûts |  | 0.25d | 2008-04-22 | 2008-04-22 | 17FS+1d | 63.85d | 0d | 1h |
| 24 | 2.2.2.6 | macro-planning de charge | milestone | 0d | 2008-04-22 | 2008-04-22 | 23 | 64.1d |  |  |
| 25 | 2.2.2.7 | Budget prévisionnel | milestone | 0d | 2008-04-22 | 2008-04-22 | 23 | 64.1d |  |  |
| 26 | 2.2.2.8 | Définir les objectifs de communication |  | 0.25d | 2008-04-22 | 2008-04-22 | 23 | 63.85d | 0d | 2h |
| 27 | 2.2.2.9 | Stratégie de communication | milestone | 0d | 2008-04-22 | 2008-04-22 | 26 | 63.85d |  |  |
| 28 | 2.2.2.10 | Définir les objectifs complémentaires |  | 0.25d | 2008-04-22 | 2008-04-22 | 17FS+1d | 0d |  | 0.5h |
| 29 | 2.2.2.11 | Note de cadrage (suite) | milestone | 0d | 2008-04-22 | 2008-04-22 | 28 | 0d |  |  |
| 30 | 2.2.2.12 | Préciser les contraintes sur objectifs |  | 0.25d | 2008-04-22 | 2008-04-22 | 29 | 0d |  | 0.5h |
| 31 | 2.2.2.13 | Note de cadrage (suite) | milestone | 0d | 2008-04-22 | 2008-04-22 | 30 | 0d |  |  |
| 32 | 2.2.2.14 | Vérifier l’adéquation entre les objectifs |  | 0.25d | 2008-04-23 | 2008-04-23 | 31 | 0d |  | 1h |
| 33 | 2.2.2.15 | Note de cadrage (suite) | milestone | 0d | 2008-04-23 | 2008-04-23 | 32 | 0d |  |  |

| ID | WBS | Task | Type | Duration | Start | Finish | Predecessors | Total slack | Free slack | Work |
| --- | --- | --- | --- | --- | --- | --- | --- | --- | --- | --- |
| 34 | 2.2.3 | **Domaine** |  | 1.25d | 2008-04-23 | 2008-04-24 |  | 0d |  | 5h |
| 35 | 2.2.3.1 | Identifier le périmètre et les acteurs |  | 1d | 2008-04-23 | 2008-04-24 | 33 | 0d |  | 4h |
| 36 | 2.2.3.2 | Fichier des acteurs | milestone | 0d | 2008-04-24 | 2008-04-24 | 35 | 62.6d |  |  |
| 37 | 2.2.3.3 | Définir la structure choisie pour la gestion du projet |  | 0.25d | 2008-04-24 | 2008-04-24 | 33, 35FF | 0d |  | 0.5h |
| 38 | 2.2.3.4 | Organigramme Projet | milestone | 0d | 2008-04-24 | 2008-04-24 | 37 | 0d |  |  |
| 39 | 2.2.3.5 | Définir les rôles des acteurs dans les structures projets |  | 0.25d | 2008-04-24 | 2008-04-24 | 38 | 0d |  | 0.5h |
| 40 | 2.2.3.6 | Fiche de poste | milestone | 0d | 2008-04-24 | 2008-04-24 | 39 | 62.35d |  |  |
| 41 | 2.2.3.7 | Carte des acteurs | milestone | 0d | 2008-04-24 | 2008-04-24 | 39 | 0d |  |  |
| 42 | 2.2.4 | **Risques** |  | 0.25d | 2008-04-24 | 2008-04-24 |  | 0d |  | 3h |
| 43 | 2.2.4.1 | Identifier, analyser et gérer les freins |  | 0.25d | 2008-04-24 | 2008-04-24 | 41 | 0d |  | 2h |
| 44 | 2.2.4.2 | Grille des freins | milestone | 0d | 2008-04-24 | 2008-04-24 | 43 | 0d |  |  |
| 45 | 2.2.4.3 | Identifier, analyser et gérer les facilitants |  | 0.25d | 2008-04-24 | 2008-04-24 | 41 | 62.1d |  | 1h |
| 46 | 2.2.4.4 | Grille des facilitants | milestone | 0d | 2008-04-24 | 2008-04-24 | 44 | 0d |  |  |
| 47 | 2.2.5 | **Méthode** |  | 0.25d | 2008-04-24 | 2008-04-24 |  | 62.1d |  | 2h |
| 48 | 2.2.5.1 | Choisir une méthode et structurer la réal. du produit |  | 0.25d | 2008-04-24 | 2008-04-24 | 41 | 62.1d | 0d | 2h |
| 49 | 2.2.5.2 | Fiche méthode | milestone | 0d | 2008-04-24 | 2008-04-24 | 48 | 62.1d |  |  |
| 50 | 2.2.6 | **Communication** |  | 0.25d | 2008-04-25 | 2008-04-25 |  | 0d |  | 2h |
| 51 | 2.2.6.1 | Définir les axes, cibles et moyens de communication |  | 0.25d | 2008-04-25 | 2008-04-25 | 46 | 0d |  | 2h |
| 52 | 2.2.6.2 | Charte graphique | milestone | 0d | 2008-04-25 | 2008-04-25 | 51 | 61.85d |  |  |
| 53 | 2.2.6.3 | Plan de communication | milestone | 0d | 2008-04-25 | 2008-04-25 | 51 | 0d |  |  |
| 54 | 2.2.7 | **Contractualisation** |  | 0.25d | 2008-04-25 | 2008-04-25 |  | 0d |  | 2h |
| 55 | 2.2.7.1 | Rédiger la note de cadrage |  | 0.25d | 2008-04-25 | 2008-04-25 | 53 | 0d |  | 2h |
| 56 | 2.2.7.2 | Note de cadrage (suite) | milestone | 0d | 2008-04-25 | 2008-04-25 | 55 | 0d |  |  |
| 57 | 2.3 | **Planifier le projet** |  | 1.1d | 2008-04-25 | 2008-04-28 |  | 0d |  | 8.35h |
| 58 | 2.3.1 | **Planification détallée** |  | 0.6d | 2008-04-25 | 2008-04-28 |  | 0d |  | 4.35h |
| 59 | 2.3.1.1 | Définir l’environnement de planification |  | 0.1d | 2008-04-25 | 2008-04-25 | 56 | 0d |  | 0.5h |
| 60 | 2.3.1.2 | Charte de planification | milestone | 0d | 2008-04-25 | 2008-04-25 | 59 | 0d |  |  |
| 61 | 2.3.1.3 | Ordonner la liste des tâches de fabrication du produit |  | 0.1d | 2008-04-25 | 2008-04-25 | 60 | 0d |  | 1h |
| 62 | 2.3.1.4 | Organigramme des tâches | milestone | 0d | 2008-04-25 | 2008-04-25 | 61 | 0d |  |  |
| 63 | 2.3.1.5 | Affecter des durées ou des charges aux tâches |  | 0.1d | 2008-04-25 | 2008-04-25 | 62 | 0d |  | 0.5h |
| 64 | 2.3.1.6 | Planning détaillé | milestone | 0d | 2008-04-25 | 2008-04-25 | 63 | 0d |  |  |
| 65 | 2.3.1.7 | Définir les liens entre les tâches |  | 0.1d | 2008-04-25 | 2008-04-28 | 64 | 0d |  | 0.25h |
| 66 | 2.3.1.8 | Planning détaillé (suite) | milestone | 0d | 2008-04-28 | 2008-04-28 | 65 | 0d |  |  |
| 67 | 2.3.1.9 | Intégrer les tâches de gestion de projet |  | 0.1d | 2008-04-28 | 2008-04-28 | 66 | 0d |  | 0.1h |
| 68 | 2.3.1.10 | Planning détaillé (suite) | milestone | 0d | 2008-04-28 | 2008-04-28 | 67 | 0d |  |  |
| 69 | 2.3.1.11 | Affecter les ressources sur les tâches |  | 0.1d | 2008-04-28 | 2008-04-28 | 68 | 0d |  | 2h |
| 70 | 2.3.1.12 | Tableau des ressources | milestone | 0d | 2008-04-28 | 2008-04-28 | 69 | 0d |  |  |
| 71 | 2.3.1.13 | Planning détaillé (suite) | milestone | 0d | 2008-04-28 | 2008-04-28 | 70 | 0d |  |  |

| ID | WBS | Task | Type | Duration | Start | Finish | Predecessors | Total slack | Work |
| --- | --- | --- | --- | --- | --- | --- | --- | --- | --- |
| 72 | 2.3.2 | **Validation** |  | 0.5d | 2008-04-28 | 2008-04-28 |  | 0d | 4h |
| 73 | 2.3.2.1 | Optimiser le planning détaillé du prévu |  | 0.25d | 2008-04-28 | 2008-04-28 | 71 | 0d | 2h |
| 74 | 2.3.2.2 | Planning détaillé (suite) | milestone | 0d | 2008-04-28 | 2008-04-28 | 73 | 0d |  |
| 75 | 2.3.2.3 | Valider, communiquer et enregistrer le planning |  | 0.25d | 2008-04-28 | 2008-04-28 | 74 | 0d | 2h |
| 76 | 2.3.2.4 | Contrat de planning | milestone | 0d | 2008-04-28 | 2008-04-28 | 75 | 0d |  |
| 77 | 2.4 | **Piloter le projet** |  | 0.5d | 2008-04-28 | 2008-04-29 |  | 0d | 3h |
| 78 | 2.4.1 | **Lancement** |  | 0.5d | 2008-04-28 | 2008-04-29 |  | 0d | 3h |
| 79 | 2.4.1.1 | Lancer la réalisation |  | 0.25d | 2008-04-28 | 2008-04-29 | 76 | 0d | 1h |
| 80 | 2.4.1.2 | Journal du projet | milestone | 0d | 2008-04-29 | 2008-04-29 | 79 | 0d |  |
| 81 | 2.4.1.3 | Fiche de reporting | milestone | 0d | 2008-04-29 | 2008-04-29 | 80 | 0d |  |
| 82 | 2.4.1.4 | Mettre en œuvre le plan de communication |  | 0.25d | 2008-04-29 | 2008-04-29 | 81 | 0d | 2h |
| 83 | 2.4.1.5 | Plan de communication (suite) | milestone | 0d | 2008-04-29 | 2008-04-29 | 82 | 0d |  |
| 84 | 3 | **FABRICATION DU PRODUIT** |  | 56d | 2008-04-29 | 2008-07-28 |  | 0d | 510h |
| 85 | 3.1 | **Etude de la gestion des stocks** |  | 4d | 2008-04-29 | 2008-05-05 |  | 0d | 20h |
| 86 | 3.1.1 | **Etude opérationnelle** |  | 2d | 2008-04-29 | 2008-05-01 |  | 0d | 8h |
| 87 | 3.1.1.1 | Analyse de l'existant |  | 1d | 2008-04-29 | 2008-04-30 | 83 | 0d | 4h |
| 88 | 3.1.1.2 | Feuille d'analyse | milestone | 0d | 2008-04-30 | 2008-04-30 | 87 | 0d |  |
| 89 | 3.1.1.3 | Recherche des améliorations |  | 1d | 2008-04-30 | 2008-05-01 | 88 | 0d | 4h |
| 90 | 3.1.1.4 | Liste des améliorations | milestone | 0d | 2008-05-01 | 2008-05-01 | 89 | 0d |  |
| 91 | 3.1.2 | **Etude fonctionnelle** |  | 4d | 2008-04-29 | 2008-05-05 |  | 0d | 12h |
| 92 | 3.1.2.1 | Analyse de l'existant |  | 1d | 2008-04-29 | 2008-04-30 | 83 | 1d | 4h |
| 93 | 3.1.2.2 | Organigramme fonctionnel | milestone | 0d | 2008-05-01 | 2008-05-01 | 92, 90 | 0d |  |
| 94 | 3.1.2.3 | Rédaction du cahier des charges |  | 2d | 2008-05-01 | 2008-05-05 | 93 | 0d | 8h |
| 95 | 3.1.2.4 | Cahier des charges | milestone | 0d | 2008-05-05 | 2008-05-05 | 94 | 0d |  |

| ID | WBS | Task | Type | Duration | Start | Finish | Predecessors | Total slack | Free slack | Work |
| --- | --- | --- | --- | --- | --- | --- | --- | --- | --- | --- |
| 96 | 3.2 | **Mise en place de la gestion des stocks** |  | 30.5d | 2008-05-05 | 2008-06-23 |  | 25.5d |  | 146h |
| 97 | 3.2.1 | **Recherche progiciels** |  | 6d | 2008-05-05 | 2008-05-14 |  | 25.5d |  | 12h |
| 98 | 3.2.1.1 | Recherche des prestataires |  | 5d | 2008-05-05 | 2008-05-13 | 95 | 25.5d | 0d | 8h |
| 99 | 3.2.1.2 | Liste des prestataires | milestone | 0d | 2008-05-13 | 2008-05-13 | 98 | 25.5d | 0d |  |
| 100 | 3.2.1.3 | Présélection des progiciels |  | 1d | 2008-05-13 | 2008-05-14 | 99 | 25.5d | 0d | 4h |
| 101 | 3.2.1.4 | Liste des logiciels | milestone | 0d | 2008-05-14 | 2008-05-14 | 100 | 25.5d | 0d |  |
| 102 | 3.2.2 | **Choix progiciels** |  | 2d | 2008-05-14 | 2008-05-19 |  | 25.5d |  | 10h |
| 103 | 3.2.2.1 | Réalisation d'un dossier de choix |  | 1d | 2008-05-14 | 2008-05-15 | 101 | 25.5d | 0d | 4h |
| 104 | 3.2.2.2 | Choix du progiciel |  | 0.5d | 2008-05-15 | 2008-05-16 | 103 | 25.5d | 0d | 2h |
| 105 | 3.2.2.3 | Dossier de choix | milestone | 0d | 2008-05-16 | 2008-05-16 | 104 | 25.5d | 0d |  |
| 106 | 3.2.2.4 | Passage de la commande |  | 0.5d | 2008-05-16 | 2008-05-19 | 105 | 48d | 0d | 4h |
| 107 | 3.2.2.5 | Bon de commande | milestone | 0d | 2008-05-19 | 2008-05-19 | 106 | 48d |  |  |
| 108 | 3.2.3 | **Mise en place** |  | 4d | 2008-05-16 | 2008-05-23 |  | 44.5d |  | 36h |
| 109 | 3.2.3.1 | Commande des matériels |  | 0.5d | 2008-05-16 | 2008-05-19 | 105 | 44.5d | 0d | 2h |
| 110 | 3.2.3.2 | Bon de commande | milestone | 0d | 2008-05-19 | 2008-05-19 | 109 | 44.5d | 0d |  |
| 111 | 3.2.3.3 | Vérification des matériels |  | 1d | 2008-05-19 | 2008-05-20 | 110 | 44.5d | 0d | 8h |
| 112 | 3.2.3.4 | PV de réception | milestone | 0d | 2008-05-20 | 2008-05-20 | 111 | 44.5d | 0d |  |
| 113 | 3.2.3.5 | Installation des matériels |  | 1d | 2008-05-20 | 2008-05-21 | 112 | 44.5d | 0d | 8h |
| 114 | 3.2.3.6 | Installation du réseau |  | 1d | 2008-05-20 | 2008-05-21 | 112 | 44.5d | 0d | 8h |
| 115 | 3.2.3.7 | Partie matérielle installée | milestone | 0d | 2008-05-21 | 2008-05-21 | 114, 113 | 44.5d | 0d |  |
| 116 | 3.2.3.8 | Installation des systèmes d'exploitation |  | 1d | 2008-05-21 | 2008-05-22 | 115 | 44.5d | 0d | 8h |
| 117 | 3.2.3.9 | Installation du progiciel de gestion des stocks |  | 0.5d | 2008-05-22 | 2008-05-23 | 116 | 44.5d | 0d | 2h |
| 118 | 3.2.3.10 | Partie logicielle installée | milestone | 0d | 2008-05-23 | 2008-05-23 | 117 | 44.5d |  |  |
| 119 | 3.2.4 | **Paramétrage** |  | 7d | 2008-05-16 | 2008-05-28 |  | 25.5d |  | 36h |
| 120 | 3.2.4.1 | Définition des paramètres |  | 2d | 2008-05-16 | 2008-05-20 | 105 | 25.5d | 0d | 4h |
| 121 | 3.2.4.2 | Paramétrage du logiciel |  | 5d | 2008-05-20 | 2008-05-28 | 120 | 25.5d | 0d | 32h |
| 122 | 3.2.4.3 | Logiciel paramétré | milestone | 0d | 2008-05-28 | 2008-05-28 | 121 | 41.5d |  |  |

| ID | WBS | Task | Type | Duration | Start | Finish | Predecessors | Total slack | Free slack | Work |
| --- | --- | --- | --- | --- | --- | --- | --- | --- | --- | --- |
| 123 | 3.2.5 | **Tests** |  | 12d | 2008-05-16 | 2008-06-05 |  | 25.5d |  | 20h |
| 124 | 3.2.5.1 | Définition des données de test |  | 1d | 2008-05-16 | 2008-05-19 | 105 | 31.5d | 6d | 4h |
| 125 | 3.2.5.2 | Tests du logiciel |  | 5d | 2008-05-28 | 2008-06-05 | 121, 124 | 25.5d | 0d | 16h |
| 126 | 3.2.5.3 | Logiciel testé | milestone | 0d | 2008-06-05 | 2008-06-05 | 125 | 25.5d | 0d |  |
| 127 | 3.2.6 | **Recette** |  | 6d | 2008-06-05 | 2008-06-16 |  | 25.5d |  | 16h |
| 128 | 3.2.6.1 | Effectuer la recette |  | 1d | 2008-06-05 | 2008-06-06 | 126 | 25.5d | 0d | 8h |
| 129 | 3.2.6.2 | PV de recette | milestone | 0d | 2008-06-06 | 2008-06-06 | 128 | 25.5d | 0d |  |
| 130 | 3.2.6.3 | Mettre en production |  | 5d | 2008-06-06 | 2008-06-16 | 129 | 25.5d | 0d | 8h |
| 131 | 3.2.6.4 | Logiciel opérationnel | milestone | 0d | 2008-06-16 | 2008-06-16 | 130 | 25.5d | 0d |  |
| 132 | 3.2.7 | **Formation** |  | 5d | 2008-06-16 | 2008-06-23 |  | 25.5d |  | 16h |
| 133 | 3.2.7.1 | Former les utilisateurs |  | 5d | 2008-06-16 | 2008-06-23 | 131 | 25.5d | 0d | 16h |
| 134 | 3.2.7.2 | Utilisateurs formés | milestone | 0d | 2008-06-23 | 2008-06-23 | 133 | 25.5d |  |  |
| 135 | 3.3 | **Etude du site internet** |  | 11d | 2008-05-05 | 2008-05-22 |  | 0d |  | 52h |
| 136 | 3.3.1 | **Définition fonctions** |  | 5d | 2008-05-05 | 2008-05-13 |  | 0d |  | 16h |
| 137 | 3.3.1.1 | Définir les fonctions |  | 3d | 2008-05-05 | 2008-05-09 | 95 | 0d |  | 8h |
| 138 | 3.3.1.2 | Rédiger le cahier des charges |  | 2d | 2008-05-09 | 2008-05-13 | 137 | 0d |  | 8h |
| 139 | 3.3.1.3 | Cahier des charges | milestone | 0d | 2008-05-13 | 2008-05-13 | 138 | 0d |  |  |
| 140 | 3.3.2 | **Définition interfaces** |  | 6d | 2008-05-13 | 2008-05-22 |  | 0d |  | 36h |
| 141 | 3.3.2.1 | Faire les maquettes |  | 5d | 2008-05-13 | 2008-05-21 | 139 | 0d |  | 32h |
| 142 | 3.3.2.2 | Valider les maquettes |  | 1d | 2008-05-21 | 2008-05-22 | 141 | 0d |  | 4h |
| 143 | 3.3.2.3 | Maquettes validées | milestone | 0d | 2008-05-22 | 2008-05-22 | 142 | 0d |  |  |
| 144 | 3.4 | **Mise en place du site** |  | 18d | 2008-05-22 | 2008-06-20 |  | 0d |  | 204h |
| 145 | 3.4.1 | **Développements** |  | 16d | 2008-05-22 | 2008-06-17 |  | 0d |  | 196h |
| 146 | 3.4.1.1 | Définir le nombre de prototypes |  | 1d | 2008-05-22 | 2008-05-23 | 143 | 0d |  | 4h |
| 147 | 3.4.1.2 | Réaliser le prototype (n fois) |  | 15d | 2008-05-23 | 2008-06-17 | 146 | 0d |  | 64h |
| 148 | 3.4.1.3 | Tester le prototype (n fois) |  | 15d | 2008-05-23 | 2008-06-17 | 146 | 0d |  | 64h |
| 149 | 3.4.1.4 | Définir les améliorations (n fois) |  | 15d | 2008-05-23 | 2008-06-17 | 146 | 0d |  | 64h |
| 150 | 3.4.1.5 | Prototypes (n) | milestone | 0d | 2008-06-17 | 2008-06-17 | 147, 148, 149 | 0d |  |  |

| ID | WBS | Task | Type | Duration | Start | Finish | Predecessors | Total slack | Work |
| --- | --- | --- | --- | --- | --- | --- | --- | --- | --- |
| 151 | 3.4.2 | **Installation** |  | 2d | 2008-06-17 | 2008-06-20 |  | 0d | 8h |
| 152 | 3.4.2.1 | Réaliser l'installation avec le prestataire d'accès |  | 2d | 2008-06-17 | 2008-06-20 | 150 | 0d | 8h |
| 153 | 3.4.2.2 | Accès internet | milestone | 0d | 2008-06-20 | 2008-06-20 | 152 | 0d |  |
| 154 | 3.5 | **Mise en production du site** |  | 23d | 2008-06-20 | 2008-07-28 |  | 0d | 88h |
| 155 | 3.5.1 | **Test finaux** |  | 10d | 2008-06-20 | 2008-07-07 |  | 0d | 32h |
| 156 | 3.5.1.1 | Faire les tests finaux |  | 10d | 2008-06-20 | 2008-07-07 | 153 | 0d | 32h |
| 157 | 3.5.2 | **Recette** |  | 3d | 2008-07-07 | 2008-07-10 |  | 0d | 8h |
| 158 | 3.5.2.1 | Effectuer la recette |  | 3d | 2008-07-07 | 2008-07-10 | 156 | 0d | 8h |
| 159 | 3.5.2.2 | PV de recette | milestone | 0d | 2008-07-10 | 2008-07-10 | 158 | 0d |  |
| 160 | 3.5.3 | **Formation** |  | 10d | 2008-07-10 | 2008-07-28 |  | 0d | 48h |
| 161 | 3.5.3.1 | Elaborer la doc utilisateurs |  | 5d | 2008-07-10 | 2008-07-18 | 159 | 0d | 16h |
| 162 | 3.5.3.2 | Doc utilisateurs | milestone | 0d | 2008-07-18 | 2008-07-18 | 161 | 0d |  |
| 163 | 3.5.3.3 | Former les utilisateurs |  | 5d | 2008-07-18 | 2008-07-28 | 162 | 0d | 32h |
| 164 | 3.5.3.4 | Utilisateurs formés | milestone | 0d | 2008-07-28 | 2008-07-28 | 163 | 0d |  |
| 165 | 4 | **GESTION DU PROJET** |  | 67.35d | 2008-04-17 | 2008-08-01 |  | 0d | 11h |
| 166 | 4.1 | **Piloter le projet** |  | 1d | 2008-04-17 | 2008-04-18 |  | 66.35d |  |
| 167 | 4.1.1 | **Réalisation** |  | 1d | 2008-04-17 | 2008-04-18 |  | 66.35d |  |
| 168 | 4.1.1.1 | **Piloter la réalisation du produit** |  | 1d | 2008-04-17 | 2008-04-18 |  | 66.35d |  |
| 169 | 4.1.1.1.1 | Faire les réunions de comité de pilotage |  | 1d | 2008-04-17 | 2008-04-18 |  | 66.35d |  |
| 170 | 4.1.1.1.2 | Rapport flash | milestone | 0d | 2008-04-17 | 2008-04-17 |  | 67.35d |  |
| 171 | 4.1.1.1.3 | Faire les réunion avec l'équipe projet |  | 1d | 2008-04-17 | 2008-04-18 |  | 66.35d |  |
| 172 | 4.1.1.1.4 | Vérifier le reporting |  | 1d | 2008-04-17 | 2008-04-18 |  | 66.35d |  |
| 173 | 4.1.1.1.5 | Fiche de reporting (suite) | milestone | 0d | 2008-04-17 | 2008-04-17 |  | 67.35d |  |
| 174 | 4.1.1.1.6 | Mettre à jour la planning |  | 1d | 2008-04-17 | 2008-04-18 |  | 66.35d |  |
| 175 | 4.1.1.1.7 | Planning détaillé (suite) | milestone | 0d | 2008-04-17 | 2008-04-17 |  | 67.35d |  |
| 176 | 4.1.1.1.8 | Mettre à jour la documentation |  | 1d | 2008-04-17 | 2008-04-18 |  | 66.35d |  |
| 177 | 4.1.1.1.9 | œuvre en œuvre la communication |  | 1d | 2008-04-17 | 2008-04-18 |  | 66.35d |  |
| 178 | 4.1.1.1.10 | Faire un bilan intermédiaire |  | 1d | 2008-04-17 | 2008-04-18 |  | 66.35d |  |
| 179 | 4.1.1.1.11 | Bilan intermédiaire | milestone | 0d | 2008-04-17 | 2008-04-17 |  | 67.35d |  |

Notes:
- 166: Cette tâche contient toutes les tâches de pilotage, elle démarre au début de la réalisation et se termine à la fin de la réalisation

| ID | WBS | Task | Type | Duration | Start | Finish | Predecessors | Total slack | Work |
| --- | --- | --- | --- | --- | --- | --- | --- | --- | --- |
| 180 | 4.2 | **Faire le bilan du projet** |  | 4d | 2008-07-28 | 2008-08-01 |  | 0d | 11h |
| 181 | 4.2.1 | **Promotion** |  | 1d | 2008-07-28 | 2008-07-29 |  | 0d | 2h |
| 182 | 4.2.1.1 | Vendre le projet |  | 1d | 2008-07-28 | 2008-07-29 | 164 | 0d | 2h |
| 183 | 4.2.1.2 | Présentation de projet | milestone | 0d | 2008-07-29 | 2008-07-29 | 182 | 0d |  |
| 184 | 4.2.2 | **Désengagement** |  | 1d | 2008-07-29 | 2008-07-30 |  | 0d | 1h |
| 185 | 4.2.2.1 | Mettre un terme à l'engagement contractuel |  | 1d | 2008-07-29 | 2008-07-30 | 183 | 0d | 1h |
| 186 | 4.2.2.2 | Note de désengagement | milestone | 0d | 2008-07-30 | 2008-07-30 | 185 | 0d |  |
| 187 | 4.2.3 | **Capitalisation** |  | 2d | 2008-07-30 | 2008-08-01 |  | 0d | 8h |
| 188 | 4.2.3.1 | Organiser les réunions de débriefing |  | 1d | 2008-07-30 | 2008-07-31 | 186 | 0d | 4h |
| 189 | 4.2.3.2 | Bilan final de projet | milestone | 0d | 2008-07-31 | 2008-07-31 | 188 | 0d |  |
| 190 | 4.2.3.3 | Archiver les dossiers du projet |  | 1d | 2008-07-31 | 2008-08-01 | 189 | 0d | 4h |
| 191 | 4.2.3.4 | Note d’archivage | milestone | 0d | 2008-08-01 | 2008-08-01 | 190 | 0d |  |
| 192 | 5 | Fin du projet | milestone | 0d | 2008-08-01 | 2008-08-01 | 191 | 0d |  |
