# Projet X

Schedule from MS Project, 2008-04-17 to 2008-08-11, costs in F.
X

## Calendars

- Standard: Mon-Fri 08:00-12:00, 13:00-17:00; Sat-Sun off.

## Resources

| Resource | Group | Rate | Cost per use |
| --- | --- | --- | --- |
| Karen | Epr | 700 |  |
| Christophe | Epr | 600 |  |
| Henri | Cpi |  |  |
| Philippe | Cpi |  |  |
| Patrick | Cpi |  |  |
| Claudio | Exp | 500 |  |
| François | Exp | 500 |  |
| Infographiste | Res | 400 |  |
| Programmeur 1 | Res | 300 |  |
| Programmeur 2 | Res | 300 |  |
| Machine de développement 1 | Mat |  | 200 |
| Machine de développement 2 | Mat |  | 200 |
| Machine de développement 3 | Mat |  | 200 |

## Schedule

| ID | WBS | Task | Type | Duration | Start | Finish | Predecessors | Total slack | Free slack | Resources | Work | Cost |
| --- | --- | --- | --- | --- | --- | --- | --- | --- | --- | --- | --- | --- |
| 1 | 1 | Début du projet | milestone | 0d | 2008-04-17 08:00 | 2008-04-17 08:00 |  | 72.6d |  |  |  |  |
| 2 | 2 | **GESTION DU PROJET** |  | 7.35d | 2008-04-17 09:00 | 2008-04-29 11:48 |  | 0d |  |  | 49.35h | 25,595 |
| 3 | 2.1 | **Initialiser le projet** |  | 1.75d | 2008-04-17 09:00 | 2008-04-18 18:00 |  | 0d |  |  | 7h | 2,100 |
| 4 | 2.1.1 | **Réception** |  | 0.5d | 2008-04-17 09:00 | 2008-04-17 15:00 |  | 0d |  |  | 4h | 1,400 |
| 5 | 2.1.1.1 | Réceptionner la demande de projet du commanditaire |  | 0.25d | 2008-04-17 09:00 | 2008-04-17 11:00 |  | 0d |  | Henri | 2h |  |
| 6 | 2.1.1.2 | Demande de projet du commanditaire | milestone | 0d | 2008-04-17 11:00 | 2008-04-17 11:00 | 5 | 0d |  |  |  |  |
| 7 | 2.1.1.3 | Examiner la demande du commanditaire |  | 0.25d | 2008-04-17 11:00 | 2008-04-17 15:00 | 6 | 0d |  | Karen | 2h | 1,400 |
| 8 | 2.1.1.4 | Réponse à la demande de projet | milestone | 0d | 2008-04-17 15:00 | 2008-04-17 15:00 | 7 | 72.1d |  |  |  |  |
| 9 | 2.1.2 | **Affectation** |  | 1.25d | 2008-04-17 15:00 | 2008-04-18 18:00 |  | 0d |  |  | 3h | 700 |
| 10 | 2.1.2.1 | Officialiser la nomination du chef de projet |  | 0.25d | 2008-04-17 15:00 | 2008-04-17 17:00 | 7 | 0d |  | Karen [50%]; Henri | 3h | 700 |
| 11 | 2.1.2.2 | Note d’affectation du chef de projet | milestone | 0d | 2008-04-18 18:00 | 2008-04-18 18:00 | 10FS+1d | 0d |  |  |  |  |
| 12 | 2.2 | **Préparer le projet** |  | 4d | 2008-04-21 09:00 | 2008-04-25 15:00 |  | 0d |  |  | 28h | 14,600 |
| 13 | 2.2.1 | **Objet** |  | 0.25d | 2008-04-21 09:00 | 2008-04-21 11:00 |  | 0d |  |  | 2h | 1,400 |
| 14 | 2.2.1.1 | Définir l’objet précis du projet |  | 0.25d | 2008-04-21 09:00 | 2008-04-21 11:00 | 11 | 70.6d | 0d | Karen [50%] | 1h | 700 |
| 15 | 2.2.1.2 | Note de cadrage | milestone | 0d | 2008-04-21 11:00 | 2008-04-21 11:00 | 14 | 70.6d |  |  |  |  |
| 16 | 2.2.1.3 | Lister les motifs et définir le contexte |  | 0.25d | 2008-04-21 09:00 | 2008-04-21 11:00 | 11 | 0d |  | Karen [50%] | 1h | 700 |
| 17 | 2.2.1.4 | Note de cadrage (suite) | milestone | 0d | 2008-04-21 11:00 | 2008-04-21 11:00 | 16 | 0d |  |  |  |  |
| 18 | 2.2.2 | **Objectifs** |  | 0.75d | 2008-04-22 14:00 | 2008-04-23 11:00 |  | 0d |  |  | 12h | 5,750 |
| 19 | 2.2.2.1 | Définir les objectifs de qualité |  | 0.25d | 2008-04-22 14:00 | 2008-04-22 16:00 | 17FS+1d | 69.35d | 0d | Karen [150%]; Henri [150%] | 6h | 2,100 |
| 20 | 2.2.2.2 | Note de cadrage (suite) | milestone | 0d | 2008-04-22 16:00 | 2008-04-22 16:00 | 19 | 69.35d |  |  |  |  |
| 21 | 2.2.2.3 | Définir les objectifs de temps |  | 0.25d | 2008-04-22 14:00 | 2008-04-22 16:00 | 17FS+1d | 69.35d | 0d | Karen [50%] | 1h | 700 |
| 22 | 2.2.2.4 | macro-planning | milestone | 0d | 2008-04-22 16:00 | 2008-04-22 16:00 | 21 | 69.35d |  |  |  |  |
| 23 | 2.2.2.5 | Définir les objectifs de charge et de coûts |  | 0.25d | 2008-04-22 14:00 | 2008-04-22 16:00 | 17FS+1d | 69.1d | 0d | Karen [50%] | 1h | 700 |
| 24 | 2.2.2.6 | macro-planning de charge | milestone | 0d | 2008-04-22 16:00 | 2008-04-22 16:00 | 23 | 69.35d |  |  |  |  |
| 25 | 2.2.2.7 | Budget prévisionnel | milestone | 0d | 2008-04-22 16:00 | 2008-04-22 16:00 | 23 | 69.35d |  |  |  |  |
| 26 | 2.2.2.8 | Définir les objectifs de communication |  | 0.25d | 2008-04-22 16:00 | 2008-04-22 18:00 | 23 | 69.1d | 0d | Christophe | 2h | 1,200 |
| 27 | 2.2.2.9 | Stratégie de communication | milestone | 0d | 2008-04-22 18:00 | 2008-04-22 18:00 | 26 | 69.1d |  |  |  |  |
| 28 | 2.2.2.10 | Définir les objectifs complémentaires |  | 0.25d | 2008-04-22 14:00 | 2008-04-22 16:00 | 17FS+1d | 0d |  | Karen [12.5%]; Henri [12.5%] | 0.5h | 175 |
| 29 | 2.2.2.11 | Note de cadrage (suite) | milestone | 0d | 2008-04-22 16:00 | 2008-04-22 16:00 | 28 | 0d |  |  |  |  |
| 30 | 2.2.2.12 | Préciser les contraintes sur objectifs |  | 0.25d | 2008-04-22 16:00 | 2008-04-22 18:00 | 29 | 0d |  | Karen [12.5%]; Henri [12.5%] | 0.5h | 175 |
| 31 | 2.2.2.13 | Note de cadrage (suite) | milestone | 0d | 2008-04-22 18:00 | 2008-04-22 18:00 | 30 | 0d |  |  |  |  |
| 32 | 2.2.2.14 | Vérifier l’adéquation entre les objectifs |  | 0.25d | 2008-04-23 09:00 | 2008-04-23 11:00 | 31 | 0d |  | Karen [50%] | 1h | 700 |
| 33 | 2.2.2.15 | Note de cadrage (suite) | milestone | 0d | 2008-04-23 11:00 | 2008-04-23 11:00 | 32 | 0d |  |  |  |  |

| ID | WBS | Task | Type | Duration | Start | Finish | Predecessors | Total slack | Free slack | Resources | Work | Cost |
| --- | --- | --- | --- | --- | --- | --- | --- | --- | --- | --- | --- | --- |
| 34 | 2.2.3 | **Domaine** |  | 1.25d | 2008-04-23 11:00 | 2008-04-24 16:00 |  | 0d |  |  | 5h | 3,500 |
| 35 | 2.2.3.1 | Identifier le périmètre et les acteurs |  | 1d | 2008-04-23 11:00 | 2008-04-24 12:00 | 33 | 0d |  | Karen [50%] | 4h | 2,800 |
| 36 | 2.2.3.2 | Fichier des acteurs | milestone | 0d | 2008-04-24 12:00 | 2008-04-24 12:00 | 35 | 67.85d |  |  |  |  |
| 37 | 2.2.3.3 | Définir la structure choisie pour la gestion du projet |  | 0.25d | 2008-04-24 10:00 | 2008-04-24 12:00 | 33, 35FF | 0d |  | Karen [25%] | 0.5h | 350 |
| 38 | 2.2.3.4 | Organigramme Projet | milestone | 0d | 2008-04-24 12:00 | 2008-04-24 12:00 | 37 | 0d |  |  |  |  |
| 39 | 2.2.3.5 | Définir les rôles des acteurs dans les structures projets |  | 0.25d | 2008-04-24 14:00 | 2008-04-24 16:00 | 38 | 0d |  | Karen [25%] | 0.5h | 350 |
| 40 | 2.2.3.6 | Fiche de poste | milestone | 0d | 2008-04-24 16:00 | 2008-04-24 16:00 | 39 | 67.6d |  |  |  |  |
| 41 | 2.2.3.7 | Carte des acteurs | milestone | 0d | 2008-04-24 16:00 | 2008-04-24 16:00 | 39 | 0d |  |  |  |  |
| 42 | 2.2.4 | **Risques** |  | 0.25d | 2008-04-24 16:00 | 2008-04-24 18:00 |  | 0d |  |  | 3h | 1,050 |
| 43 | 2.2.4.1 | Identifier, analyser et gérer les freins |  | 0.25d | 2008-04-24 16:00 | 2008-04-24 18:00 | 41 | 0d |  | Karen [50%]; Henri [50%] | 2h | 700 |
| 44 | 2.2.4.2 | Grille des freins | milestone | 0d | 2008-04-24 18:00 | 2008-04-24 18:00 | 43 | 0d |  |  |  |  |
| 45 | 2.2.4.3 | Identifier, analyser et gérer les facilitants |  | 0.25d | 2008-04-24 16:00 | 2008-04-24 18:00 | 41 | 67.35d |  | Karen [25%]; Henri [25%] | 1h | 350 |
| 46 | 2.2.4.4 | Grille des facilitants | milestone | 0d | 2008-04-24 18:00 | 2008-04-24 18:00 | 44 | 0d |  |  |  |  |
| 47 | 2.2.5 | **Méthode** |  | 0.25d | 2008-04-24 16:00 | 2008-04-24 18:00 |  | 67.35d |  |  | 2h | 1,000 |
| 48 | 2.2.5.1 | Choisir une méthode et structurer la réal. du produit |  | 0.25d | 2008-04-24 16:00 | 2008-04-24 18:00 | 41 | 67.35d | 0d | Claudio [50%]; François [50%] | 2h | 1,000 |
| 49 | 2.2.5.2 | Fiche méthode | milestone | 0d | 2008-04-24 18:00 | 2008-04-24 18:00 | 48 | 67.35d |  |  |  |  |
| 50 | 2.2.6 | **Communication** |  | 0.25d | 2008-04-25 09:00 | 2008-04-25 11:00 |  | 0d |  |  | 2h | 1,200 |
| 51 | 2.2.6.1 | Définir les axes, cibles et moyens de communication |  | 0.25d | 2008-04-25 09:00 | 2008-04-25 11:00 | 46 | 0d |  | Christophe | 2h | 1,200 |
| 52 | 2.2.6.2 | Charte graphique | milestone | 0d | 2008-04-25 11:00 | 2008-04-25 11:00 | 51 | 67.1d |  |  |  |  |
| 53 | 2.2.6.3 | Plan de communication | milestone | 0d | 2008-04-25 11:00 | 2008-04-25 11:00 | 51 | 0d |  |  |  |  |
| 54 | 2.2.7 | **Contractualisation** |  | 0.25d | 2008-04-25 11:00 | 2008-04-25 15:00 |  | 0d |  |  | 2h | 700 |
| 55 | 2.2.7.1 | Rédiger la note de cadrage |  | 0.25d | 2008-04-25 11:00 | 2008-04-25 15:00 | 53 | 0d |  | Henri [50%]; Karen [50%] | 2h | 700 |
| 56 | 2.2.7.2 | Note de cadrage (suite) | milestone | 0d | 2008-04-25 15:00 | 2008-04-25 15:00 | 55 | 0d |  |  |  |  |
| 57 | 2.3 | **Planifier le projet** |  | 1.1d | 2008-04-25 15:00 | 2008-04-28 16:48 |  | 0d |  |  | 11.35h | 7,045 |
| 58 | 2.3.1 | **Planification détallée** |  | 0.6d | 2008-04-25 15:00 | 2008-04-28 10:48 |  | 0d |  |  | 6.35h | 4,045 |
| 59 | 2.3.1.1 | Définir l’environnement de planification |  | 0.1d | 2008-04-25 15:00 | 2008-04-25 15:48 | 56 | 0d |  | Karen [62.5%] | 0.5h | 350 |
| 60 | 2.3.1.2 | Charte de planification | milestone | 0d | 2008-04-25 15:48 | 2008-04-25 15:48 | 59 | 0d |  |  |  |  |
| 61 | 2.3.1.3 | Ordonner la liste des tâches de fabrication du produit |  | 0.1d | 2008-04-25 15:48 | 2008-04-25 16:36 | 60 | 0d |  | Karen [125%]; Claudio [125%]; François [125%] | 3h | 1,700 |
| 62 | 2.3.1.4 | Organigramme des tâches | milestone | 0d | 2008-04-25 16:36 | 2008-04-25 16:36 | 61 | 0d |  |  |  |  |
| 63 | 2.3.1.5 | Affecter des durées ou des charges aux tâches |  | 0.1d | 2008-04-25 16:36 | 2008-04-25 17:24 | 62 | 0d |  | Karen [62.5%] | 0.5h | 350 |
| 64 | 2.3.1.6 | Planning détaillé | milestone | 0d | 2008-04-25 17:24 | 2008-04-25 17:24 | 63 | 0d |  |  |  |  |
| 65 | 2.3.1.7 | Définir les liens entre les tâches |  | 0.1d | 2008-04-25 17:24 | 2008-04-28 09:12 | 64 | 0d |  | Karen [31.2%] | 0.25h | 175 |
| 66 | 2.3.1.8 | Planning détaillé (suite) | milestone | 0d | 2008-04-28 09:12 | 2008-04-28 09:12 | 65 | 0d |  |  |  |  |
| 67 | 2.3.1.9 | Intégrer les tâches de gestion de projet |  | 0.1d | 2008-04-28 09:12 | 2008-04-28 10:00 | 66 | 0d |  | Karen [12.5%] | 0.1h | 70 |
| 68 | 2.3.1.10 | Planning détaillé (suite) | milestone | 0d | 2008-04-28 10:00 | 2008-04-28 10:00 | 67 | 0d |  |  |  |  |
| 69 | 2.3.1.11 | Affecter les ressources sur les tâches |  | 0.1d | 2008-04-28 10:00 | 2008-04-28 10:48 | 68 | 0d |  | Karen [250%] | 2h | 1,400 |
| 70 | 2.3.1.12 | Tableau des ressources | milestone | 0d | 2008-04-28 10:48 | 2008-04-28 10:48 | 69 | 0d |  |  |  |  |
| 71 | 2.3.1.13 | Planning détaillé (suite) | milestone | 0d | 2008-04-28 10:48 | 2008-04-28 10:48 | 70 | 0d |  |  |  |  |

| ID | WBS | Task | Type | Duration | Start | Finish | Predecessors | Total slack | Resources | Work | Cost |
| --- | --- | --- | --- | --- | --- | --- | --- | --- | --- | --- | --- |
| 72 | 2.3.2 | **Validation** |  | 0.5d | 2008-04-28 10:48 | 2008-04-28 16:48 |  | 0d |  | 5h | 3,000 |
| 73 | 2.3.2.1 | Optimiser le planning détaillé du prévu |  | 0.25d | 2008-04-28 10:48 | 2008-04-28 14:48 | 71 | 0d | Karen [50%]; Claudio [50%]; François [50%] | 3h | 1,700 |
| 74 | 2.3.2.2 | Planning détaillé (suite) | milestone | 0d | 2008-04-28 14:48 | 2008-04-28 14:48 | 73 | 0d |  |  |  |
| 75 | 2.3.2.3 | Valider, communiquer et enregistrer le planning |  | 0.25d | 2008-04-28 14:48 | 2008-04-28 16:48 | 74 | 0d | Karen [50%]; Christophe [50%] | 2h | 1,300 |
| 76 | 2.3.2.4 | Contrat de planning | milestone | 0d | 2008-04-28 16:48 | 2008-04-28 16:48 | 75 | 0d |  |  |  |
| 77 | 2.4 | **Piloter le projet** |  | 0.5d | 2008-04-28 16:48 | 2008-04-29 11:48 |  | 0d |  | 3h | 1,850 |
| 78 | 2.4.1 | **Lancement** |  | 0.5d | 2008-04-28 16:48 | 2008-04-29 11:48 |  | 0d |  | 3h | 1,850 |
| 79 | 2.4.1.1 | Lancer la réalisation |  | 0.25d | 2008-04-28 16:48 | 2008-04-29 09:48 | 76 | 0d | Karen [25%]; Christophe [25%] | 1h | 650 |
| 80 | 2.4.1.2 | Journal du projet | milestone | 0d | 2008-04-29 09:48 | 2008-04-29 09:48 | 79 | 0d |  |  |  |
| 81 | 2.4.1.3 | Fiche de reporting | milestone | 0d | 2008-04-29 09:48 | 2008-04-29 09:48 | 80 | 0d |  |  |  |
| 82 | 2.4.1.4 | Mettre en œuvre le plan de communication |  | 0.25d | 2008-04-29 09:48 | 2008-04-29 11:48 | 81 | 0d | Christophe | 2h | 1,200 |
| 83 | 2.4.1.5 | Plan de communication (suite) | milestone | 0d | 2008-04-29 11:48 | 2008-04-29 11:48 | 82 | 0d |  |  |  |
| 84 | 3 | **FABRICATION DU PRODUIT** |  | 61.25d | 2008-04-29 11:48 | 2008-08-05 11:48 |  | 0d |  | 1305h | 281,860 |
| 85 | 3.1 | **Etude de la gestion des stocks** |  | 4d | 2008-04-29 11:48 | 2008-05-05 17:48 |  | 0d |  | 20h |  |
| 86 | 3.1.1 | **Etude opérationnelle** |  | 2d | 2008-04-29 11:48 | 2008-05-01 15:48 |  | 0d |  | 8h |  |
| 87 | 3.1.1.1 | Analyse de l'existant |  | 1d | 2008-04-29 11:48 | 2008-04-30 14:48 | 83 | 0d | Patrick [50%] | 4h |  |
| 88 | 3.1.1.2 | Feuille d'analyse | milestone | 0d | 2008-04-30 14:48 | 2008-04-30 14:48 | 87 | 0d |  |  |  |
| 89 | 3.1.1.3 | Recherche des améliorations |  | 1d | 2008-04-30 14:48 | 2008-05-01 15:48 | 88 | 0d | Patrick [50%] | 4h |  |
| 90 | 3.1.1.4 | Liste des améliorations | milestone | 0d | 2008-05-01 15:48 | 2008-05-01 15:48 | 89 | 0d |  |  |  |
| 91 | 3.1.2 | **Etude fonctionnelle** |  | 4d | 2008-04-29 11:48 | 2008-05-05 17:48 |  | 0d |  | 12h |  |
| 92 | 3.1.2.1 | Analyse de l'existant |  | 1d | 2008-04-29 11:48 | 2008-04-30 14:48 | 83 | 1d | Henri [50%] | 4h |  |
| 93 | 3.1.2.2 | Organigramme fonctionnel | milestone | 0d | 2008-05-01 15:48 | 2008-05-01 15:48 | 92, 90 | 0d |  |  |  |
| 94 | 3.1.2.3 | Rédaction du cahier des charges |  | 2d | 2008-05-01 15:48 | 2008-05-05 17:48 | 93 | 0d | Henri [50%] | 8h |  |
| 95 | 3.1.2.4 | Cahier des charges | milestone | 0d | 2008-05-05 17:48 | 2008-05-05 17:48 | 94 | 0d |  |  |  |

| ID | WBS | Task | Type | Duration | Start | Finish | Predecessors | Total slack | Free slack | Resources | Work | Cost |
| --- | --- | --- | --- | --- | --- | --- | --- | --- | --- | --- | --- | --- |
| 96 | 3.2 | **Mise en place de la gestion des stocks** |  | 42.75d | 2008-05-05 17:48 | 2008-07-11 16:48 |  | 18.5d |  |  | 289h | 67,700 |
| 97 | 3.2.1 | **Recherche progiciels** |  | 6d | 2008-05-05 17:48 | 2008-05-14 16:48 |  | 18.5d |  |  | 12h | 6,000 |
| 98 | 3.2.1.1 | Recherche des prestataires |  | 5d | 2008-05-05 17:48 | 2008-05-13 15:48 | 95 | 18.5d | 0d | Claudio [20%] | 8h | 4,000 |
| 99 | 3.2.1.2 | Liste des prestataires | milestone | 0d | 2008-05-13 15:48 | 2008-05-13 15:48 | 98 | 18.5d | 0d |  |  |  |
| 100 | 3.2.1.3 | Présélection des progiciels |  | 1d | 2008-05-13 15:48 | 2008-05-14 16:48 | 99 | 18.5d | 0d | Claudio [50%] | 4h | 2,000 |
| 101 | 3.2.1.4 | Liste des logiciels | milestone | 0d | 2008-05-14 16:48 | 2008-05-14 16:48 | 100 | 18.5d | 0d |  |  |  |
| 102 | 3.2.2 | **Choix progiciels** |  | 1.75d | 2008-05-14 16:48 | 2008-05-16 16:48 |  | 18.5d |  |  | 11h | 2,500 |
| 103 | 3.2.2.1 | Réalisation d'un dossier de choix |  | 1d | 2008-05-14 16:48 | 2008-05-15 17:48 | 101 | 18.5d | 0d | Claudio [50%] | 4h | 2,000 |
| 104 | 3.2.2.2 | Choix du progiciel |  | 0.25d | 2008-05-15 17:48 | 2008-05-16 10:48 | 103 | 18.5d | 0d | Claudio [50%]; Henri; Patrick | 3h | 500 |
| 105 | 3.2.2.3 | Dossier de choix | milestone | 0d | 2008-05-16 10:48 | 2008-05-16 10:48 | 104 | 18.5d | 0d |  |  |  |
| 106 | 3.2.2.4 | Passage de la commande |  | 0.5d | 2008-05-16 10:48 | 2008-05-16 16:48 | 105 | 53.5d | 0d | Henri | 4h |  |
| 107 | 3.2.2.5 | Bon de commande | milestone | 0d | 2008-05-16 16:48 | 2008-05-16 16:48 | 106 | 53.5d |  |  |  |  |
| 108 | 3.2.3 | **Mise en place** |  | 6.5d | 2008-05-16 10:48 | 2008-05-27 15:48 |  | 47.5d |  |  | 54h | 23,000 |
| 109 | 3.2.3.1 | Commande des matériels |  | 0.5d | 2008-05-16 10:48 | 2008-05-16 16:48 | 105 | 47.5d | 0d | Claudio [50%] | 2h | 1,000 |
| 110 | 3.2.3.2 | Bon de commande | milestone | 0d | 2008-05-16 16:48 | 2008-05-16 16:48 | 109 | 47.5d | 0d |  |  |  |
| 111 | 3.2.3.3 | Vérification des matériels |  | 1d | 2008-05-16 16:48 | 2008-05-19 17:48 | 110 | 47.5d | 0d | Programmeur 1 | 8h | 2,400 |
| 112 | 3.2.3.4 | PV de réception | milestone | 0d | 2008-05-19 17:48 | 2008-05-19 17:48 | 111 | 47.5d | 0d |  |  |  |
| 113 | 3.2.3.5 | Installation des matériels |  | 1d | 2008-05-19 17:48 | 2008-05-21 09:48 | 112 | 48.5d | 1d | Programmeur 2 | 8h | 2,400 |
| 114 | 3.2.3.6 | Installation du réseau |  | 2d | 2008-05-19 17:48 | 2008-05-22 10:48 | 112 | 47.5d | 0d | Claudio | 16h | 8,000 |
| 115 | 3.2.3.7 | Partie matérielle installée | milestone | 0d | 2008-05-22 10:48 | 2008-05-22 10:48 | 114, 113 | 47.5d | 0d |  |  |  |
| 116 | 3.2.3.8 | Installation des systèmes d'exploitation |  | 2d | 2008-05-22 10:48 | 2008-05-26 14:48 | 115 | 47.5d | 0d | Claudio | 16h | 8,000 |
| 117 | 3.2.3.9 | Installation du progiciel de gestion des stocks |  | 1d | 2008-05-26 14:48 | 2008-05-27 15:48 | 116 | 47.5d | 0d | Programmeur 2 [50%] | 4h | 1,200 |
| 118 | 3.2.3.10 | Partie logicielle installée | milestone | 0d | 2008-05-27 15:48 | 2008-05-27 15:48 | 117 | 47.5d |  |  |  |  |
| 119 | 3.2.4 | **Paramétrage** |  | 12d | 2008-05-16 10:48 | 2008-06-04 17:48 |  | 18.5d |  |  | 132h | 19,400 |
| 120 | 3.2.4.1 | Définition des paramètres |  | 2d | 2008-05-16 10:48 | 2008-05-20 14:48 | 105 | 18.5d | 0d | Patrick [25%] | 4h |  |
| 121 | 3.2.4.2 | Paramétrage du logiciel |  | 10d | 2008-05-20 14:48 | 2008-06-04 17:48 | 120 | 18.5d | 0d | Programmeur 2 [80%]; Machine de développement 3 | 128h | 19,400 |
| 122 | 3.2.4.3 | Logiciel paramétré | milestone | 0d | 2008-06-04 17:48 | 2008-06-04 17:48 | 121 | 42d |  |  |  |  |

| ID | WBS | Task | Type | Duration | Start | Finish | Predecessors | Total slack | Free slack | Resources | Work | Cost |
| --- | --- | --- | --- | --- | --- | --- | --- | --- | --- | --- | --- | --- |
| 123 | 3.2.5 | **Tests** |  | 14.5d | 2008-05-16 10:48 | 2008-06-09 16:48 |  | 18.5d |  |  | 24h | 2,400 |
| 124 | 3.2.5.1 | Définition des données de test |  | 2d | 2008-05-16 10:48 | 2008-05-20 14:48 | 105 | 28.5d | 10d | Patrick [50%] | 8h |  |
| 125 | 3.2.5.2 | Tests du logiciel |  | 2.5d | 2008-06-04 17:48 | 2008-06-09 16:48 | 121, 124 | 18.5d | 0d | Patrick [40%]; Programmeur 2 | 16h | 2,400 |
| 126 | 3.2.5.3 | Logiciel testé | milestone | 0d | 2008-06-09 16:48 | 2008-06-09 16:48 | 125 | 18.5d | 0d |  |  |  |
| 127 | 3.2.6 | **Recette** |  | 11d | 2008-06-09 16:48 | 2008-06-26 11:48 |  | 18.5d |  |  | 24h | 4,800 |
| 128 | 3.2.6.1 | Effectuer la recette |  | 1d | 2008-06-09 16:48 | 2008-06-10 17:48 | 126 | 18.5d | 0d | Henri | 8h |  |
| 129 | 3.2.6.2 | PV de recette | milestone | 0d | 2008-06-10 17:48 | 2008-06-10 17:48 | 128 | 18.5d | 0d |  |  |  |
| 130 | 3.2.6.3 | Mettre en production |  | 10d | 2008-06-10 17:48 | 2008-06-26 11:48 | 129 | 18.5d | 0d | Programmeur 2 [20%] | 16h | 4,800 |
| 131 | 3.2.6.4 | Logiciel opérationnel | milestone | 0d | 2008-06-26 11:48 | 2008-06-26 11:48 | 130 | 18.5d | 0d |  |  |  |
| 132 | 3.2.7 | **Formation** |  | 10d | 2008-06-26 11:48 | 2008-07-11 16:48 |  | 18.5d |  |  | 32h | 9,600 |
| 133 | 3.2.7.1 | Former les utilisateurs |  | 10d | 2008-06-26 11:48 | 2008-07-11 16:48 | 131 | 18.5d | 0d | Programmeur 2 [40%] | 32h | 9,600 |
| 134 | 3.2.7.2 | Utilisateurs formés | milestone | 0d | 2008-07-11 16:48 | 2008-07-11 16:48 | 133 | 18.5d |  |  |  |  |
| 135 | 3.3 | **Etude du site internet** |  | 12.25d | 2008-05-05 17:48 | 2008-05-23 17:48 |  | 0d |  |  | 60h | 20,000 |
| 136 | 3.3.1 | **Définition fonctions** |  | 5d | 2008-05-05 17:48 | 2008-05-13 15:48 |  | 0d |  |  | 16h |  |
| 137 | 3.3.1.1 | Définir les fonctions |  | 3d | 2008-05-05 17:48 | 2008-05-09 11:48 | 95 | 0d |  | Henri [33.3%] | 8h |  |
| 138 | 3.3.1.2 | Rédiger le cahier des charges |  | 2d | 2008-05-09 11:48 | 2008-05-13 15:48 | 137 | 0d |  | Henri [50%] | 8h |  |
| 139 | 3.3.1.3 | Cahier des charges | milestone | 0d | 2008-05-13 15:48 | 2008-05-13 15:48 | 138 | 0d |  |  |  |  |
| 140 | 3.3.2 | **Définition interfaces** |  | 7.25d | 2008-05-13 15:48 | 2008-05-23 17:48 |  | 0d |  |  | 44h | 20,000 |
| 141 | 3.3.2.1 | Faire les maquettes |  | 6.25d | 2008-05-13 15:48 | 2008-05-22 16:48 | 139 | 0d |  | François [80%] | 40h | 20,000 |
| 142 | 3.3.2.2 | Valider les maquettes |  | 1d | 2008-05-22 16:48 | 2008-05-23 17:48 | 141 | 0d |  | Henri [50%] | 4h |  |
| 143 | 3.3.2.3 | Maquettes validées | milestone | 0d | 2008-05-23 17:48 | 2008-05-23 17:48 | 142 | 0d |  |  |  |  |
| 144 | 3.4 | **Mise en place du site** |  | 22d | 2008-05-23 17:48 | 2008-06-30 09:48 |  | 0d |  |  | 736h | 149,200 |
| 145 | 3.4.1 | **Développements** |  | 16d | 2008-05-23 17:48 | 2008-06-19 10:48 |  | 0d |  |  | 712h | 137,200 |
| 146 | 3.4.1.1 | Définir le nombre de prototypes |  | 1d | 2008-05-23 17:48 | 2008-05-27 09:48 | 143 | 0d |  | Henri [50%]; François | 8h | 2,000 |
| 147 | 3.4.1.2 | Réaliser le prototype (n fois) |  | 15d | 2008-05-27 09:48 | 2008-06-19 10:48 | 146 | 0d |  | Infographiste [53.3%]; Programmeur 1; Machine de développement 1; Machine de développement 2 | 256h | 45,200 |
| 148 | 3.4.1.3 | Tester le prototype (n fois) |  | 15d | 2008-05-27 09:48 | 2008-06-19 10:48 | 146 | 0d |  | Infographiste [53.3%]; Programmeur 1; Machine de développement 1; Machine de développement 2 | 256h | 45,200 |
| 149 | 3.4.1.4 | Définir les améliorations (n fois) |  | 15d | 2008-05-27 09:48 | 2008-06-19 10:48 | 146 | 0d |  | Henri [53.3%]; Infographiste; Programmeur 2 | 192h | 44,800 |
| 150 | 3.4.1.5 | Prototypes (n) | milestone | 0d | 2008-06-19 10:48 | 2008-06-19 10:48 | 147, 148, 149 | 0d |  |  |  |  |

| ID | WBS | Task | Type | Duration | Start | Finish | Predecessors | Total slack | Constraint | Resources | Work | Cost |
| --- | --- | --- | --- | --- | --- | --- | --- | --- | --- | --- | --- | --- |
| 151 | 3.4.2 | **Installation** |  | 6d | 2008-06-19 10:48 | 2008-06-30 09:48 |  | 0d |  |  | 24h | 12,000 |
| 152 | 3.4.2.1 | Réaliser l'installation avec le prestataire d'accès |  | 6d | 2008-06-19 10:48 | 2008-06-30 09:48 | 150 | 0d |  | François [50%] | 24h | 12,000 |
| 153 | 3.4.2.2 | Accès internet | milestone | 0d | 2008-06-30 09:48 | 2008-06-30 09:48 | 152 | 0d |  |  |  |  |
| 154 | 3.5 | **Mise en production du site** |  | 23d | 2008-06-30 09:48 | 2008-08-05 11:48 |  | 0d |  |  | 200h | 44,960 |
| 155 | 3.5.1 | **Test finaux** |  | 10d | 2008-06-30 09:48 | 2008-07-15 14:48 |  | 0d |  |  | 128h | 19,360 |
| 156 | 3.5.1.1 | Faire les tests finaux |  | 10d | 2008-06-30 09:48 | 2008-07-15 14:48 | 153 | 0d |  | Programmeur 2 [80%]; Machine de développement 3 [80%] | 128h | 19,360 |
| 157 | 3.5.2 | **Recette** |  | 3d | 2008-07-15 14:48 | 2008-07-18 17:48 |  | 0d |  |  | 8h |  |
| 158 | 3.5.2.1 | Effectuer la recette |  | 3d | 2008-07-15 14:48 | 2008-07-18 17:48 | 156 | 0d |  | Henri [33.3%] | 8h |  |
| 159 | 3.5.2.2 | PV de recette | milestone | 0d | 2008-07-18 17:48 | 2008-07-18 17:48 | 158 | 0d |  |  |  |  |
| 160 | 3.5.3 | **Formation** |  | 10d | 2008-07-18 17:48 | 2008-08-05 11:48 |  | 0d |  |  | 64h | 25,600 |
| 161 | 3.5.3.1 | Elaborer la doc utilisateurs |  | 5d | 2008-07-18 17:48 | 2008-07-28 15:48 | 159 | 0d |  | François [80%] | 32h | 16,000 |
| 162 | 3.5.3.2 | Doc utilisateurs | milestone | 0d | 2008-07-28 15:48 | 2008-07-28 15:48 | 161 | 0d |  |  |  |  |
| 163 | 3.5.3.3 | Former les utilisateurs |  | 5d | 2008-07-28 15:48 | 2008-08-05 11:48 | 162 | 0d |  | Programmeur 2 [80%] | 32h | 9,600 |
| 164 | 3.5.3.4 | Utilisateurs formés | milestone | 0d | 2008-08-05 11:48 | 2008-08-05 11:48 | 163 | 0d |  |  |  |  |
| 165 | 4 | **GESTION DU PROJET** |  | 72.6d | 2008-04-17 08:00 | 2008-08-11 17:48 |  | 0d |  |  | 65h | 27,850 |
| 166 | 4.1 | **Piloter le projet** |  | 69.6d | 2008-04-17 08:00 | 2008-08-06 14:48 |  | 3d |  |  | 30h | 8,800 |
| 167 | 4.1.1 | **Réalisation** |  | 69.6d | 2008-04-17 08:00 | 2008-08-06 14:48 |  | 3d |  |  | 30h | 8,800 |
| 168 | 4.1.1.1 | **Piloter la réalisation du produit** |  | 69.6d | 2008-04-17 08:00 | 2008-08-06 14:48 |  | 3d |  |  | 30h | 8,800 |
| 169 | 4.1.1.1.1 | **Reporting CAPS** |  | 66.53d | 2008-04-17 09:00 | 2008-08-01 09:15 |  | 6.07d |  |  |  |  |
| 170 | 4.1.1.1.1.1 | Reporting CAPS 1 |  | 15min | 2008-04-17 09:00 | 2008-04-17 09:15 |  | 72.57d | start no earlier than 2008-04-17 08:00 |  |  |  |
| 171 | 4.1.1.1.1.2 | Reporting CAPS 2 |  | 15min | 2008-04-18 09:00 | 2008-04-18 09:15 |  | 71.69d | start no earlier than 2008-04-18 08:00 |  |  |  |
| 172 | 4.1.1.1.1.3 | Reporting CAPS 3 |  | 15min | 2008-04-21 09:00 | 2008-04-21 09:15 |  | 70.82d | start no earlier than 2008-04-19 08:00 |  |  |  |
| 173 | 4.1.1.1.1.4 | Reporting CAPS 4 |  | 15min | 2008-04-21 09:00 | 2008-04-21 09:15 |  | 70.82d | start no earlier than 2008-04-20 08:00 |  |  |  |
| 174 | 4.1.1.1.1.5 | Reporting CAPS 5 |  | 15min | 2008-04-21 09:00 | 2008-04-21 09:15 |  | 70.82d | start no earlier than 2008-04-21 08:00 |  |  |  |
| 175 | 4.1.1.1.1.6 | Reporting CAPS 6 |  | 15min | 2008-04-22 09:00 | 2008-04-22 09:15 |  | 69.94d | start no earlier than 2008-04-22 08:00 |  |  |  |
| 176 | 4.1.1.1.1.7 | Reporting CAPS 7 |  | 15min | 2008-04-23 09:00 | 2008-04-23 09:15 |  | 69.07d | start no earlier than 2008-04-23 08:00 |  |  |  |
| 177 | 4.1.1.1.1.8 | Reporting CAPS 8 |  | 15min | 2008-04-24 09:00 | 2008-04-24 09:15 |  | 68.19d | start no earlier than 2008-04-24 08:00 |  |  |  |
| 178 | 4.1.1.1.1.9 | Reporting CAPS 9 |  | 15min | 2008-04-25 09:00 | 2008-04-25 09:15 |  | 67.32d | start no earlier than 2008-04-25 08:00 |  |  |  |
| 179 | 4.1.1.1.1.10 | Reporting CAPS 10 |  | 15min | 2008-04-28 09:00 | 2008-04-28 09:15 |  | 66.44d | start no earlier than 2008-04-26 08:00 |  |  |  |
| 180 | 4.1.1.1.1.11 | Reporting CAPS 11 |  | 15min | 2008-04-28 09:00 | 2008-04-28 09:15 |  | 66.44d | start no earlier than 2008-04-27 08:00 |  |  |  |
| 181 | 4.1.1.1.1.12 | Reporting CAPS 12 |  | 15min | 2008-04-28 09:00 | 2008-04-28 09:15 |  | 66.44d | start no earlier than 2008-04-28 08:00 |  |  |  |
| 182 | 4.1.1.1.1.13 | Reporting CAPS 13 |  | 15min | 2008-04-29 09:00 | 2008-04-29 09:15 |  | 65.57d | start no earlier than 2008-04-29 08:00 |  |  |  |
| 183 | 4.1.1.1.1.14 | Reporting CAPS 14 |  | 15min | 2008-04-30 09:00 | 2008-04-30 09:15 |  | 64.69d | start no earlier than 2008-04-30 08:00 |  |  |  |
| 184 | 4.1.1.1.1.15 | Reporting CAPS 15 |  | 15min | 2008-05-01 09:00 | 2008-05-01 09:15 |  | 63.82d | start no earlier than 2008-05-01 08:00 |  |  |  |
| 185 | 4.1.1.1.1.16 | Reporting CAPS 16 |  | 15min | 2008-05-02 09:00 | 2008-05-02 09:15 |  | 62.94d | start no earlier than 2008-05-02 08:00 |  |  |  |
| 186 | 4.1.1.1.1.17 | Reporting CAPS 17 |  | 15min | 2008-05-05 09:00 | 2008-05-05 09:15 |  | 62.07d | start no earlier than 2008-05-03 08:00 |  |  |  |
| 187 | 4.1.1.1.1.18 | Reporting CAPS 18 |  | 15min | 2008-05-05 09:00 | 2008-05-05 09:15 |  | 62.07d | start no earlier than 2008-05-04 08:00 |  |  |  |
| 188 | 4.1.1.1.1.19 | Reporting CAPS 19 |  | 15min | 2008-05-05 09:00 | 2008-05-05 09:15 |  | 62.07d | start no earlier than 2008-05-05 08:00 |  |  |  |
| 189 | 4.1.1.1.1.20 | Reporting CAPS 20 |  | 15min | 2008-05-06 09:00 | 2008-05-06 09:15 |  | 61.19d | start no earlier than 2008-05-06 08:00 |  |  |  |
| 190 | 4.1.1.1.1.21 | Reporting CAPS 21 |  | 15min | 2008-05-07 09:00 | 2008-05-07 09:15 |  | 60.32d | start no earlier than 2008-05-07 08:00 |  |  |  |
| 191 | 4.1.1.1.1.22 | Reporting CAPS 22 |  | 15min | 2008-05-08 09:00 | 2008-05-08 09:15 |  | 59.44d | start no earlier than 2008-05-08 08:00 |  |  |  |
| 192 | 4.1.1.1.1.23 | Reporting CAPS 23 |  | 15min | 2008-05-09 09:00 | 2008-05-09 09:15 |  | 58.57d | start no earlier than 2008-05-09 08:00 |  |  |  |
| 193 | 4.1.1.1.1.24 | Reporting CAPS 24 |  | 15min | 2008-05-12 09:00 | 2008-05-12 09:15 |  | 57.69d | start no earlier than 2008-05-10 08:00 |  |  |  |
| 194 | 4.1.1.1.1.25 | Reporting CAPS 25 |  | 15min | 2008-05-12 09:00 | 2008-05-12 09:15 |  | 57.69d | start no earlier than 2008-05-11 08:00 |  |  |  |
| 195 | 4.1.1.1.1.26 | Reporting CAPS 26 |  | 15min | 2008-05-12 09:00 | 2008-05-12 09:15 |  | 57.69d | start no earlier than 2008-05-12 08:00 |  |  |  |
| 196 | 4.1.1.1.1.27 | Reporting CAPS 27 |  | 15min | 2008-05-13 09:00 | 2008-05-13 09:15 |  | 56.82d | start no earlier than 2008-05-13 08:00 |  |  |  |
| 197 | 4.1.1.1.1.28 | Reporting CAPS 28 |  | 15min | 2008-05-14 09:00 | 2008-05-14 09:15 |  | 55.94d | start no earlier than 2008-05-14 08:00 |  |  |  |
| 198 | 4.1.1.1.1.29 | Reporting CAPS 29 |  | 15min | 2008-05-15 09:00 | 2008-05-15 09:15 |  | 55.07d | start no earlier than 2008-05-15 08:00 |  |  |  |
| 199 | 4.1.1.1.1.30 | Reporting CAPS 30 |  | 15min | 2008-05-16 09:00 | 2008-05-16 09:15 |  | 54.19d | start no earlier than 2008-05-16 08:00 |  |  |  |
| 200 | 4.1.1.1.1.31 | Reporting CAPS 31 |  | 15min | 2008-05-19 09:00 | 2008-05-19 09:15 |  | 53.32d | start no earlier than 2008-05-17 08:00 |  |  |  |
| 201 | 4.1.1.1.1.32 | Reporting CAPS 32 |  | 15min | 2008-05-19 09:00 | 2008-05-19 09:15 |  | 53.32d | start no earlier than 2008-05-18 08:00 |  |  |  |
| 202 | 4.1.1.1.1.33 | Reporting CAPS 33 |  | 15min | 2008-05-19 09:00 | 2008-05-19 09:15 |  | 53.32d | start no earlier than 2008-05-19 08:00 |  |  |  |
| 203 | 4.1.1.1.1.34 | Reporting CAPS 34 |  | 15min | 2008-05-20 09:00 | 2008-05-20 09:15 |  | 52.44d | start no earlier than 2008-05-20 08:00 |  |  |  |
| 204 | 4.1.1.1.1.35 | Reporting CAPS 35 |  | 15min | 2008-05-21 09:00 | 2008-05-21 09:15 |  | 51.57d | start no earlier than 2008-05-21 08:00 |  |  |  |
| 205 | 4.1.1.1.1.36 | Reporting CAPS 36 |  | 15min | 2008-05-22 09:00 | 2008-05-22 09:15 |  | 50.69d | start no earlier than 2008-05-22 08:00 |  |  |  |
| 206 | 4.1.1.1.1.37 | Reporting CAPS 37 |  | 15min | 2008-05-23 09:00 | 2008-05-23 09:15 |  | 49.82d | start no earlier than 2008-05-23 08:00 |  |  |  |
| 207 | 4.1.1.1.1.38 | Reporting CAPS 38 |  | 15min | 2008-05-26 09:00 | 2008-05-26 09:15 |  | 48.94d | start no earlier than 2008-05-24 08:00 |  |  |  |
| 208 | 4.1.1.1.1.39 | Reporting CAPS 39 |  | 15min | 2008-05-26 09:00 | 2008-05-26 09:15 |  | 48.94d | start no earlier than 2008-05-25 08:00 |  |  |  |
| 209 | 4.1.1.1.1.40 | Reporting CAPS 40 |  | 15min | 2008-05-26 09:00 | 2008-05-26 09:15 |  | 48.94d | start no earlier than 2008-05-26 08:00 |  |  |  |
| 210 | 4.1.1.1.1.41 | Reporting CAPS 41 |  | 15min | 2008-05-27 09:00 | 2008-05-27 09:15 |  | 48.07d | start no earlier than 2008-05-27 08:00 |  |  |  |
| 211 | 4.1.1.1.1.42 | Reporting CAPS 42 |  | 15min | 2008-05-28 09:00 | 2008-05-28 09:15 |  | 47.19d | start no earlier than 2008-05-28 08:00 |  |  |  |
| 212 | 4.1.1.1.1.43 | Reporting CAPS 43 |  | 15min | 2008-05-29 09:00 | 2008-05-29 09:15 |  | 46.32d | start no earlier than 2008-05-29 08:00 |  |  |  |
| 213 | 4.1.1.1.1.44 | Reporting CAPS 44 |  | 15min | 2008-05-30 09:00 | 2008-05-30 09:15 |  | 45.44d | start no earlier than 2008-05-30 08:00 |  |  |  |
| 214 | 4.1.1.1.1.45 | Reporting CAPS 45 |  | 15min | 2008-06-02 09:00 | 2008-06-02 09:15 |  | 44.57d | start no earlier than 2008-05-31 08:00 |  |  |  |
| 215 | 4.1.1.1.1.46 | Reporting CAPS 46 |  | 15min | 2008-06-02 09:00 | 2008-06-02 09:15 |  | 44.57d | start no earlier than 2008-06-01 08:00 |  |  |  |
| 216 | 4.1.1.1.1.47 | Reporting CAPS 47 |  | 15min | 2008-06-02 09:00 | 2008-06-02 09:15 |  | 44.57d | start no earlier than 2008-06-02 08:00 |  |  |  |
| 217 | 4.1.1.1.1.48 | Reporting CAPS 48 |  | 15min | 2008-06-03 09:00 | 2008-06-03 09:15 |  | 43.69d | start no earlier than 2008-06-03 08:00 |  |  |  |
| 218 | 4.1.1.1.1.49 | Reporting CAPS 49 |  | 15min | 2008-06-04 09:00 | 2008-06-04 09:15 |  | 42.82d | start no earlier than 2008-06-04 08:00 |  |  |  |
| 219 | 4.1.1.1.1.50 | Reporting CAPS 50 |  | 15min | 2008-06-05 09:00 | 2008-06-05 09:15 |  | 41.94d | start no earlier than 2008-06-05 08:00 |  |  |  |
| 220 | 4.1.1.1.1.51 | Reporting CAPS 51 |  | 15min | 2008-06-06 09:00 | 2008-06-06 09:15 |  | 41.07d | start no earlier than 2008-06-06 08:00 |  |  |  |

Notes:
- 166: Cette tâche contient toutes les tâches de pilotage, elle démarre au début de la réalisation et se termine à la fin de la réalisation

| ID | WBS | Task | Duration | Start | Finish | Total slack | Constraint |
| --- | --- | --- | --- | --- | --- | --- | --- |
| 221 | 4.1.1.1.1.52 | Reporting CAPS 52 | 15min | 2008-06-09 09:00 | 2008-06-09 09:15 | 40.19d | start no earlier than 2008-06-07 08:00 |
| 222 | 4.1.1.1.1.53 | Reporting CAPS 53 | 15min | 2008-06-09 09:00 | 2008-06-09 09:15 | 40.19d | start no earlier than 2008-06-08 08:00 |
| 223 | 4.1.1.1.1.54 | Reporting CAPS 54 | 15min | 2008-06-09 09:00 | 2008-06-09 09:15 | 40.19d | start no earlier than 2008-06-09 08:00 |
| 224 | 4.1.1.1.1.55 | Reporting CAPS 55 | 15min | 2008-06-10 09:00 | 2008-06-10 09:15 | 39.32d | start no earlier than 2008-06-10 08:00 |
| 225 | 4.1.1.1.1.56 | Reporting CAPS 56 | 15min | 2008-06-11 09:00 | 2008-06-11 09:15 | 38.44d | start no earlier than 2008-06-11 08:00 |
| 226 | 4.1.1.1.1.57 | Reporting CAPS 57 | 15min | 2008-06-12 09:00 | 2008-06-12 09:15 | 37.57d | start no earlier than 2008-06-12 08:00 |
| 227 | 4.1.1.1.1.58 | Reporting CAPS 58 | 15min | 2008-06-13 09:00 | 2008-06-13 09:15 | 36.69d | start no earlier than 2008-06-13 08:00 |
| 228 | 4.1.1.1.1.59 | Reporting CAPS 59 | 15min | 2008-06-16 09:00 | 2008-06-16 09:15 | 35.82d | start no earlier than 2008-06-14 08:00 |
| 229 | 4.1.1.1.1.60 | Reporting CAPS 60 | 15min | 2008-06-16 09:00 | 2008-06-16 09:15 | 35.82d | start no earlier than 2008-06-15 08:00 |
| 230 | 4.1.1.1.1.61 | Reporting CAPS 61 | 15min | 2008-06-16 09:00 | 2008-06-16 09:15 | 35.82d | start no earlier than 2008-06-16 08:00 |
| 231 | 4.1.1.1.1.62 | Reporting CAPS 62 | 15min | 2008-06-17 09:00 | 2008-06-17 09:15 | 34.94d | start no earlier than 2008-06-17 08:00 |
| 232 | 4.1.1.1.1.63 | Reporting CAPS 63 | 15min | 2008-06-18 09:00 | 2008-06-18 09:15 | 34.07d | start no earlier than 2008-06-18 08:00 |
| 233 | 4.1.1.1.1.64 | Reporting CAPS 64 | 15min | 2008-06-19 09:00 | 2008-06-19 09:15 | 33.19d | start no earlier than 2008-06-19 08:00 |
| 234 | 4.1.1.1.1.65 | Reporting CAPS 65 | 15min | 2008-06-20 09:00 | 2008-06-20 09:15 | 32.32d | start no earlier than 2008-06-20 08:00 |
| 235 | 4.1.1.1.1.66 | Reporting CAPS 66 | 15min | 2008-06-23 09:00 | 2008-06-23 09:15 | 31.44d | start no earlier than 2008-06-21 08:00 |
| 236 | 4.1.1.1.1.67 | Reporting CAPS 67 | 15min | 2008-06-23 09:00 | 2008-06-23 09:15 | 31.44d | start no earlier than 2008-06-22 08:00 |
| 237 | 4.1.1.1.1.68 | Reporting CAPS 68 | 15min | 2008-06-23 09:00 | 2008-06-23 09:15 | 31.44d | start no earlier than 2008-06-23 08:00 |
| 238 | 4.1.1.1.1.69 | Reporting CAPS 69 | 15min | 2008-06-24 09:00 | 2008-06-24 09:15 | 30.57d | start no earlier than 2008-06-24 08:00 |
| 239 | 4.1.1.1.1.70 | Reporting CAPS 70 | 15min | 2008-06-25 09:00 | 2008-06-25 09:15 | 29.69d | start no earlier than 2008-06-25 08:00 |
| 240 | 4.1.1.1.1.71 | Reporting CAPS 71 | 15min | 2008-06-26 09:00 | 2008-06-26 09:15 | 28.82d | start no earlier than 2008-06-26 08:00 |
| 241 | 4.1.1.1.1.72 | Reporting CAPS 72 | 15min | 2008-06-27 09:00 | 2008-06-27 09:15 | 27.94d | start no earlier than 2008-06-27 08:00 |
| 242 | 4.1.1.1.1.73 | Reporting CAPS 73 | 15min | 2008-06-30 09:00 | 2008-06-30 09:15 | 27.07d | start no earlier than 2008-06-28 08:00 |
| 243 | 4.1.1.1.1.74 | Reporting CAPS 74 | 15min | 2008-06-30 09:00 | 2008-06-30 09:15 | 27.07d | start no earlier than 2008-06-29 08:00 |
| 244 | 4.1.1.1.1.75 | Reporting CAPS 75 | 15min | 2008-06-30 09:00 | 2008-06-30 09:15 | 27.07d | start no earlier than 2008-06-30 08:00 |
| 245 | 4.1.1.1.1.76 | Reporting CAPS 76 | 15min | 2008-07-01 09:00 | 2008-07-01 09:15 | 26.19d | start no earlier than 2008-07-01 08:00 |
| 246 | 4.1.1.1.1.77 | Reporting CAPS 77 | 15min | 2008-07-02 09:00 | 2008-07-02 09:15 | 25.32d | start no earlier than 2008-07-02 08:00 |
| 247 | 4.1.1.1.1.78 | Reporting CAPS 78 | 15min | 2008-07-03 09:00 | 2008-07-03 09:15 | 24.44d | start no earlier than 2008-07-03 08:00 |
| 248 | 4.1.1.1.1.79 | Reporting CAPS 79 | 15min | 2008-07-04 09:00 | 2008-07-04 09:15 | 23.57d | start no earlier than 2008-07-04 08:00 |
| 249 | 4.1.1.1.1.80 | Reporting CAPS 80 | 15min | 2008-07-07 09:00 | 2008-07-07 09:15 | 22.69d | start no earlier than 2008-07-05 08:00 |
| 250 | 4.1.1.1.1.81 | Reporting CAPS 81 | 15min | 2008-07-07 09:00 | 2008-07-07 09:15 | 22.69d | start no earlier than 2008-07-06 08:00 |
| 251 | 4.1.1.1.1.82 | Reporting CAPS 82 | 15min | 2008-07-07 09:00 | 2008-07-07 09:15 | 22.69d | start no earlier than 2008-07-07 08:00 |
| 252 | 4.1.1.1.1.83 | Reporting CAPS 83 | 15min | 2008-07-08 09:00 | 2008-07-08 09:15 | 21.82d | start no earlier than 2008-07-08 08:00 |
| 253 | 4.1.1.1.1.84 | Reporting CAPS 84 | 15min | 2008-07-09 09:00 | 2008-07-09 09:15 | 20.94d | start no earlier than 2008-07-09 08:00 |
| 254 | 4.1.1.1.1.85 | Reporting CAPS 85 | 15min | 2008-07-10 09:00 | 2008-07-10 09:15 | 20.07d | start no earlier than 2008-07-10 08:00 |
| 255 | 4.1.1.1.1.86 | Reporting CAPS 86 | 15min | 2008-07-11 09:00 | 2008-07-11 09:15 | 19.19d | start no earlier than 2008-07-11 08:00 |
| 256 | 4.1.1.1.1.87 | Reporting CAPS 87 | 15min | 2008-07-14 09:00 | 2008-07-14 09:15 | 18.32d | start no earlier than 2008-07-12 08:00 |
| 257 | 4.1.1.1.1.88 | Reporting CAPS 88 | 15min | 2008-07-14 09:00 | 2008-07-14 09:15 | 18.32d | start no earlier than 2008-07-13 08:00 |
| 258 | 4.1.1.1.1.89 | Reporting CAPS 89 | 15min | 2008-07-14 09:00 | 2008-07-14 09:15 | 18.32d | start no earlier than 2008-07-14 08:00 |
| 259 | 4.1.1.1.1.90 | Reporting CAPS 90 | 15min | 2008-07-15 09:00 | 2008-07-15 09:15 | 17.44d | start no earlier than 2008-07-15 08:00 |
| 260 | 4.1.1.1.1.91 | Reporting CAPS 91 | 15min | 2008-07-16 09:00 | 2008-07-16 09:15 | 16.57d | start no earlier than 2008-07-16 08:00 |
| 261 | 4.1.1.1.1.92 | Reporting CAPS 92 | 15min | 2008-07-17 09:00 | 2008-07-17 09:15 | 15.69d | start no earlier than 2008-07-17 08:00 |
| 262 | 4.1.1.1.1.93 | Reporting CAPS 93 | 15min | 2008-07-18 09:00 | 2008-07-18 09:15 | 14.82d | start no earlier than 2008-07-18 08:00 |
| 263 | 4.1.1.1.1.94 | Reporting CAPS 94 | 15min | 2008-07-21 09:00 | 2008-07-21 09:15 | 13.94d | start no earlier than 2008-07-19 08:00 |
| 264 | 4.1.1.1.1.95 | Reporting CAPS 95 | 15min | 2008-07-21 09:00 | 2008-07-21 09:15 | 13.94d | start no earlier than 2008-07-20 08:00 |
| 265 | 4.1.1.1.1.96 | Reporting CAPS 96 | 15min | 2008-07-21 09:00 | 2008-07-21 09:15 | 13.94d | start no earlier than 2008-07-21 08:00 |
| 266 | 4.1.1.1.1.97 | Reporting CAPS 97 | 15min | 2008-07-22 09:00 | 2008-07-22 09:15 | 13.07d | start no earlier than 2008-07-22 08:00 |
| 267 | 4.1.1.1.1.98 | Reporting CAPS 98 | 15min | 2008-07-23 09:00 | 2008-07-23 09:15 | 12.19d | start no earlier than 2008-07-23 08:00 |
| 268 | 4.1.1.1.1.99 | Reporting CAPS 99 | 15min | 2008-07-24 09:00 | 2008-07-24 09:15 | 11.32d | start no earlier than 2008-07-24 08:00 |
| 269 | 4.1.1.1.1.100 | Reporting CAPS 100 | 15min | 2008-07-25 09:00 | 2008-07-25 09:15 | 10.44d | start no earlier than 2008-07-25 08:00 |
| 270 | 4.1.1.1.1.101 | Reporting CAPS 101 | 15min | 2008-07-28 09:00 | 2008-07-28 09:15 | 9.57d | start no earlier than 2008-07-26 08:00 |
| 271 | 4.1.1.1.1.102 | Reporting CAPS 102 | 15min | 2008-07-28 09:00 | 2008-07-28 09:15 | 9.57d | start no earlier than 2008-07-27 08:00 |
| 272 | 4.1.1.1.1.103 | Reporting CAPS 103 | 15min | 2008-07-28 09:00 | 2008-07-28 09:15 | 9.57d | start no earlier than 2008-07-28 08:00 |
| 273 | 4.1.1.1.1.104 | Reporting CAPS 104 | 15min | 2008-07-29 09:00 | 2008-07-29 09:15 | 8.69d | start no earlier than 2008-07-29 08:00 |
| 274 | 4.1.1.1.1.105 | Reporting CAPS 105 | 15min | 2008-07-30 09:00 | 2008-07-30 09:15 | 7.82d | start no earlier than 2008-07-30 08:00 |
| 275 | 4.1.1.1.1.106 | Reporting CAPS 106 | 15min | 2008-07-31 09:00 | 2008-07-31 09:15 | 6.94d | start no earlier than 2008-07-31 08:00 |
| 276 | 4.1.1.1.1.107 | Reporting CAPS 107 | 15min | 2008-08-01 09:00 | 2008-08-01 09:15 | 6.07d | start no earlier than 2008-08-01 08:00 |

| ID | WBS | Task | Duration | Start | Finish | Total slack | Constraint |
| --- | --- | --- | --- | --- | --- | --- | --- |
| 277 | 4.1.1.1.2 | **Reporting PO** | 62.19d | 2008-04-21 09:00 | 2008-07-29 09:30 | 8.66d |  |
| 278 | 4.1.1.1.2.1 | Reporting PO 1 | 30min | 2008-04-21 09:00 | 2008-04-21 09:30 | 70.79d | start no earlier than 2008-04-21 08:00 |
| 279 | 4.1.1.1.2.2 | Reporting PO 2 | 30min | 2008-04-22 09:00 | 2008-04-22 09:30 | 69.91d | start no earlier than 2008-04-22 08:00 |
| 280 | 4.1.1.1.2.3 | Reporting PO 3 | 30min | 2008-04-28 09:00 | 2008-04-28 09:30 | 66.41d | start no earlier than 2008-04-28 08:00 |
| 281 | 4.1.1.1.2.4 | Reporting PO 4 | 30min | 2008-04-29 09:00 | 2008-04-29 09:30 | 65.54d | start no earlier than 2008-04-29 08:00 |
| 282 | 4.1.1.1.2.5 | Reporting PO 5 | 30min | 2008-05-05 09:00 | 2008-05-05 09:30 | 62.04d | start no earlier than 2008-05-05 08:00 |
| 283 | 4.1.1.1.2.6 | Reporting PO 6 | 30min | 2008-05-06 09:00 | 2008-05-06 09:30 | 61.16d | start no earlier than 2008-05-06 08:00 |
| 284 | 4.1.1.1.2.7 | Reporting PO 7 | 30min | 2008-05-12 09:00 | 2008-05-12 09:30 | 57.66d | start no earlier than 2008-05-12 08:00 |
| 285 | 4.1.1.1.2.8 | Reporting PO 8 | 30min | 2008-05-13 09:00 | 2008-05-13 09:30 | 56.79d | start no earlier than 2008-05-13 08:00 |
| 286 | 4.1.1.1.2.9 | Reporting PO 9 | 30min | 2008-05-19 09:00 | 2008-05-19 09:30 | 53.29d | start no earlier than 2008-05-19 08:00 |
| 287 | 4.1.1.1.2.10 | Reporting PO 10 | 30min | 2008-05-20 09:00 | 2008-05-20 09:30 | 52.41d | start no earlier than 2008-05-20 08:00 |
| 288 | 4.1.1.1.2.11 | Reporting PO 11 | 30min | 2008-05-26 09:00 | 2008-05-26 09:30 | 48.91d | start no earlier than 2008-05-26 08:00 |
| 289 | 4.1.1.1.2.12 | Reporting PO 12 | 30min | 2008-05-27 09:00 | 2008-05-27 09:30 | 48.04d | start no earlier than 2008-05-27 08:00 |
| 290 | 4.1.1.1.2.13 | Reporting PO 13 | 30min | 2008-06-02 09:00 | 2008-06-02 09:30 | 44.54d | start no earlier than 2008-06-02 08:00 |
| 291 | 4.1.1.1.2.14 | Reporting PO 14 | 30min | 2008-06-03 09:00 | 2008-06-03 09:30 | 43.66d | start no earlier than 2008-06-03 08:00 |
| 292 | 4.1.1.1.2.15 | Reporting PO 15 | 30min | 2008-06-09 09:00 | 2008-06-09 09:30 | 40.16d | start no earlier than 2008-06-09 08:00 |
| 293 | 4.1.1.1.2.16 | Reporting PO 16 | 30min | 2008-06-10 09:00 | 2008-06-10 09:30 | 39.29d | start no earlier than 2008-06-10 08:00 |
| 294 | 4.1.1.1.2.17 | Reporting PO 17 | 30min | 2008-06-16 09:00 | 2008-06-16 09:30 | 35.79d | start no earlier than 2008-06-16 08:00 |
| 295 | 4.1.1.1.2.18 | Reporting PO 18 | 30min | 2008-06-17 09:00 | 2008-06-17 09:30 | 34.91d | start no earlier than 2008-06-17 08:00 |
| 296 | 4.1.1.1.2.19 | Reporting PO 19 | 30min | 2008-06-23 09:00 | 2008-06-23 09:30 | 31.41d | start no earlier than 2008-06-23 08:00 |
| 297 | 4.1.1.1.2.20 | Reporting PO 20 | 30min | 2008-06-24 09:00 | 2008-06-24 09:30 | 30.54d | start no earlier than 2008-06-24 08:00 |
| 298 | 4.1.1.1.2.21 | Reporting PO 21 | 30min | 2008-06-30 09:00 | 2008-06-30 09:30 | 27.04d | start no earlier than 2008-06-30 08:00 |
| 299 | 4.1.1.1.2.22 | Reporting PO 22 | 30min | 2008-07-01 09:00 | 2008-07-01 09:30 | 26.16d | start no earlier than 2008-07-01 08:00 |
| 300 | 4.1.1.1.2.23 | Reporting PO 23 | 30min | 2008-07-07 09:00 | 2008-07-07 09:30 | 22.66d | start no earlier than 2008-07-07 08:00 |
| 301 | 4.1.1.1.2.24 | Reporting PO 24 | 30min | 2008-07-08 09:00 | 2008-07-08 09:30 | 21.79d | start no earlier than 2008-07-08 08:00 |
| 302 | 4.1.1.1.2.25 | Reporting PO 25 | 30min | 2008-07-14 09:00 | 2008-07-14 09:30 | 18.29d | start no earlier than 2008-07-14 08:00 |
| 303 | 4.1.1.1.2.26 | Reporting PO 26 | 30min | 2008-07-15 09:00 | 2008-07-15 09:30 | 17.41d | start no earlier than 2008-07-15 08:00 |
| 304 | 4.1.1.1.2.27 | Reporting PO 27 | 30min | 2008-07-21 09:00 | 2008-07-21 09:30 | 13.91d | start no earlier than 2008-07-21 08:00 |
| 305 | 4.1.1.1.2.28 | Reporting PO 28 | 30min | 2008-07-22 09:00 | 2008-07-22 09:30 | 13.04d | start no earlier than 2008-07-22 08:00 |
| 306 | 4.1.1.1.2.29 | Reporting PO 29 | 30min | 2008-07-28 09:00 | 2008-07-28 09:30 | 9.54d | start no earlier than 2008-07-28 08:00 |
| 307 | 4.1.1.1.2.30 | Reporting PO 30 | 30min | 2008-07-29 09:00 | 2008-07-29 09:30 | 8.66d | start no earlier than 2008-07-29 08:00 |

| ID | WBS | Task | Type | Duration | Start | Finish | Total slack | Constraint |
| --- | --- | --- | --- | --- | --- | --- | --- | --- |
| 308 | 4.1.1.1.3 | **Reporting commanditaire** |  | 61.28d | 2008-04-22 09:00 | 2008-07-29 09:15 | 8.69d |  |
| 309 | 4.1.1.1.3.1 | Reporting commanditaire 1 |  | 15min | 2008-04-22 09:00 | 2008-04-22 09:15 | 69.94d | start no earlier than 2008-04-22 08:00 |
| 310 | 4.1.1.1.3.2 | Reporting commanditaire 2 |  | 15min | 2008-04-29 09:00 | 2008-04-29 09:15 | 65.57d | start no earlier than 2008-04-29 08:00 |
| 311 | 4.1.1.1.3.3 | Reporting commanditaire 3 |  | 15min | 2008-05-06 09:00 | 2008-05-06 09:15 | 61.19d | start no earlier than 2008-05-06 08:00 |
| 312 | 4.1.1.1.3.4 | Reporting commanditaire 4 |  | 15min | 2008-05-13 09:00 | 2008-05-13 09:15 | 56.82d | start no earlier than 2008-05-13 08:00 |
| 313 | 4.1.1.1.3.5 | Reporting commanditaire 5 |  | 15min | 2008-05-20 09:00 | 2008-05-20 09:15 | 52.44d | start no earlier than 2008-05-20 08:00 |
| 314 | 4.1.1.1.3.6 | Reporting commanditaire 6 |  | 15min | 2008-05-27 09:00 | 2008-05-27 09:15 | 48.07d | start no earlier than 2008-05-27 08:00 |
| 315 | 4.1.1.1.3.7 | Reporting commanditaire 7 |  | 15min | 2008-06-03 09:00 | 2008-06-03 09:15 | 43.69d | start no earlier than 2008-06-03 08:00 |
| 316 | 4.1.1.1.3.8 | Reporting commanditaire 8 |  | 15min | 2008-06-10 09:00 | 2008-06-10 09:15 | 39.32d | start no earlier than 2008-06-10 08:00 |
| 317 | 4.1.1.1.3.9 | Reporting commanditaire 9 |  | 15min | 2008-06-17 09:00 | 2008-06-17 09:15 | 34.94d | start no earlier than 2008-06-17 08:00 |
| 318 | 4.1.1.1.3.10 | Reporting commanditaire 10 |  | 15min | 2008-06-24 09:00 | 2008-06-24 09:15 | 30.57d | start no earlier than 2008-06-24 08:00 |
| 319 | 4.1.1.1.3.11 | Reporting commanditaire 11 |  | 15min | 2008-07-01 09:00 | 2008-07-01 09:15 | 26.19d | start no earlier than 2008-07-01 08:00 |
| 320 | 4.1.1.1.3.12 | Reporting commanditaire 12 |  | 15min | 2008-07-08 09:00 | 2008-07-08 09:15 | 21.82d | start no earlier than 2008-07-08 08:00 |
| 321 | 4.1.1.1.3.13 | Reporting commanditaire 13 |  | 15min | 2008-07-15 09:00 | 2008-07-15 09:15 | 17.44d | start no earlier than 2008-07-15 08:00 |
| 322 | 4.1.1.1.3.14 | Reporting commanditaire 14 |  | 15min | 2008-07-22 09:00 | 2008-07-22 09:15 | 13.07d | start no earlier than 2008-07-22 08:00 |
| 323 | 4.1.1.1.3.15 | Reporting commanditaire 15 |  | 15min | 2008-07-29 09:00 | 2008-07-29 09:15 | 8.69d | start no earlier than 2008-07-29 08:00 |
| 324 | 4.1.1.1.4 | **Fiche de reporting** |  | 61.25d | 2008-04-21 08:00 | 2008-07-28 08:00 | 9.6d |  |
| 325 | 4.1.1.1.4.1 | Fiche de reporting 1 | milestone | 0d | 2008-04-21 08:00 | 2008-04-21 08:00 | 70.85d | start no earlier than 2008-04-21 08:00 |
| 326 | 4.1.1.1.4.2 | Fiche de reporting 2 | milestone | 0d | 2008-04-28 08:00 | 2008-04-28 08:00 | 66.48d | start no earlier than 2008-04-28 08:00 |
| 327 | 4.1.1.1.4.3 | Fiche de reporting 3 | milestone | 0d | 2008-05-05 08:00 | 2008-05-05 08:00 | 62.1d | start no earlier than 2008-05-05 08:00 |
| 328 | 4.1.1.1.4.4 | Fiche de reporting 4 | milestone | 0d | 2008-05-12 08:00 | 2008-05-12 08:00 | 57.73d | start no earlier than 2008-05-12 08:00 |
| 329 | 4.1.1.1.4.5 | Fiche de reporting 5 | milestone | 0d | 2008-05-19 08:00 | 2008-05-19 08:00 | 53.35d | start no earlier than 2008-05-19 08:00 |
| 330 | 4.1.1.1.4.6 | Fiche de reporting 6 | milestone | 0d | 2008-05-26 08:00 | 2008-05-26 08:00 | 48.98d | start no earlier than 2008-05-26 08:00 |
| 331 | 4.1.1.1.4.7 | Fiche de reporting 7 | milestone | 0d | 2008-06-02 08:00 | 2008-06-02 08:00 | 44.6d | start no earlier than 2008-06-02 08:00 |
| 332 | 4.1.1.1.4.8 | Fiche de reporting 8 | milestone | 0d | 2008-06-09 08:00 | 2008-06-09 08:00 | 40.23d | start no earlier than 2008-06-09 08:00 |
| 333 | 4.1.1.1.4.9 | Fiche de reporting 9 | milestone | 0d | 2008-06-16 08:00 | 2008-06-16 08:00 | 35.85d | start no earlier than 2008-06-16 08:00 |
| 334 | 4.1.1.1.4.10 | Fiche de reporting 10 | milestone | 0d | 2008-06-23 08:00 | 2008-06-23 08:00 | 31.48d | start no earlier than 2008-06-23 08:00 |
| 335 | 4.1.1.1.4.11 | Fiche de reporting 11 | milestone | 0d | 2008-06-30 08:00 | 2008-06-30 08:00 | 27.1d | start no earlier than 2008-06-30 08:00 |
| 336 | 4.1.1.1.4.12 | Fiche de reporting 12 | milestone | 0d | 2008-07-07 08:00 | 2008-07-07 08:00 | 22.73d | start no earlier than 2008-07-07 08:00 |
| 337 | 4.1.1.1.4.13 | Fiche de reporting 13 | milestone | 0d | 2008-07-14 08:00 | 2008-07-14 08:00 | 18.35d | start no earlier than 2008-07-14 08:00 |
| 338 | 4.1.1.1.4.14 | Fiche de reporting 14 | milestone | 0d | 2008-07-21 08:00 | 2008-07-21 08:00 | 13.98d | start no earlier than 2008-07-21 08:00 |
| 339 | 4.1.1.1.4.15 | Fiche de reporting 15 | milestone | 0d | 2008-07-28 08:00 | 2008-07-28 08:00 | 9.6d | start no earlier than 2008-07-28 08:00 |

| ID | WBS | Task | Type | Duration | Start | Finish | Total slack | Constraint |
| --- | --- | --- | --- | --- | --- | --- | --- | --- |
| 340 | 4.1.1.1.5 | **Réunion comité de pilotage** |  | 57.88d | 2008-04-17 09:00 | 2008-07-18 10:00 | 14.73d |  |
| 341 | 4.1.1.1.5.1 | Réunion comité de pilotage 1 |  | 1d | 2008-04-17 09:00 | 2008-04-18 10:00 | 71.6d | start no earlier than 2008-04-17 08:00 |
| 342 | 4.1.1.1.5.2 | Réunion comité de pilotage 2 |  | 1d | 2008-05-19 09:00 | 2008-05-20 10:00 | 52.35d | start no earlier than 2008-05-17 08:00 |
| 343 | 4.1.1.1.5.3 | Réunion comité de pilotage 3 |  | 1d | 2008-06-17 09:00 | 2008-06-18 10:00 | 33.98d | start no earlier than 2008-06-17 08:00 |
| 344 | 4.1.1.1.5.4 | Réunion comité de pilotage 4 |  | 1d | 2008-07-17 09:00 | 2008-07-18 10:00 | 14.73d | start no earlier than 2008-07-17 08:00 |
| 345 | 4.1.1.1.6 | **Rapport Flash** |  | 56.88d | 2008-04-17 08:00 | 2008-07-17 08:00 | 15.73d |  |
| 346 | 4.1.1.1.6.1 | Rapport Flash 1 | milestone | 0d | 2008-04-17 08:00 | 2008-04-17 08:00 | 72.6d | start no earlier than 2008-04-17 08:00 |
| 347 | 4.1.1.1.6.2 | Rapport Flash 2 | milestone | 0d | 2008-05-17 08:00 | 2008-05-17 08:00 | 53.35d | start no earlier than 2008-05-17 08:00 |
| 348 | 4.1.1.1.6.3 | Rapport Flash 3 | milestone | 0d | 2008-06-17 08:00 | 2008-06-17 08:00 | 34.98d | start no earlier than 2008-06-17 08:00 |
| 349 | 4.1.1.1.6.4 | Rapport Flash 4 | milestone | 0d | 2008-07-17 08:00 | 2008-07-17 08:00 | 15.73d | start no earlier than 2008-07-17 08:00 |
| 350 | 4.1.1.1.7 | **Mettre à jour le planning** |  | 61.38d | 2008-04-21 09:00 | 2008-07-28 10:00 | 9.48d |  |
| 351 | 4.1.1.1.7.1 | Mettre à jour le planning 1 |  | 1h | 2008-04-21 09:00 | 2008-04-21 10:00 | 70.73d | start no earlier than 2008-04-21 08:00 |
| 352 | 4.1.1.1.7.2 | Mettre à jour le planning 2 |  | 1h | 2008-04-28 09:00 | 2008-04-28 10:00 | 66.35d | start no earlier than 2008-04-28 08:00 |
| 353 | 4.1.1.1.7.3 | Mettre à jour le planning 3 |  | 1h | 2008-05-05 09:00 | 2008-05-05 10:00 | 61.98d | start no earlier than 2008-05-05 08:00 |
| 354 | 4.1.1.1.7.4 | Mettre à jour le planning 4 |  | 1h | 2008-05-12 09:00 | 2008-05-12 10:00 | 57.6d | start no earlier than 2008-05-12 08:00 |
| 355 | 4.1.1.1.7.5 | Mettre à jour le planning 5 |  | 1h | 2008-05-19 09:00 | 2008-05-19 10:00 | 53.23d | start no earlier than 2008-05-19 08:00 |
| 356 | 4.1.1.1.7.6 | Mettre à jour le planning 6 |  | 1h | 2008-05-26 09:00 | 2008-05-26 10:00 | 48.85d | start no earlier than 2008-05-26 08:00 |
| 357 | 4.1.1.1.7.7 | Mettre à jour le planning 7 |  | 1h | 2008-06-02 09:00 | 2008-06-02 10:00 | 44.48d | start no earlier than 2008-06-02 08:00 |
| 358 | 4.1.1.1.7.8 | Mettre à jour le planning 8 |  | 1h | 2008-06-09 09:00 | 2008-06-09 10:00 | 40.1d | start no earlier than 2008-06-09 08:00 |
| 359 | 4.1.1.1.7.9 | Mettre à jour le planning 9 |  | 1h | 2008-06-16 09:00 | 2008-06-16 10:00 | 35.73d | start no earlier than 2008-06-16 08:00 |
| 360 | 4.1.1.1.7.10 | Mettre à jour le planning 10 |  | 1h | 2008-06-23 09:00 | 2008-06-23 10:00 | 31.35d | start no earlier than 2008-06-23 08:00 |
| 361 | 4.1.1.1.7.11 | Mettre à jour le planning 11 |  | 1h | 2008-06-30 09:00 | 2008-06-30 10:00 | 26.98d | start no earlier than 2008-06-30 08:00 |
| 362 | 4.1.1.1.7.12 | Mettre à jour le planning 12 |  | 1h | 2008-07-07 09:00 | 2008-07-07 10:00 | 22.6d | start no earlier than 2008-07-07 08:00 |
| 363 | 4.1.1.1.7.13 | Mettre à jour le planning 13 |  | 1h | 2008-07-14 09:00 | 2008-07-14 10:00 | 18.23d | start no earlier than 2008-07-14 08:00 |
| 364 | 4.1.1.1.7.14 | Mettre à jour le planning 14 |  | 1h | 2008-07-21 09:00 | 2008-07-21 10:00 | 13.85d | start no earlier than 2008-07-21 08:00 |
| 365 | 4.1.1.1.7.15 | Mettre à jour le planning 15 |  | 1h | 2008-07-28 09:00 | 2008-07-28 10:00 | 9.48d | start no earlier than 2008-07-28 08:00 |

| ID | WBS | Task | Type | Duration | Start | Finish | Predecessors | Total slack | Free slack | Constraint | Resources | Work | Cost |
| --- | --- | --- | --- | --- | --- | --- | --- | --- | --- | --- | --- | --- | --- |
| 366 | 4.1.1.1.8 | **Planning détaillé de suivi** |  | 61.25d | 2008-04-21 08:00 | 2008-07-28 08:00 |  | 9.6d |  |  |  |  |  |
| 367 | 4.1.1.1.8.1 | Planning détaillé de suivi 1 | milestone | 0d | 2008-04-21 08:00 | 2008-04-21 08:00 |  | 70.85d |  | start no earlier than 2008-04-21 08:00 |  |  |  |
| 368 | 4.1.1.1.8.2 | Planning détaillé de suivi 2 | milestone | 0d | 2008-04-28 08:00 | 2008-04-28 08:00 |  | 66.48d |  | start no earlier than 2008-04-28 08:00 |  |  |  |
| 369 | 4.1.1.1.8.3 | Planning détaillé de suivi 3 | milestone | 0d | 2008-05-05 08:00 | 2008-05-05 08:00 |  | 62.1d |  | start no earlier than 2008-05-05 08:00 |  |  |  |
| 370 | 4.1.1.1.8.4 | Planning détaillé de suivi 4 | milestone | 0d | 2008-05-12 08:00 | 2008-05-12 08:00 |  | 57.73d |  | start no earlier than 2008-05-12 08:00 |  |  |  |
| 371 | 4.1.1.1.8.5 | Planning détaillé de suivi 5 | milestone | 0d | 2008-05-19 08:00 | 2008-05-19 08:00 |  | 53.35d |  | start no earlier than 2008-05-19 08:00 |  |  |  |
| 372 | 4.1.1.1.8.6 | Planning détaillé de suivi 6 | milestone | 0d | 2008-05-26 08:00 | 2008-05-26 08:00 |  | 48.98d |  | start no earlier than 2008-05-26 08:00 |  |  |  |
| 373 | 4.1.1.1.8.7 | Planning détaillé de suivi 7 | milestone | 0d | 2008-06-02 08:00 | 2008-06-02 08:00 |  | 44.6d |  | start no earlier than 2008-06-02 08:00 |  |  |  |
| 374 | 4.1.1.1.8.8 | Planning détaillé de suivi 8 | milestone | 0d | 2008-06-09 08:00 | 2008-06-09 08:00 |  | 40.23d |  | start no earlier than 2008-06-09 08:00 |  |  |  |
| 375 | 4.1.1.1.8.9 | Planning détaillé de suivi 9 | milestone | 0d | 2008-06-16 08:00 | 2008-06-16 08:00 |  | 35.85d |  | start no earlier than 2008-06-16 08:00 |  |  |  |
| 376 | 4.1.1.1.8.10 | Planning détaillé de suivi 10 | milestone | 0d | 2008-06-23 08:00 | 2008-06-23 08:00 |  | 31.48d |  | start no earlier than 2008-06-23 08:00 |  |  |  |
| 377 | 4.1.1.1.8.11 | Planning détaillé de suivi 11 | milestone | 0d | 2008-06-30 08:00 | 2008-06-30 08:00 |  | 27.1d |  | start no earlier than 2008-06-30 08:00 |  |  |  |
| 378 | 4.1.1.1.8.12 | Planning détaillé de suivi 12 | milestone | 0d | 2008-07-07 08:00 | 2008-07-07 08:00 |  | 22.73d |  | start no earlier than 2008-07-07 08:00 |  |  |  |
| 379 | 4.1.1.1.8.13 | Planning détaillé de suivi 13 | milestone | 0d | 2008-07-14 08:00 | 2008-07-14 08:00 |  | 18.35d |  | start no earlier than 2008-07-14 08:00 |  |  |  |
| 380 | 4.1.1.1.8.14 | Planning détaillé de suivi 14 | milestone | 0d | 2008-07-21 08:00 | 2008-07-21 08:00 |  | 13.98d |  | start no earlier than 2008-07-21 08:00 |  |  |  |
| 381 | 4.1.1.1.8.15 | Planning détaillé de suivi 15 | milestone | 0d | 2008-07-28 08:00 | 2008-07-28 08:00 |  | 9.6d |  | start no earlier than 2008-07-28 08:00 |  |  |  |
| 382 | 4.1.1.1.9 | **Mettre à jour la documentation** |  | 61.38d | 2008-04-21 09:00 | 2008-07-28 10:00 |  | 9.48d |  |  |  |  |  |
| 383 | 4.1.1.1.9.1 | Mettre à jour la documentation 1 |  | 1h | 2008-04-21 09:00 | 2008-04-21 10:00 |  | 70.73d |  | start no earlier than 2008-04-21 08:00 |  |  |  |
| 384 | 4.1.1.1.9.2 | Mettre à jour la documentation 2 |  | 1h | 2008-04-28 09:00 | 2008-04-28 10:00 |  | 66.35d |  | start no earlier than 2008-04-28 08:00 |  |  |  |
| 385 | 4.1.1.1.9.3 | Mettre à jour la documentation 3 |  | 1h | 2008-05-05 09:00 | 2008-05-05 10:00 |  | 61.98d |  | start no earlier than 2008-05-05 08:00 |  |  |  |
| 386 | 4.1.1.1.9.4 | Mettre à jour la documentation 4 |  | 1h | 2008-05-12 09:00 | 2008-05-12 10:00 |  | 57.6d |  | start no earlier than 2008-05-12 08:00 |  |  |  |
| 387 | 4.1.1.1.9.5 | Mettre à jour la documentation 5 |  | 1h | 2008-05-19 09:00 | 2008-05-19 10:00 |  | 53.23d |  | start no earlier than 2008-05-19 08:00 |  |  |  |
| 388 | 4.1.1.1.9.6 | Mettre à jour la documentation 6 |  | 1h | 2008-05-26 09:00 | 2008-05-26 10:00 |  | 48.85d |  | start no earlier than 2008-05-26 08:00 |  |  |  |
| 389 | 4.1.1.1.9.7 | Mettre à jour la documentation 7 |  | 1h | 2008-06-02 09:00 | 2008-06-02 10:00 |  | 44.48d |  | start no earlier than 2008-06-02 08:00 |  |  |  |
| 390 | 4.1.1.1.9.8 | Mettre à jour la documentation 8 |  | 1h | 2008-06-09 09:00 | 2008-06-09 10:00 |  | 40.1d |  | start no earlier than 2008-06-09 08:00 |  |  |  |
| 391 | 4.1.1.1.9.9 | Mettre à jour la documentation 9 |  | 1h | 2008-06-16 09:00 | 2008-06-16 10:00 |  | 35.73d |  | start no earlier than 2008-06-16 08:00 |  |  |  |
| 392 | 4.1.1.1.9.10 | Mettre à jour la documentation 10 |  | 1h | 2008-06-23 09:00 | 2008-06-23 10:00 |  | 31.35d |  | start no earlier than 2008-06-23 08:00 |  |  |  |
| 393 | 4.1.1.1.9.11 | Mettre à jour la documentation 11 |  | 1h | 2008-06-30 09:00 | 2008-06-30 10:00 |  | 26.98d |  | start no earlier than 2008-06-30 08:00 |  |  |  |
| 394 | 4.1.1.1.9.12 | Mettre à jour la documentation 12 |  | 1h | 2008-07-07 09:00 | 2008-07-07 10:00 |  | 22.6d |  | start no earlier than 2008-07-07 08:00 |  |  |  |
| 395 | 4.1.1.1.9.13 | Mettre à jour la documentation 13 |  | 1h | 2008-07-14 09:00 | 2008-07-14 10:00 |  | 18.23d |  | start no earlier than 2008-07-14 08:00 |  |  |  |
| 396 | 4.1.1.1.9.14 | Mettre à jour la documentation 14 |  | 1h | 2008-07-21 09:00 | 2008-07-21 10:00 |  | 13.85d |  | start no earlier than 2008-07-21 08:00 |  |  |  |
| 397 | 4.1.1.1.9.15 | Mettre à jour la documentation 15 |  | 1h | 2008-07-28 09:00 | 2008-07-28 10:00 |  | 9.48d |  | start no earlier than 2008-07-28 08:00 |  |  |  |
| 398 | 4.1.1.1.10 | Faire un bilan intermédiaire |  | 1d | 2008-05-15 09:00 | 2008-05-16 10:00 |  | 54.1d | 0d | start no earlier than 2008-05-15 09:00 | Karen [50%]; Henri [50%] | 8h | 2,800 |
| 399 | 4.1.1.1.11 | Bilan intermédiaire | milestone | 0d | 2008-05-16 10:00 | 2008-05-16 10:00 | 398 | 54.1d |  |  |  |  |  |
| 400 | 4.1.1.1.12 | Préparer la communication presse |  | 5d | 2008-05-26 09:00 | 2008-06-02 16:00 |  | 43.98d |  | start no earlier than 2008-05-26 08:00 | Christophe [20%] | 8h | 4,800 |
| 401 | 4.1.1.1.13 | Envoyer communication presse |  | 1d | 2008-06-26 09:00 | 2008-06-27 10:00 |  | 27.85d |  | start no earlier than 2008-06-26 09:00 | Christophe [25%] | 2h | 1,200 |
| 402 | 4.1.1.1.14 | Communication presse | milestone | 0d | 2008-08-05 11:48 | 2008-08-05 11:48 | 164, 401 | 4d |  |  |  |  |  |
| 403 | 4.1.1.1.15 | Rédiger la communication clients |  | 1d | 2008-06-26 09:00 | 2008-06-27 10:00 |  | 27.85d |  | start no earlier than 2008-06-26 09:00 | Henri [50%] | 4h |  |
| 404 | 4.1.1.1.16 | Envoyer la communication clients |  | 1d | 2008-08-05 11:48 | 2008-08-06 14:48 | 164 | 3d | 0d |  | Henri | 8h |  |
| 405 | 4.1.1.1.17 | Communication clients | milestone | 0d | 2008-08-06 14:48 | 2008-08-06 14:48 | 404 | 3d |  |  |  |  |  |

| ID | WBS | Task | Type | Duration | Start | Finish | Predecessors | Total slack | Resources | Work | Cost |
| --- | --- | --- | --- | --- | --- | --- | --- | --- | --- | --- | --- |
| 406 | 4.2 | **Faire le bilan du projet** |  | 4d | 2008-08-05 11:48 | 2008-08-11 17:48 |  | 0d |  | 35h | 19,050 |
| 407 | 4.2.1 | **Promotion** |  | 1d | 2008-08-05 11:48 | 2008-08-06 14:48 |  | 0d |  | 2h | 700 |
| 408 | 4.2.1.1 | Vendre le projet |  | 1d | 2008-08-05 11:48 | 2008-08-06 14:48 | 164 | 0d | Karen [12.5%]; Henri [12.5%] | 2h | 700 |
| 409 | 4.2.1.2 | Présentation de projet | milestone | 0d | 2008-08-06 14:48 | 2008-08-06 14:48 | 408 | 0d |  |  |  |
| 410 | 4.2.2 | **Désengagement** |  | 1d | 2008-08-06 14:48 | 2008-08-07 15:48 |  | 0d |  | 1h | 350 |
| 411 | 4.2.2.1 | Mettre un terme à l'engagement contractuel |  | 1d | 2008-08-06 14:48 | 2008-08-07 15:48 | 409 | 0d | Karen [6.2%]; Henri [6.2%] | 1h | 350 |
| 412 | 4.2.2.2 | Note de désengagement | milestone | 0d | 2008-08-07 15:48 | 2008-08-07 15:48 | 411 | 0d |  |  |  |
| 413 | 4.2.3 | **Capitalisation** |  | 2d | 2008-08-07 15:48 | 2008-08-11 17:48 |  | 0d |  | 32h | 18,000 |
| 414 | 4.2.3.1 | Organiser les réunions de débriefing |  | 1d | 2008-08-07 15:48 | 2008-08-08 16:48 | 412 | 0d | Karen [50%]; Christophe; Claudio; François | 28h | 15,600 |
| 415 | 4.2.3.2 | Bilan final de projet | milestone | 0d | 2008-08-08 16:48 | 2008-08-08 16:48 | 414 | 0d |  |  |  |
| 416 | 4.2.3.3 | Archiver les dossiers du projet |  | 1d | 2008-08-08 16:48 | 2008-08-11 17:48 | 415 | 0d | Christophe [50%] | 4h | 2,400 |
| 417 | 4.2.3.4 | Note d’archivage | milestone | 0d | 2008-08-11 17:48 | 2008-08-11 17:48 | 416 | 0d |  |  |  |
| 418 | 5 | Fin du projet | milestone | 0d | 2008-08-11 17:48 | 2008-08-11 17:48 | 417 | 0d |  |  |  |
