# Projet X

Schedule from MS Project, 2000-04-17 to 2000-09-22, costs in F, A marks actual dates.
X

## Calendars

- Standard: Mon-Fri 08:00-12:00, 13:00-17:00; Sat-Sun off. Exceptions (off unless hours are given): 2000-05-01, 2000-05-08, 2000-06-01, 2000-06-12.

## Resources

| Resource | Group | Rate | Cost per use |
| --- | --- | --- | --- |
| Karen | Epr | 700 |  |
| Christophe | Epr | 600 |  |
| Henri | Cpi |  |  |
| Philippe | Cpi |  |  |
| Patrick | Cpi |  |  |
| Claudio | Exp | 500 |  |
| François | Exp | 500 |  |
| Infographiste | Res | 400 |  |
| Programmeur 1 | Res | 300 |  |
| Programmeur 2 | Res | 300 |  |
| Machine de développement 1 | Mat |  | 200 |
| Machine de développement 2 | Mat |  | 200 |
| Machine de développement 3 | Mat |  | 200 |

## Schedule

| ID | WBS | Task | Type | Duration | Start | Finish | Predecessors | Complete | Baseline start | Baseline finish | Baseline duration | Resources | Work | Actual work | Cost | Baseline cost | Actual cost |
| --- | --- | --- | --- | --- | --- | --- | --- | --- | --- | --- | --- | --- | --- | --- | --- | --- | --- |
| 1 | 1 | Début du projet | milestone | 0d | 2000-04-17 08:00 A | 2000-04-17 08:00 A |  | 100% | 2000-04-17 08:00 | 2000-04-17 08:00 | 0d |  |  |  |  |  |  |
| 2 | 2 | **GESTION DU PROJET** |  | 6.78d | 2000-04-17 08:00 A | 2000-04-26 16:12 A |  | 100% | 2000-04-17 08:00 | 2000-04-26 16:12 | 7.9d |  | 49.35h | 49.35h | 25,595 | 25,595 | 25,595 |
| 3 | 2.1 | **Initialiser le projet** |  | 1.38d | 2000-04-17 08:00 A | 2000-04-18 15:00 A |  | 100% | 2000-04-17 08:00 | 2000-04-18 15:00 | 1.75d |  | 7h | 7h | 2,100 | 2,100 | 2,100 |
| 4 | 2.1.1 | **Réception** |  | 0.38d | 2000-04-17 08:00 A | 2000-04-17 12:00 A |  | 100% | 2000-04-17 08:00 | 2000-04-17 12:00 | 0.5d |  | 4h | 4h | 1,400 | 1,400 | 1,400 |
| 5 | 2.1.1.1 | Réceptionner la demande de projet du commanditaire |  | 0.12d | 2000-04-17 08:00 A | 2000-04-17 10:00 A |  | 100% | 2000-04-17 08:00 | 2000-04-17 10:00 | 0.25d | Henri [200%] | 2h | 2h |  |  |  |
| 6 | 2.1.1.2 | Demande de projet du commanditaire | milestone | 0d | 2000-04-17 10:00 A | 2000-04-17 10:00 A | 5 | 100% | 2000-04-17 10:00 | 2000-04-17 10:00 | 0d |  |  |  |  |  |  |
| 7 | 2.1.1.3 | Examiner la demande du commanditaire |  | 0.25d | 2000-04-17 10:00 A | 2000-04-17 12:00 A | 6 | 100% | 2000-04-17 10:00 | 2000-04-17 12:00 | 0.25d | Karen | 2h | 2h | 1,400 | 1,400 | 1,400 |
| 8 | 2.1.1.4 | Réponse à la demande de projet | milestone | 0d | 2000-04-17 12:00 A | 2000-04-17 12:00 A | 7 | 100% | 2000-04-17 12:00 | 2000-04-17 12:00 | 0d |  |  |  |  |  |  |
| 9 | 2.1.2 | **Affectation** |  | 1d | 2000-04-17 13:00 A | 2000-04-18 15:00 A |  | 100% | 2000-04-17 13:00 | 2000-04-18 15:00 | 1.25d |  | 3h | 3h | 700 | 700 | 700 |
| 10 | 2.1.2.1 | Officialiser la nomination du chef de projet |  | 0.12d | 2000-04-17 13:00 A | 2000-04-17 15:00 A | 7 | 100% | 2000-04-17 13:00 | 2000-04-17 15:00 | 0.25d | Karen; Henri [200%] | 3h | 3h | 700 | 700 | 700 |
| 11 | 2.1.2.2 | Note d’affectation du chef de projet | milestone | 0d | 2000-04-18 15:00 A | 2000-04-18 15:00 A | 10FS+1d | 100% | 2000-04-18 15:00 | 2000-04-18 15:00 | 0d |  |  |  |  |  |  |
| 12 | 2.2 | **Préparer le projet** |  | 3.5d | 2000-04-18 15:00 A | 2000-04-24 15:00 A |  | 100% | 2000-04-18 15:00 | 2000-04-24 15:00 | 4d |  | 28h | 28h | 14,600 | 14,600 | 14,600 |
| 13 | 2.2.1 | **Objet** |  | 0.25d | 2000-04-18 15:00 A | 2000-04-18 17:00 A |  | 100% | 2000-04-18 15:00 | 2000-04-18 17:00 | 0.25d |  | 2h | 2h | 1,400 | 1,400 | 1,400 |
| 14 | 2.2.1.1 | Définir l’objet précis du projet |  | 0.25d | 2000-04-18 15:00 A | 2000-04-18 17:00 A | 11 | 100% | 2000-04-18 15:00 | 2000-04-18 17:00 | 0.25d | Karen [50%] | 1h | 1h | 700 | 700 | 700 |
| 15 | 2.2.1.2 | Note de cadrage | milestone | 0d | 2000-04-18 17:00 A | 2000-04-18 17:00 A | 14 | 100% | 2000-04-18 17:00 | 2000-04-18 17:00 | 0d |  |  |  |  |  |  |
| 16 | 2.2.1.3 | Lister les motifs et définir le contexte |  | 0.25d | 2000-04-18 15:00 A | 2000-04-18 17:00 A | 11 | 100% | 2000-04-18 15:00 | 2000-04-18 17:00 | 0.25d | Karen [50%] | 1h | 1h | 700 | 700 | 700 |
| 17 | 2.2.1.4 | Note de cadrage (suite) | milestone | 0d | 2000-04-18 17:00 A | 2000-04-18 17:00 A | 16 | 100% | 2000-04-18 17:00 | 2000-04-18 17:00 | 0d |  |  |  |  |  |  |
| 18 | 2.2.2 | **Objectifs** |  | 0.5d | 2000-04-20 08:00 A | 2000-04-20 15:00 A |  | 100% | 2000-04-20 08:00 | 2000-04-20 15:00 | 0.75d |  | 12h | 12h | 5,750 | 5,750 | 5,750 |
| 19 | 2.2.2.1 | Définir les objectifs de qualité |  | 0.38d | 2000-04-20 08:00 A | 2000-04-20 12:00 A | 17FS+1d | 100% | 2000-04-20 08:00 | 2000-04-20 12:00 | 0.5d | Karen; Henri | 6h | 6h | 2,100 | 2,100 | 2,100 |
| 20 | 2.2.2.2 | Note de cadrage (suite) | milestone | 0d | 2000-04-20 12:00 A | 2000-04-20 12:00 A | 19 | 100% | 2000-04-20 12:00 | 2000-04-20 12:00 | 0d |  |  |  |  |  |  |
| 21 | 2.2.2.3 | Définir les objectifs de temps |  | 0.12d | 2000-04-20 08:00 A | 2000-04-20 10:00 A | 17FS+1d | 100% | 2000-04-20 08:00 | 2000-04-20 10:00 | 0.25d | Karen | 1h | 1h | 700 | 700 | 700 |
| 22 | 2.2.2.4 | macro-planning | milestone | 0d | 2000-04-20 10:00 A | 2000-04-20 10:00 A | 21 | 100% | 2000-04-20 10:00 | 2000-04-20 10:00 | 0d |  |  |  |  |  |  |
| 23 | 2.2.2.5 | Définir les objectifs de charge et de coûts |  | 0.12d | 2000-04-20 08:00 A | 2000-04-20 10:00 A | 17FS+1d | 100% | 2000-04-20 08:00 | 2000-04-20 10:00 | 0.25d | Karen | 1h | 1h | 700 | 700 | 700 |
| 24 | 2.2.2.6 | macro-planning de charge | milestone | 0d | 2000-04-20 10:00 A | 2000-04-20 10:00 A | 23 | 100% | 2000-04-20 10:00 | 2000-04-20 10:00 | 0d |  |  |  |  |  |  |
| 25 | 2.2.2.7 | Budget prévisionnel | milestone | 0d | 2000-04-20 10:00 A | 2000-04-20 10:00 A | 23 | 100% | 2000-04-20 10:00 | 2000-04-20 10:00 | 0d |  |  |  |  |  |  |
| 26 | 2.2.2.8 | Définir les objectifs de communication |  | 0.25d | 2000-04-20 10:00 A | 2000-04-20 12:00 A | 23 | 100% | 2000-04-20 10:00 | 2000-04-20 12:00 | 0.25d | Christophe | 2h | 2h | 1,200 | 1,200 | 1,200 |
| 27 | 2.2.2.9 | Stratégie de communication | milestone | 0d | 2000-04-20 12:00 A | 2000-04-20 12:00 A | 26 | 100% | 2000-04-20 12:00 | 2000-04-20 12:00 | 0d |  |  |  |  |  |  |
| 28 | 2.2.2.10 | Définir les objectifs complémentaires |  | 0.12d | 2000-04-20 08:00 A | 2000-04-20 10:00 A | 17FS+1d | 100% | 2000-04-20 08:00 | 2000-04-20 10:00 | 0.25d | Karen [25%]; Henri [25%] | 0.5h | 0.5h | 175 | 175 | 175 |
| 29 | 2.2.2.11 | Note de cadrage (suite) | milestone | 0d | 2000-04-20 10:00 A | 2000-04-20 10:00 A | 28 | 100% | 2000-04-20 10:00 | 2000-04-20 10:00 | 0d |  |  |  |  |  |  |
| 30 | 2.2.2.12 | Préciser les contraintes sur objectifs |  | 0.25d | 2000-04-20 10:00 A | 2000-04-20 12:00 A | 29 | 100% | 2000-04-20 10:00 | 2000-04-20 12:00 | 0.25d | Karen [12.5%]; Henri [12.5%] | 0.5h | 0.5h | 175 | 175 | 175 |
| 31 | 2.2.2.13 | Note de cadrage (suite) | milestone | 0d | 2000-04-20 12:00 A | 2000-04-20 12:00 A | 30 | 100% | 2000-04-20 12:00 | 2000-04-20 12:00 | 0d |  |  |  |  |  |  |
| 32 | 2.2.2.14 | Vérifier l’adéquation entre les objectifs |  | 0.12d | 2000-04-20 13:00 A | 2000-04-20 15:00 A | 31 | 100% | 2000-04-20 13:00 | 2000-04-20 15:00 | 0.25d | Karen | 1h | 1h | 700 | 700 | 700 |
| 33 | 2.2.2.15 | Note de cadrage (suite) | milestone | 0d | 2000-04-20 15:00 A | 2000-04-20 15:00 A | 32 | 100% | 2000-04-20 15:00 | 2000-04-20 15:00 | 0d |  |  |  |  |  |  |

| ID | WBS | Task | Type | Duration | Start | Finish | Predecessors | Complete | Baseline start | Baseline finish | Baseline duration | Resources | Work | Actual work | Cost | Baseline cost | Actual cost |
| --- | --- | --- | --- | --- | --- | --- | --- | --- | --- | --- | --- | --- | --- | --- | --- | --- | --- |
| 34 | 2.2.3 | **Domaine** |  | 1.12d | 2000-04-20 15:00 A | 2000-04-21 17:00 A |  | 100% | 2000-04-20 15:00 | 2000-04-21 17:00 | 1.25d |  | 5h | 5h | 3,500 | 3,500 | 3,500 |
| 35 | 2.2.3.1 | Identifier le périmètre et les acteurs |  | 0.88d | 2000-04-20 15:00 A | 2000-04-21 15:00 A | 33 | 100% | 2000-04-20 15:00 | 2000-04-21 15:00 | 1d | Karen [57.1%] | 4h | 4h | 2,800 | 2,800 | 2,800 |
| 36 | 2.2.3.2 | Fichier des acteurs | milestone | 0d | 2000-04-21 15:00 A | 2000-04-21 15:00 A | 35 | 100% | 2000-04-21 15:00 | 2000-04-21 15:00 | 0d |  |  |  |  |  |  |
| 37 | 2.2.3.3 | Définir la structure choisie pour la gestion du projet |  | 0.12d | 2000-04-21 13:00 A | 2000-04-21 15:00 A | 33, 35FF | 100% | 2000-04-21 13:00 | 2000-04-21 15:00 | 0.25d | Karen [50%] | 0.5h | 0.5h | 350 | 350 | 350 |
| 38 | 2.2.3.4 | Organigramme Projet | milestone | 0d | 2000-04-21 15:00 A | 2000-04-21 15:00 A | 37 | 100% | 2000-04-21 15:00 | 2000-04-21 15:00 | 0d |  |  |  |  |  |  |
| 39 | 2.2.3.5 | Définir les rôles des acteurs dans les structures projets |  | 0.25d | 2000-04-21 15:00 A | 2000-04-21 17:00 A | 38 | 100% | 2000-04-21 15:00 | 2000-04-21 17:00 | 0.25d | Karen [25%] | 0.5h | 0.5h | 350 | 350 | 350 |
| 40 | 2.2.3.6 | Fiche de poste | milestone | 0d | 2000-04-21 17:00 A | 2000-04-21 17:00 A | 39 | 100% | 2000-04-21 17:00 | 2000-04-21 17:00 | 0d |  |  |  |  |  |  |
| 41 | 2.2.3.7 | Carte des acteurs | milestone | 0d | 2000-04-21 17:00 A | 2000-04-21 17:00 A | 39 | 100% | 2000-04-21 17:00 | 2000-04-21 17:00 | 0d |  |  |  |  |  |  |
| 42 | 2.2.4 | **Risques** |  | 0.12d | 2000-04-24 08:00 A | 2000-04-24 10:00 A |  | 100% | 2000-04-24 08:00 | 2000-04-24 10:00 | 0.25d |  | 3h | 3h | 1,050 | 1,050 | 1,050 |
| 43 | 2.2.4.1 | Identifier, analyser et gérer les freins |  | 0.12d | 2000-04-24 08:00 A | 2000-04-24 10:00 A | 41 | 100% | 2000-04-24 08:00 | 2000-04-24 10:00 | 0.25d | Karen; Henri | 2h | 2h | 700 | 700 | 700 |
| 44 | 2.2.4.2 | Grille des freins | milestone | 0d | 2000-04-24 10:00 A | 2000-04-24 10:00 A | 43 | 100% | 2000-04-24 10:00 | 2000-04-24 10:00 | 0d |  |  |  |  |  |  |
| 45 | 2.2.4.3 | Identifier, analyser et gérer les facilitants |  | 0.12d | 2000-04-24 08:00 A | 2000-04-24 10:00 A | 41 | 100% | 2000-04-24 08:00 | 2000-04-24 10:00 | 0.25d | Karen [50%]; Henri [50%] | 1h | 1h | 350 | 350 | 350 |
| 46 | 2.2.4.4 | Grille des facilitants | milestone | 0d | 2000-04-24 10:00 A | 2000-04-24 10:00 A | 44 | 100% | 2000-04-24 10:00 | 2000-04-24 10:00 | 0d |  |  |  |  |  |  |
| 47 | 2.2.5 | **Méthode** |  | 0.12d | 2000-04-24 08:00 A | 2000-04-24 10:00 A |  | 100% | 2000-04-24 08:00 | 2000-04-24 10:00 | 0.25d |  | 2h | 2h | 1,000 | 1,000 | 1,000 |
| 48 | 2.2.5.1 | Choisir une méthode et structurer la réal. du produit |  | 0.12d | 2000-04-24 08:00 A | 2000-04-24 10:00 A | 41 | 100% | 2000-04-24 08:00 | 2000-04-24 10:00 | 0.25d | Claudio; François | 2h | 2h | 1,000 | 1,000 | 1,000 |
| 49 | 2.2.5.2 | Fiche méthode | milestone | 0d | 2000-04-24 10:00 A | 2000-04-24 10:00 A | 48 | 100% | 2000-04-24 10:00 | 2000-04-24 10:00 | 0d |  |  |  |  |  |  |
| 50 | 2.2.6 | **Communication** |  | 0.25d | 2000-04-24 10:00 A | 2000-04-24 12:00 A |  | 100% | 2000-04-24 10:00 | 2000-04-24 12:00 | 0.25d |  | 2h | 2h | 1,200 | 1,200 | 1,200 |
| 51 | 2.2.6.1 | Définir les axes, cibles et moyens de communication |  | 0.25d | 2000-04-24 10:00 A | 2000-04-24 12:00 A | 46 | 100% | 2000-04-24 10:00 | 2000-04-24 12:00 | 0.25d | Christophe | 2h | 2h | 1,200 | 1,200 | 1,200 |
| 52 | 2.2.6.2 | Charte graphique | milestone | 0d | 2000-04-24 12:00 A | 2000-04-24 12:00 A | 51 | 100% | 2000-04-24 12:00 | 2000-04-24 12:00 | 0d |  |  |  |  |  |  |
| 53 | 2.2.6.3 | Plan de communication | milestone | 0d | 2000-04-24 12:00 A | 2000-04-24 12:00 A | 51 | 100% | 2000-04-24 12:00 | 2000-04-24 12:00 | 0d |  |  |  |  |  |  |
| 54 | 2.2.7 | **Contractualisation** |  | 0.12d | 2000-04-24 13:00 A | 2000-04-24 15:00 A |  | 100% | 2000-04-24 13:00 | 2000-04-24 15:00 | 0.25d |  | 2h | 2h | 700 | 700 | 700 |
| 55 | 2.2.7.1 | Rédiger la note de cadrage |  | 0.12d | 2000-04-24 13:00 A | 2000-04-24 15:00 A | 53 | 100% | 2000-04-24 13:00 | 2000-04-24 15:00 | 0.25d | Henri; Karen | 2h | 2h | 700 | 700 | 700 |
| 56 | 2.2.7.2 | Note de cadrage (suite) | milestone | 0d | 2000-04-24 15:00 A | 2000-04-24 15:00 A | 55 | 100% | 2000-04-24 15:00 | 2000-04-24 15:00 | 0d |  |  |  |  |  |  |
| 57 | 2.3 | **Planifier le projet** |  | 1.52d | 2000-04-24 15:00 A | 2000-04-26 11:12 A |  | 100% | 2000-04-24 15:00 | 2000-04-26 11:12 | 1.65d |  | 11.35h | 11.35h | 7,045 | 7,045 | 7,045 |
| 58 | 2.3.1 | **Planification détallée** |  | 1.02d | 2000-04-24 15:00 A | 2000-04-25 16:12 A |  | 100% | 2000-04-24 15:00 | 2000-04-25 16:12 | 1.15d |  | 6.35h | 6.35h | 4,045 | 4,045 | 4,045 |
| 59 | 2.3.1.1 | Définir l’environnement de planification |  | 0.1d | 2000-04-24 15:00 A | 2000-04-24 15:48 A | 56 | 100% | 2000-04-24 15:00 | 2000-04-24 15:48 | 0.1d | Karen [62.5%] | 0.5h | 0.5h | 350 | 350 | 350 |
| 60 | 2.3.1.2 | Charte de planification | milestone | 0d | 2000-04-24 15:48 A | 2000-04-24 15:48 A | 59 | 100% | 2000-04-24 15:48 | 2000-04-24 15:48 | 0d |  |  |  |  |  |  |
| 61 | 2.3.1.3 | Ordonner la liste des tâches de fabrication du produit |  | 0.28d | 2000-04-24 15:48 A | 2000-04-25 08:48 A | 60 | 100% | 2000-04-24 15:48 | 2000-04-25 08:48 | 0.25d | Karen [45.5%]; Claudio [45.5%]; François [45.5%] | 3h | 3h | 1,700 | 1,700 | 1,700 |
| 62 | 2.3.1.4 | Organigramme des tâches | milestone | 0d | 2000-04-25 08:48 A | 2000-04-25 08:48 A | 61 | 100% | 2000-04-25 08:48 | 2000-04-25 08:48 | 0d |  |  |  |  |  |  |
| 63 | 2.3.1.5 | Affecter des durées ou des charges aux tâches |  | 0.07d | 2000-04-25 08:48 A | 2000-04-25 09:36 A | 62 | 100% | 2000-04-25 08:48 | 2000-04-25 09:36 | 0.1d | Karen [83.3%] | 0.5h | 0.5h | 350 | 350 | 350 |
| 64 | 2.3.1.6 | Planning détaillé | milestone | 0d | 2000-04-25 09:36 A | 2000-04-25 09:36 A | 63 | 100% | 2000-04-25 09:36 | 2000-04-25 09:36 | 0d |  |  |  |  |  |  |
| 65 | 2.3.1.7 | Définir les liens entre les tâches |  | 0.1d | 2000-04-25 09:36 A | 2000-04-25 10:24 A | 64 | 100% | 2000-04-25 09:36 | 2000-04-25 10:24 | 0.1d | Karen [31.2%] | 0.25h | 0.25h | 175 | 175 | 175 |
| 66 | 2.3.1.8 | Planning détaillé (suite) | milestone | 0d | 2000-04-25 10:24 A | 2000-04-25 10:24 A | 65 | 100% | 2000-04-25 10:24 | 2000-04-25 10:24 | 0d |  |  |  |  |  |  |
| 67 | 2.3.1.9 | Intégrer les tâches de gestion de projet |  | 0.1d | 2000-04-25 10:24 A | 2000-04-25 11:12 A | 66 | 100% | 2000-04-25 10:24 | 2000-04-25 11:12 | 0.1d | Karen [12.5%] | 0.1h | 0.1h | 70 | 70 | 70 |
| 68 | 2.3.1.10 | Planning détaillé (suite) | milestone | 0d | 2000-04-25 11:12 A | 2000-04-25 11:12 A | 67 | 100% | 2000-04-25 11:12 | 2000-04-25 11:12 | 0d |  |  |  |  |  |  |
| 69 | 2.3.1.11 | Affecter les ressources sur les tâches |  | 0.38d | 2000-04-25 11:12 A | 2000-04-25 16:12 A | 68 | 100% | 2000-04-25 11:12 | 2000-04-25 16:12 | 0.5d | Karen [66.7%] | 2h | 2h | 1,400 | 1,400 | 1,400 |
| 70 | 2.3.1.12 | Tableau des ressources | milestone | 0d | 2000-04-25 16:12 A | 2000-04-25 16:12 A | 69 | 100% | 2000-04-25 16:12 | 2000-04-25 16:12 | 0d |  |  |  |  |  |  |
| 71 | 2.3.1.13 | Planning détaillé (suite) | milestone | 0d | 2000-04-25 16:12 A | 2000-04-25 16:12 A | 70 | 100% | 2000-04-25 16:12 | 2000-04-25 16:12 | 0d |  |  |  |  |  |  |

| ID | WBS | Task | Type | Duration | Start | Finish | Predecessors | Complete | Remaining | Baseline start | Baseline finish | Baseline duration | Total slack | Resources | Work | Actual work | Cost | Baseline cost | Actual cost |
| --- | --- | --- | --- | --- | --- | --- | --- | --- | --- | --- | --- | --- | --- | --- | --- | --- | --- | --- | --- |
| 72 | 2.3.2 | **Validation** |  | 0.5d | 2000-04-25 16:12 A | 2000-04-26 11:12 A |  | 100% |  | 2000-04-25 16:12 | 2000-04-26 11:12 | 0.5d |  |  | 5h | 5h | 3,000 | 3,000 | 3,000 |
| 73 | 2.3.2.1 | Optimiser le planning détaillé du prévu |  | 0.25d | 2000-04-25 16:12 A | 2000-04-26 09:12 A | 71 | 100% |  | 2000-04-25 16:12 | 2000-04-26 09:12 | 0.25d |  | Karen [50%]; Claudio [50%]; François [50%] | 3h | 3h | 1,700 | 1,700 | 1,700 |
| 74 | 2.3.2.2 | Planning détaillé (suite) | milestone | 0d | 2000-04-26 09:12 A | 2000-04-26 09:12 A | 73 | 100% |  | 2000-04-26 09:12 | 2000-04-26 09:12 | 0d |  |  |  |  |  |  |  |
| 75 | 2.3.2.3 | Valider, communiquer et enregistrer le planning |  | 0.25d | 2000-04-26 09:12 A | 2000-04-26 11:12 A | 74 | 100% |  | 2000-04-26 09:12 | 2000-04-26 11:12 | 0.25d |  | Karen [50%]; Christophe [50%] | 2h | 2h | 1,300 | 1,300 | 1,300 |
| 76 | 2.3.2.4 | Contrat de planning | milestone | 0d | 2000-04-26 11:12 A | 2000-04-26 11:12 A | 75 | 100% |  | 2000-04-26 11:12 | 2000-04-26 11:12 | 0d |  |  |  |  |  |  |  |
| 77 | 2.4 | **Piloter le projet** |  | 0.38d | 2000-04-26 11:12 A | 2000-04-26 16:12 A |  | 100% |  | 2000-04-26 11:12 | 2000-04-26 16:12 | 0.5d |  |  | 3h | 3h | 1,850 | 1,850 | 1,850 |
| 78 | 2.4.1 | **Lancement** |  | 0.38d | 2000-04-26 11:12 A | 2000-04-26 16:12 A |  | 100% |  | 2000-04-26 11:12 | 2000-04-26 16:12 | 0.5d |  |  | 3h | 3h | 1,850 | 1,850 | 1,850 |
| 79 | 2.4.1.1 | Lancer la réalisation |  | 0.12d | 2000-04-26 11:12 A | 2000-04-26 14:12 A | 76 | 100% |  | 2000-04-26 11:12 | 2000-04-26 14:12 | 0.25d |  | Karen [50%]; Christophe [50%] | 1h | 1h | 650 | 650 | 650 |
| 80 | 2.4.1.2 | Journal du projet | milestone | 0d | 2000-04-26 14:12 A | 2000-04-26 14:12 A | 79 | 100% |  | 2000-04-26 14:12 | 2000-04-26 14:12 | 0d |  |  |  |  |  |  |  |
| 81 | 2.4.1.3 | Fiche de reporting | milestone | 0d | 2000-04-26 14:12 A | 2000-04-26 14:12 A | 80 | 100% |  | 2000-04-26 14:12 | 2000-04-26 14:12 | 0d |  |  |  |  |  |  |  |
| 82 | 2.4.1.4 | Mettre en œuvre le plan de communication |  | 0.25d | 2000-04-26 14:12 A | 2000-04-26 16:12 A | 81 | 100% |  | 2000-04-26 14:12 | 2000-04-26 16:12 | 0.25d |  | Christophe | 2h | 2h | 1,200 | 1,200 | 1,200 |
| 83 | 2.4.1.5 | Plan de communication (suite) | milestone | 0d | 2000-04-26 16:12 A | 2000-04-26 16:12 A | 82 | 100% |  | 2000-04-26 16:12 | 2000-04-26 16:12 | 0d |  |  |  |  |  |  |  |
| 84 | 3 | **FABRICATION DU PRODUIT** |  | 86.13d | 2000-04-26 16:12 A | 2000-09-18 10:12 |  | 45% | 47.55d | 2000-04-26 16:12 | 2000-08-30 09:12 | 85.25d | 4d |  | 1338.67h | 632.57h | 279,815.24 | 281,860 | 111,595.88 |
| 85 | 3.1 | **Etude de la gestion des stocks** |  | 12.25d | 2000-04-26 16:12 A | 2000-05-18 16:12 A |  | 100% |  | 2000-04-26 16:12 | 2000-05-04 16:12 | 5d |  |  | 56h | 56h |  |  |  |
| 86 | 3.1.1 | **Etude opérationnelle** |  | 9.62d | 2000-04-26 16:12 A | 2000-05-15 16:12 A |  | 100% |  | 2000-04-26 16:12 | 2000-04-28 16:12 | 2d |  |  | 44h | 44h |  |  |  |
| 87 | 3.1.1.1 | Analyse de l'existant |  | 8.75d | 2000-04-26 16:12 A | 2000-05-12 16:12 A | 83 | 100% |  | 2000-04-26 16:12 | 2000-04-27 16:12 | 1d |  | Patrick [57.1%] | 40h | 40h |  |  |  |
| 88 | 3.1.1.2 | Feuille d'analyse | milestone | 0d | 2000-05-12 16:12 A | 2000-05-12 16:12 A | 87 | 100% |  | 2000-04-27 16:12 | 2000-04-27 16:12 | 0d |  |  |  |  |  |  |  |
| 89 | 3.1.1.3 | Recherche des améliorations |  | 0.88d | 2000-05-12 16:12 A | 2000-05-15 16:12 A | 88 | 100% |  | 2000-04-27 16:12 | 2000-04-28 16:12 | 1d |  | Patrick [57.1%] | 4h | 4h |  |  |  |
| 90 | 3.1.1.4 | Liste des améliorations | milestone | 0d | 2000-05-15 16:12 A | 2000-05-15 16:12 A | 89 | 100% |  | 2000-04-28 16:12 | 2000-04-28 16:12 | 0d |  |  |  |  |  |  |  |
| 91 | 3.1.2 | **Etude fonctionnelle** |  | 12.25d | 2000-04-26 16:12 A | 2000-05-18 16:12 A |  | 100% |  | 2000-04-26 16:12 | 2000-05-04 16:12 | 5d |  |  | 12h | 12h |  |  |  |
| 92 | 3.1.2.1 | Analyse de l'existant |  | 0.88d | 2000-04-26 16:12 A | 2000-04-27 16:12 A | 83 | 100% |  | 2000-04-26 16:12 | 2000-04-27 16:12 | 1d |  | Henri [57.1%] | 4h | 4h |  |  |  |
| 93 | 3.1.2.2 | Organigramme fonctionnel | milestone | 0d | 2000-05-15 16:12 A | 2000-05-15 16:12 A | 92, 90 | 100% |  | 2000-04-28 16:12 | 2000-04-28 16:12 | 0d |  |  |  |  |  |  |  |
| 94 | 3.1.2.3 | Rédaction du cahier des charges |  | 1.62d | 2000-05-15 16:12 A | 2000-05-18 16:12 A | 93 | 100% |  | 2000-04-28 16:12 | 2000-05-04 16:12 | 2d |  | Henri [61.5%] | 8h | 8h |  |  |  |
| 95 | 3.1.2.4 | Cahier des charges | milestone | 0d | 2000-05-18 16:12 A | 2000-05-18 16:12 A | 94 | 100% |  | 2000-05-04 16:12 | 2000-05-04 16:12 | 0d |  |  |  |  |  |  |  |

| ID | WBS | Task | Type | Duration | Start | Finish | Predecessors | Complete | Remaining | Baseline start | Baseline finish | Baseline duration | Total slack | Resources | Work | Actual work | Cost | Baseline cost | Actual cost |
| --- | --- | --- | --- | --- | --- | --- | --- | --- | --- | --- | --- | --- | --- | --- | --- | --- | --- | --- | --- |
| 96 | 3.2 | **Mise en place de la gestion des stocks** |  | 41.34d | 2000-05-18 16:12 A | 2000-07-26 17:54 |  | 78% | 9.27d | 2000-05-04 16:12 | 2000-07-19 15:09 | 50.87d | 36.54d |  | 286.8h | 254.8h | 65,708.57 | 67,700 | 56,108.57 |
| 97 | 3.2.1 | **Recherche progiciels** |  | 2.62d | 2000-05-18 16:12 A | 2000-05-23 16:12 A |  | 100% |  | 2000-05-04 16:12 | 2000-05-15 16:12 | 6d |  |  | 7.2h | 7.2h | 3,600 | 6,000 | 3,600 |
| 98 | 3.2.1.1 | Recherche des prestataires |  | 1.75d | 2000-05-18 16:12 A | 2000-05-22 16:12 A | 95 | 100% |  | 2000-05-04 16:12 | 2000-05-12 16:12 | 5d |  | Claudio [22.9%] | 3.2h | 3.2h | 1,600 | 4,000 | 1,600 |
| 99 | 3.2.1.2 | Liste des prestataires | milestone | 0d | 2000-05-22 16:12 A | 2000-05-22 16:12 A | 98 | 100% |  | 2000-05-12 16:12 | 2000-05-12 16:12 | 0d |  |  |  |  |  |  |  |
| 100 | 3.2.1.3 | Présélection des progiciels |  | 0.88d | 2000-05-22 16:12 A | 2000-05-23 16:12 A | 99 | 100% |  | 2000-05-12 16:12 | 2000-05-15 16:12 | 1d |  | Claudio [57.1%] | 4h | 4h | 2,000 | 2,000 | 2,000 |
| 101 | 3.2.1.4 | Liste des logiciels | milestone | 0d | 2000-05-23 16:12 A | 2000-05-23 16:12 A | 100 | 100% |  | 2000-05-15 16:12 | 2000-05-15 16:12 | 0d |  |  |  |  |  |  |  |
| 102 | 3.2.2 | **Choix progiciels** |  | 2.38d | 2000-05-23 16:12 A | 2000-05-26 14:12 A |  | 100% |  | 2000-05-15 16:12 | 2000-05-17 14:12 | 1.75d |  |  | 15h | 15h | 4,500 | 2,500 | 4,500 |
| 103 | 3.2.2.1 | Réalisation d'un dossier de choix |  | 1.75d | 2000-05-23 16:12 A | 2000-05-25 16:12 A | 101 | 100% |  | 2000-05-15 16:12 | 2000-05-16 16:12 | 1d |  | Claudio [57.1%] | 8h | 8h | 4,000 | 2,000 | 4,000 |
| 104 | 3.2.2.2 | Choix du progiciel |  | 0.25d | 2000-05-25 16:12 A | 2000-05-26 09:12 A | 103 | 100% |  | 2000-05-16 16:12 | 2000-05-17 09:12 | 0.25d |  | Claudio [50%]; Henri [55.6%]; Patrick [55.6%] | 3h | 3h | 500 | 500 | 500 |
| 105 | 3.2.2.3 | Dossier de choix | milestone | 0d | 2000-05-26 09:12 A | 2000-05-26 09:12 A | 104 | 100% |  | 2000-05-17 09:12 | 2000-05-17 09:12 | 0d |  |  |  |  |  |  |  |
| 106 | 3.2.2.4 | Passage de la commande |  | 0.38d | 2000-05-26 09:12 A | 2000-05-26 14:12 A | 105 | 100% |  | 2000-05-17 09:12 | 2000-05-17 14:12 | 0.5d |  | Henri [133.3%] | 4h | 4h |  |  |  |
| 107 | 3.2.2.5 | Bon de commande | milestone | 0d | 2000-05-26 14:12 A | 2000-05-26 14:12 A | 106 | 100% |  | 2000-05-17 14:12 | 2000-05-17 14:12 | 0d |  |  |  |  |  |  |  |
| 108 | 3.2.3 | **Mise en place** |  | 19.37d | 2000-05-26 09:12 A | 2000-06-29 10:09 A |  | 100% |  | 2000-05-17 09:12 | 2000-06-19 15:09 | 21.62d |  |  | 48h | 48h | 20,000 | 23,000 | 20,000 |
| 109 | 3.2.3.1 | Commande des matériels |  | 0.88d | 2000-05-26 09:12 A | 2000-05-29 09:12 A | 105 | 100% |  | 2000-05-17 09:12 | 2000-05-17 14:12 | 0.5d |  | Claudio [57.1%] | 4h | 4h | 2,000 | 1,000 | 2,000 |
| 110 | 3.2.3.2 | Bon de commande | milestone | 0d | 2000-05-29 09:12 A | 2000-05-29 09:12 A | 109 | 100% |  | 2000-05-17 14:12 | 2000-05-17 14:12 | 0d |  |  |  |  |  |  |  |
| 111 | 3.2.3.3 | Vérification des matériels |  | 0.88d | 2000-05-29 09:12 A | 2000-05-30 09:12 A | 110 | 100% |  | 2000-05-17 14:12 | 2000-05-18 14:12 | 1d |  | Programmeur 1 [114.3%] | 8h | 8h | 2,400 | 2,400 | 2,400 |
| 112 | 3.2.3.4 | PV de réception | milestone | 0d | 2000-05-30 09:12 A | 2000-05-30 09:12 A | 111 | 100% |  | 2000-05-18 14:12 | 2000-05-18 14:12 | 0d |  |  |  |  |  |  |  |
| 113 | 3.2.3.5 | Installation des matériels |  | 0.88d | 2000-05-30 09:12 A | 2000-06-16 09:27 A | 112 | 100% |  | 2000-05-18 14:12 | 2000-06-05 14:27 | 1d |  | Programmeur 2 [114.2%] | 8h | 8h | 2,400 | 2,400 | 2,400 |
| 114 | 3.2.3.6 | Installation du réseau |  | 0.88d | 2000-05-30 09:12 A | 2000-05-31 09:27 A | 112 | 100% |  | 2000-05-18 14:12 | 2000-05-22 14:27 | 2d |  | Claudio [114.3%] | 8h | 8h | 4,000 | 8,000 | 4,000 |
| 115 | 3.2.3.7 | Partie matérielle installée | milestone | 0d | 2000-06-16 09:27 A | 2000-06-16 09:27 A | 114, 113 | 100% |  | 2000-06-05 14:27 | 2000-06-05 14:27 | 0d |  |  |  |  |  |  |  |
| 116 | 3.2.3.8 | Installation des systèmes d'exploitation |  | 1.75d | 2000-06-16 09:27 A | 2000-06-20 09:42 A | 115 | 100% |  | 2000-06-05 14:27 | 2000-06-07 14:42 | 2d |  | Claudio [114.3%] | 16h | 16h | 8,000 | 8,000 | 8,000 |
| 117 | 3.2.3.9 | Installation du progiciel de gestion des stocks |  | 0.12d | 2000-06-20 09:42 A | 2000-06-29 10:09 A | 116 | 100% |  | 2000-06-07 14:42 | 2000-06-19 15:09 | 1d |  | Programmeur 2 [400%] | 4h | 4h | 1,200 | 1,200 | 1,200 |
| 118 | 3.2.3.10 | Partie logicielle installée | milestone | 0d | 2000-06-29 10:09 A | 2000-06-29 10:09 A | 117 | 100% |  | 2000-06-19 15:09 | 2000-06-19 15:09 | 0d |  |  |  |  |  |  |  |
| 119 | 3.2.4 | **Paramétrage** |  | 19.31d | 2000-05-26 09:12 A | 2000-06-29 09:42 A |  | 100% |  | 2000-05-17 09:12 | 2000-06-16 09:57 | 20.09d |  |  | 144.6h | 144.6h | 23,208.57 | 19,400 | 23,208.57 |
| 120 | 3.2.4.1 | Définition des paramètres |  | 1.75d | 2000-05-26 09:12 A | 2000-05-30 09:12 A | 105 | 100% |  | 2000-05-17 09:12 | 2000-05-19 09:12 | 2d |  | Patrick [28.6%] | 4h | 4h |  |  |  |
| 121 | 3.2.4.2 | Paramétrage du logiciel |  | 13.33d | 2000-05-30 09:12 A | 2000-06-29 09:42 A | 120 | 100% |  | 2000-05-19 09:12 | 2000-06-16 09:57 | 14.03d |  | Programmeur 2 [101.1%]; Machine de développement 3 [114.3%] | 140.6h | 140.6h | 23,208.57 | 19,400 | 23,208.57 |
| 122 | 3.2.4.3 | Logiciel paramétré | milestone | 0d | 2000-06-29 09:42 A | 2000-06-29 09:42 A | 121 | 100% |  | 2000-06-16 09:57 | 2000-06-16 09:57 | 0d |  |  |  |  |  |  |  |

| ID | WBS | Task | Type | Duration | Start | Finish | Predecessors | Complete | Remaining | Baseline start | Baseline finish | Baseline duration | Total slack | Free slack | Resources | Work | Actual work | Cost | Baseline cost | Actual cost |
| --- | --- | --- | --- | --- | --- | --- | --- | --- | --- | --- | --- | --- | --- | --- | --- | --- | --- | --- | --- | --- |
| 123 | 3.2.5 | **Tests** |  | 21.46d | 2000-05-26 09:12 A | 2000-07-03 14:54 A |  | 100% |  | 2000-05-17 09:12 | 2000-06-20 15:09 | 22.62d |  |  |  | 24h | 24h | 2,400 | 2,400 | 2,400 |
| 124 | 3.2.5.1 | Définition des données de test |  | 1.75d | 2000-05-26 09:12 A | 2000-05-30 09:12 A | 105 | 100% |  | 2000-05-17 09:12 | 2000-05-19 09:12 | 2d |  |  | Patrick [57.1%] | 8h | 8h |  |  |  |
| 125 | 3.2.5.2 | Tests du logiciel |  | 2.15d | 2000-06-29 09:42 A | 2000-07-03 14:54 A | 121, 124 | 100% |  | 2000-06-16 09:57 | 2000-06-20 15:09 | 2.52d |  |  | Patrick [47.1%]; Programmeur 2 [114.3%] | 16h | 16h | 2,400 | 2,400 | 2,400 |
| 126 | 3.2.5.3 | Logiciel testé | milestone | 0d | 2000-07-03 14:54 A | 2000-07-03 14:54 A | 125 | 100% |  | 2000-06-20 15:09 | 2000-06-20 15:09 | 0d |  |  |  |  |  |  |  |  |
| 127 | 3.2.6 | **Recette** |  | 5.25d | 2000-07-03 14:54 A | 2000-07-11 14:54 A |  | 100% |  | 2000-06-20 15:09 | 2000-07-05 15:09 | 11d |  |  |  | 16h | 16h | 2,400 | 4,800 | 2,400 |
| 128 | 3.2.6.1 | Effectuer la recette |  | 0.88d | 2000-07-03 14:54 A | 2000-07-04 14:54 A | 126 | 100% |  | 2000-06-20 15:09 | 2000-06-21 15:09 | 1d |  |  | Henri [114.3%] | 8h | 8h |  |  |  |
| 129 | 3.2.6.2 | PV de recette | milestone | 0d | 2000-07-04 14:54 A | 2000-07-04 14:54 A | 128 | 100% |  | 2000-06-21 15:09 | 2000-06-21 15:09 | 0d |  |  |  |  |  |  |  |  |
| 130 | 3.2.6.3 | Mettre en production |  | 4.38d | 2000-07-04 14:54 A | 2000-07-11 14:54 A | 129 | 100% |  | 2000-06-21 15:09 | 2000-07-05 15:09 | 10d |  |  | Programmeur 2 [22.9%] | 8h | 8h | 2,400 | 4,800 | 2,400 |
| 131 | 3.2.6.4 | Logiciel opérationnel | milestone | 0d | 2000-07-11 14:54 A | 2000-07-11 14:54 A | 130 | 100% |  | 2000-07-05 15:09 | 2000-07-05 15:09 | 0d |  |  |  |  |  |  |  |  |
| 132 | 3.2.7 | **Formation** |  | 10d | 2000-07-11 14:54 | 2000-07-26 17:54 |  |  |  | 2000-07-05 15:09 | 2000-07-19 15:09 | 10d | 36.54d |  |  | 32h |  | 9,600 | 9,600 |  |
| 133 | 3.2.7.1 | Former les utilisateurs |  | 10d | 2000-07-11 14:54 | 2000-07-26 17:54 | 131 |  |  | 2000-07-05 15:09 | 2000-07-19 15:09 | 10d | 36.54d | 0d | Programmeur 2 [40%] | 32h |  | 9,600 | 9,600 |  |
| 134 | 3.2.7.2 | Utilisateurs formés | milestone | 0d | 2000-07-26 17:54 | 2000-07-26 17:54 | 133 |  |  | 2000-07-19 15:09 | 2000-07-19 15:09 | 0d | 36.54d |  |  |  |  |  |  |  |
| 135 | 3.3 | **Etude du site internet** |  | 10.75d | 2000-05-18 16:12 A | 2000-06-07 09:12 A |  | 100% |  | 2000-05-04 16:12 | 2000-05-24 09:12 | 12.25d |  |  |  | 60h | 60h | 20,000 | 20,000 | 20,000 |
| 136 | 3.3.1 | **Définition fonctions** |  | 4.38d | 2000-05-18 16:12 A | 2000-05-25 16:12 A |  | 100% |  | 2000-05-04 16:12 | 2000-05-12 16:12 | 5d |  |  |  | 16h | 16h |  |  |  |
| 137 | 3.3.1.1 | Définir les fonctions |  | 2.62d | 2000-05-18 16:12 A | 2000-05-23 16:12 A | 95 | 100% |  | 2000-05-04 16:12 | 2000-05-10 16:12 | 3d |  |  | Henri [38.1%] | 8h | 8h |  |  |  |
| 138 | 3.3.1.2 | Rédiger le cahier des charges |  | 1.75d | 2000-05-23 16:12 A | 2000-05-25 16:12 A | 137 | 100% |  | 2000-05-10 16:12 | 2000-05-12 16:12 | 2d |  |  | Henri [57.1%] | 8h | 8h |  |  |  |
| 139 | 3.3.1.3 | Cahier des charges | milestone | 0d | 2000-05-25 16:12 A | 2000-05-25 16:12 A | 138 | 100% |  | 2000-05-12 16:12 | 2000-05-12 16:12 | 0d |  |  |  |  |  |  |  |  |
| 140 | 3.3.2 | **Définition interfaces** |  | 6.38d | 2000-05-25 16:12 A | 2000-06-07 09:12 A |  | 100% |  | 2000-05-12 16:12 | 2000-05-24 09:12 | 7.25d |  |  |  | 44h | 44h | 20,000 | 20,000 | 20,000 |
| 141 | 3.3.2.1 | Faire les maquettes |  | 5.5d | 2000-05-25 16:12 A | 2000-06-06 09:12 A | 139 | 100% |  | 2000-05-12 16:12 | 2000-05-23 09:12 | 6.25d |  |  | François [90.9%] | 40h | 40h | 20,000 | 20,000 | 20,000 |
| 142 | 3.3.2.2 | Valider les maquettes |  | 0.88d | 2000-06-06 09:12 A | 2000-06-07 09:12 A | 141 | 100% |  | 2000-05-23 09:12 | 2000-05-24 09:12 | 1d |  |  | Henri [57.1%] | 4h | 4h |  |  |  |
| 143 | 3.3.2.3 | Maquettes validées | milestone | 0d | 2000-06-07 09:12 A | 2000-06-07 09:12 A | 142 | 100% |  | 2000-05-24 09:12 | 2000-05-24 09:12 | 0d |  |  |  |  |  |  |  |  |
| 144 | 3.4 | **Mise en place du site** |  | 40.13d | 2000-06-07 09:12 A | 2000-08-10 17:12 |  | 20% | 32.17d | 2000-05-24 09:12 | 2000-07-28 09:12 | 45d | 0d |  |  | 735.87h | 261.77h | 149,146.67 | 149,200 | 35,487.31 |
| 145 | 3.4.1 | **Développements** |  | 37.88d | 2000-06-07 09:12 A | 2000-08-08 11:12 |  | 22% | 29.64d | 2000-05-24 09:12 | 2000-07-20 09:12 | 39d | 0d |  |  | 711.87h | 261.77h | 137,146.67 | 137,200 | 35,487.31 |
| 146 | 3.4.1.1 | Définir le nombre de prototypes |  | 1d | 2000-06-07 09:12 A | 2000-06-08 10:12 | 143 | 25% | 0.75d | 2000-05-24 09:12 | 2000-05-25 09:12 | 1d | 15.94d | 0d | Henri [50%]; François | 8h | 3h | 2,000 | 2,000 | 1,000 |
| 147 | 3.4.1.2 | Réaliser le prototype (n fois) |  | 14.97d | 2000-06-08 09:12 A | 2000-07-17 09:27 | 146 | 14% | 12.9d | 2000-05-25 09:12 | 2000-06-29 09:27 | 8.25d | 10.47d |  | Infographiste [53.3%]; Programmeur 1; Machine de développement 1; Machine de développement 2 | 255.87h | 57.8h | 45,146.67 | 45,200 | 8,719.81 |
| 148 | 3.4.1.3 | Tester le prototype (n fois) |  | 23.47d | 2000-06-21 09:12 A | 2000-08-08 11:12 | 146 | 25% | 17.6d | 2000-06-07 09:12 | 2000-07-20 09:12 | 23.47d | -3.75d | 0d | Infographiste [53.3%]; Programmeur 1; Machine de développement 1; Machine de développement 2 | 256h | 137.43h | 45,200 | 45,200 | 13,465 |
| 149 | 3.4.1.4 | Définir les améliorations (n fois) |  | 22.47d | 2000-06-08 09:12 A | 2000-07-17 14:57 | 146 | 24% | 17.19d | 2000-05-25 09:12 | 2000-06-29 10:57 | 21.13d | 10.03d |  | Henri [53.3%]; Infographiste; Programmeur 2 | 192h | 63.54h | 44,800 | 44,800 | 12,302.5 |
| 150 | 3.4.1.5 | Prototypes (n) | milestone | 0d | 2000-08-02 09:12 A | 2000-08-02 09:12 | 147, 148, 149 | 25% | 0d | 2000-07-20 09:12 | 2000-07-20 09:12 | 0d | 0d |  |  |  |  |  |  |  |

| ID | WBS | Task | Type | Duration | Start | Finish | Predecessors | Baseline start | Baseline finish | Baseline duration | Total slack | Constraint | Resources | Work | Cost | Baseline cost |
| --- | --- | --- | --- | --- | --- | --- | --- | --- | --- | --- | --- | --- | --- | --- | --- | --- |
| 151 | 3.4.2 | **Installation** |  | 6d | 2000-08-02 09:12 | 2000-08-10 17:12 |  | 2000-07-20 09:12 | 2000-07-28 09:12 | 6d | 0d |  |  | 24h | 12,000 | 12,000 |
| 152 | 3.4.2.1 | Réaliser l'installation avec le prestataire d'accès |  | 6d | 2000-08-02 09:12 | 2000-08-10 17:12 | 150 | 2000-07-20 09:12 | 2000-07-28 09:12 | 6d | 0d |  | François [50%] | 24h | 12,000 | 12,000 |
| 153 | 3.4.2.2 | Accès internet | milestone | 0d | 2000-08-10 17:12 | 2000-08-10 17:12 | 152 | 2000-07-28 09:12 | 2000-07-28 09:12 | 0d | 0d |  |  |  |  |  |
| 154 | 3.5 | **Mise en production du site** |  | 23d | 2000-08-10 17:12 | 2000-09-18 10:12 |  | 2000-07-28 09:12 | 2000-08-30 09:12 | 23d | 0d |  |  | 200h | 44,960 | 44,960 |
| 155 | 3.5.1 | **Test finaux** |  | 10d | 2000-08-10 17:12 | 2000-08-28 11:12 |  | 2000-07-28 09:12 | 2000-08-11 09:12 | 10d | 0d |  |  | 128h | 19,360 | 19,360 |
| 156 | 3.5.1.1 | Faire les tests finaux |  | 10d | 2000-08-10 17:12 | 2000-08-28 11:12 | 153 | 2000-07-28 09:12 | 2000-08-11 09:12 | 10d | 0d |  | Programmeur 2 [80%]; Machine de développement 3 [80%] | 128h | 19,360 | 19,360 |
| 157 | 3.5.2 | **Recette** |  | 3d | 2000-08-28 11:12 | 2000-08-31 16:12 |  | 2000-08-11 09:12 | 2000-08-16 09:12 | 3d | 0d |  |  | 8h |  |  |
| 158 | 3.5.2.1 | Effectuer la recette |  | 3d | 2000-08-28 11:12 | 2000-08-31 16:12 | 156 | 2000-08-11 09:12 | 2000-08-16 09:12 | 3d | 0d |  | Henri [33.3%] | 8h |  |  |
| 159 | 3.5.2.2 | PV de recette | milestone | 0d | 2000-08-31 16:12 | 2000-08-31 16:12 | 158 | 2000-08-16 09:12 | 2000-08-16 09:12 | 0d | 0d |  |  |  |  |  |
| 160 | 3.5.3 | **Formation** |  | 10d | 2000-08-31 16:12 | 2000-09-18 10:12 |  | 2000-08-16 09:12 | 2000-08-30 09:12 | 10d | 0d |  |  | 64h | 25,600 | 25,600 |
| 161 | 3.5.3.1 | Elaborer la doc utilisateurs |  | 5d | 2000-08-31 16:12 | 2000-09-08 14:12 | 159 | 2000-08-16 09:12 | 2000-08-23 09:12 | 5d | 0d |  | François [80%] | 32h | 16,000 | 16,000 |
| 162 | 3.5.3.2 | Doc utilisateurs | milestone | 0d | 2000-09-08 14:12 | 2000-09-08 14:12 | 161 | 2000-08-23 09:12 | 2000-08-23 09:12 | 0d | 0d |  |  |  |  |  |
| 163 | 3.5.3.3 | Former les utilisateurs |  | 5d | 2000-09-08 14:12 | 2000-09-18 10:12 | 162 | 2000-08-23 09:12 | 2000-08-30 09:12 | 5d | 0d |  | Programmeur 2 [80%] | 32h | 9,600 | 9,600 |
| 164 | 3.5.3.4 | Utilisateurs formés | milestone | 0d | 2000-09-18 10:12 | 2000-09-18 10:12 | 163 | 2000-08-30 09:12 | 2000-08-30 09:12 | 0d | 0d |  |  |  |  |  |
| 165 | 4 | **GESTION DU PROJET** |  | 96.9d | 2000-04-17 08:00 | 2000-09-22 16:12 |  | 2000-04-17 08:00 | 2000-09-05 09:12 | 97.15d | 0d |  |  | 258.25h | 103,550 | 103,550 |
| 166 | 4.1 | **Piloter le projet** |  | 93.9d | 2000-04-17 08:00 | 2000-09-19 11:12 |  | 2000-04-17 08:00 | 2000-08-31 09:12 | 94.15d | 3d |  |  | 223.25h | 84,500 | 84,500 |
| 167 | 4.1.1 | **Réalisation** |  | 93.9d | 2000-04-17 08:00 | 2000-09-19 11:12 |  | 2000-04-17 08:00 | 2000-08-31 09:12 | 94.15d | 3d |  |  | 223.25h | 84,500 | 84,500 |
| 168 | 4.1.1.1 | **Piloter la réalisation du produit** |  | 93.9d | 2000-04-17 08:00 | 2000-09-19 11:12 |  | 2000-04-17 08:00 | 2000-08-31 09:12 | 94.15d | 3d |  |  | 223.25h | 84,500 | 84,500 |
| 169 | 4.1.1.1.1 | **Reporting CAPS** |  | 49.03d | 2000-04-26 09:00 | 2000-07-19 09:15 |  | 2000-04-26 08:00 | 2000-07-19 08:15 | 56.03d | 41.75d |  |  | 71.25h | 28,500 | 28,500 |
| 170 | 4.1.1.1.1.1 | Reporting CAPS 1 |  | 15min | 2000-04-26 09:00 | 2000-04-26 09:15 |  | 2000-04-26 08:00 | 2000-04-26 08:15 | 15min | 90.75d | start no earlier than 2000-04-26 08:00 | Claudio; François; Infographiste; Programmeur 1; Programmeur 2 | 1.25h | 500 | 500 |
| 171 | 4.1.1.1.1.2 | Reporting CAPS 2 |  | 15min | 2000-04-27 09:00 | 2000-04-27 09:15 |  | 2000-04-27 08:00 | 2000-04-27 08:15 | 15min | 89.87d | start no earlier than 2000-04-27 08:00 | Claudio; François; Infographiste; Programmeur 1; Programmeur 2 | 1.25h | 500 | 500 |
| 172 | 4.1.1.1.1.3 | Reporting CAPS 3 |  | 15min | 2000-04-28 09:00 | 2000-04-28 09:15 |  | 2000-04-28 08:00 | 2000-04-28 08:15 | 15min | 89d | start no earlier than 2000-04-28 08:00 | Claudio; François; Infographiste; Programmeur 1; Programmeur 2 | 1.25h | 500 | 500 |
| 173 | 4.1.1.1.1.4 | Reporting CAPS 4 |  | 15min | 2000-05-02 09:00 | 2000-05-02 09:15 |  | 2000-05-02 08:00 | 2000-05-02 08:15 | 15min | 88.12d | start no earlier than 2000-05-02 08:00 | Claudio; François; Infographiste; Programmeur 1; Programmeur 2 | 1.25h | 500 | 500 |
| 174 | 4.1.1.1.1.5 | Reporting CAPS 5 |  | 15min | 2000-05-03 09:00 | 2000-05-03 09:15 |  | 2000-05-03 08:00 | 2000-05-03 08:15 | 15min | 87.25d | start no earlier than 2000-05-03 08:00 | Claudio; François; Infographiste; Programmeur 1; Programmeur 2 | 1.25h | 500 | 500 |
| 175 | 4.1.1.1.1.6 | Reporting CAPS 6 |  | 15min | 2000-05-04 09:00 | 2000-05-04 09:15 |  | 2000-05-04 08:00 | 2000-05-04 08:15 | 15min | 86.37d | start no earlier than 2000-05-04 08:00 | Claudio; François; Infographiste; Programmeur 1; Programmeur 2 | 1.25h | 500 | 500 |
| 176 | 4.1.1.1.1.7 | Reporting CAPS 7 |  | 15min | 2000-05-05 09:00 | 2000-05-05 09:15 |  | 2000-05-05 08:00 | 2000-05-05 08:15 | 15min | 85.5d | start no earlier than 2000-05-05 08:00 | Claudio; François; Infographiste; Programmeur 1; Programmeur 2 | 1.25h | 500 | 500 |
| 177 | 4.1.1.1.1.8 | Reporting CAPS 8 |  | 15min | 2000-05-09 09:00 | 2000-05-09 09:15 |  | 2000-05-09 08:00 | 2000-05-09 08:15 | 15min | 84.62d | start no earlier than 2000-05-09 08:00 | Claudio; François; Infographiste; Programmeur 1; Programmeur 2 | 1.25h | 500 | 500 |
| 178 | 4.1.1.1.1.9 | Reporting CAPS 9 |  | 15min | 2000-05-10 09:00 | 2000-05-10 09:15 |  | 2000-05-10 08:00 | 2000-05-10 08:15 | 15min | 83.75d | start no earlier than 2000-05-10 08:00 | Claudio; François; Infographiste; Programmeur 1; Programmeur 2 | 1.25h | 500 | 500 |
| 179 | 4.1.1.1.1.10 | Reporting CAPS 10 |  | 15min | 2000-05-11 09:00 | 2000-05-11 09:15 |  | 2000-05-11 08:00 | 2000-05-11 08:15 | 15min | 82.87d | start no earlier than 2000-05-11 08:00 | Claudio; François; Infographiste; Programmeur 1; Programmeur 2 | 1.25h | 500 | 500 |
| 180 | 4.1.1.1.1.11 | Reporting CAPS 11 |  | 15min | 2000-05-12 09:00 | 2000-05-12 09:15 |  | 2000-05-12 08:00 | 2000-05-12 08:15 | 15min | 82d | start no earlier than 2000-05-12 08:00 | Claudio; François; Infographiste; Programmeur 1; Programmeur 2 | 1.25h | 500 | 500 |
| 181 | 4.1.1.1.1.12 | Reporting CAPS 12 |  | 15min | 2000-05-15 09:00 | 2000-05-15 09:15 |  | 2000-05-15 08:00 | 2000-05-15 08:15 | 15min | 81.12d | start no earlier than 2000-05-15 08:00 | Claudio; François; Infographiste; Programmeur 1; Programmeur 2 | 1.25h | 500 | 500 |
| 182 | 4.1.1.1.1.13 | Reporting CAPS 13 |  | 15min | 2000-05-16 09:00 | 2000-05-16 09:15 |  | 2000-05-16 08:00 | 2000-05-16 08:15 | 15min | 80.25d | start no earlier than 2000-05-16 08:00 | Claudio; François; Infographiste; Programmeur 1; Programmeur 2 | 1.25h | 500 | 500 |
| 183 | 4.1.1.1.1.14 | Reporting CAPS 14 |  | 15min | 2000-05-17 09:00 | 2000-05-17 09:15 |  | 2000-05-17 08:00 | 2000-05-17 08:15 | 15min | 79.37d | start no earlier than 2000-05-17 08:00 | Claudio; François; Infographiste; Programmeur 1; Programmeur 2 | 1.25h | 500 | 500 |
| 184 | 4.1.1.1.1.15 | Reporting CAPS 15 |  | 15min | 2000-05-18 09:00 | 2000-05-18 09:15 |  | 2000-05-18 08:00 | 2000-05-18 08:15 | 15min | 78.5d | start no earlier than 2000-05-18 08:00 | Claudio; François; Infographiste; Programmeur 1; Programmeur 2 | 1.25h | 500 | 500 |
| 185 | 4.1.1.1.1.16 | Reporting CAPS 16 |  | 15min | 2000-05-19 09:00 | 2000-05-19 09:15 |  | 2000-05-19 08:00 | 2000-05-19 08:15 | 15min | 77.62d | start no earlier than 2000-05-19 08:00 | Claudio; François; Infographiste; Programmeur 1; Programmeur 2 | 1.25h | 500 | 500 |
| 186 | 4.1.1.1.1.17 | Reporting CAPS 17 |  | 15min | 2000-05-22 09:00 | 2000-05-22 09:15 |  | 2000-05-22 08:00 | 2000-05-22 08:15 | 15min | 76.75d | start no earlier than 2000-05-22 08:00 | Claudio; François; Infographiste; Programmeur 1; Programmeur 2 | 1.25h | 500 | 500 |
| 187 | 4.1.1.1.1.18 | Reporting CAPS 18 |  | 15min | 2000-05-23 09:00 | 2000-05-23 09:15 |  | 2000-05-23 08:00 | 2000-05-23 08:15 | 15min | 75.87d | start no earlier than 2000-05-23 08:00 | Claudio; François; Infographiste; Programmeur 1; Programmeur 2 | 1.25h | 500 | 500 |
| 188 | 4.1.1.1.1.19 | Reporting CAPS 19 |  | 15min | 2000-05-24 09:00 | 2000-05-24 09:15 |  | 2000-05-24 08:00 | 2000-05-24 08:15 | 15min | 75d | start no earlier than 2000-05-24 08:00 | Claudio; François; Infographiste; Programmeur 1; Programmeur 2 | 1.25h | 500 | 500 |
| 189 | 4.1.1.1.1.20 | Reporting CAPS 20 |  | 15min | 2000-05-25 09:00 | 2000-05-25 09:15 |  | 2000-05-25 08:00 | 2000-05-25 08:15 | 15min | 74.12d | start no earlier than 2000-05-25 08:00 | Claudio; François; Infographiste; Programmeur 1; Programmeur 2 | 1.25h | 500 | 500 |
| 190 | 4.1.1.1.1.21 | Reporting CAPS 21 |  | 15min | 2000-05-26 09:00 | 2000-05-26 09:15 |  | 2000-05-26 08:00 | 2000-05-26 08:15 | 15min | 73.25d | start no earlier than 2000-05-26 08:00 | Claudio; François; Infographiste; Programmeur 1; Programmeur 2 | 1.25h | 500 | 500 |
| 191 | 4.1.1.1.1.22 | Reporting CAPS 22 |  | 15min | 2000-05-29 09:00 | 2000-05-29 09:15 |  | 2000-05-29 08:00 | 2000-05-29 08:15 | 15min | 72.37d | start no earlier than 2000-05-29 08:00 | Claudio; François; Infographiste; Programmeur 1; Programmeur 2 | 1.25h | 500 | 500 |
| 192 | 4.1.1.1.1.23 | Reporting CAPS 23 |  | 15min | 2000-05-30 09:00 | 2000-05-30 09:15 |  | 2000-05-30 08:00 | 2000-05-30 08:15 | 15min | 71.5d | start no earlier than 2000-05-30 08:00 | Claudio; François; Infographiste; Programmeur 1; Programmeur 2 | 1.25h | 500 | 500 |
| 193 | 4.1.1.1.1.24 | Reporting CAPS 24 |  | 15min | 2000-05-31 09:00 | 2000-05-31 09:15 |  | 2000-05-31 08:00 | 2000-05-31 08:15 | 15min | 70.62d | start no earlier than 2000-05-31 08:00 | Claudio; François; Infographiste; Programmeur 1; Programmeur 2 | 1.25h | 500 | 500 |
| 194 | 4.1.1.1.1.25 | Reporting CAPS 25 |  | 15min | 2000-06-02 09:00 | 2000-06-02 09:15 |  | 2000-06-02 08:00 | 2000-06-02 08:15 | 15min | 69.75d | start no earlier than 2000-06-02 08:00 | Claudio; François; Infographiste; Programmeur 1; Programmeur 2 | 1.25h | 500 | 500 |
| 195 | 4.1.1.1.1.26 | Reporting CAPS 26 |  | 15min | 2000-06-05 09:00 | 2000-06-05 09:15 |  | 2000-06-05 08:00 | 2000-06-05 08:15 | 15min | 68.87d | start no earlier than 2000-06-05 08:00 | Claudio; François; Infographiste; Programmeur 1; Programmeur 2 | 1.25h | 500 | 500 |
| 196 | 4.1.1.1.1.27 | Reporting CAPS 27 |  | 15min | 2000-06-06 09:00 | 2000-06-06 09:15 |  | 2000-06-06 08:00 | 2000-06-06 08:15 | 15min | 68d | start no earlier than 2000-06-06 08:00 | Claudio; François; Infographiste; Programmeur 1; Programmeur 2 | 1.25h | 500 | 500 |
| 197 | 4.1.1.1.1.28 | Reporting CAPS 28 |  | 15min | 2000-06-07 09:00 | 2000-06-07 09:15 |  | 2000-06-07 08:00 | 2000-06-07 08:15 | 15min | 67.12d | start no earlier than 2000-06-07 08:00 | Claudio; François; Infographiste; Programmeur 1; Programmeur 2 | 1.25h | 500 | 500 |
| 198 | 4.1.1.1.1.29 | Reporting CAPS 29 |  | 15min | 2000-06-08 09:00 | 2000-06-08 09:15 |  | 2000-06-08 08:00 | 2000-06-08 08:15 | 15min | 66.25d | start no earlier than 2000-06-08 08:00 | Claudio; François; Infographiste; Programmeur 1; Programmeur 2 | 1.25h | 500 | 500 |
| 199 | 4.1.1.1.1.30 | Reporting CAPS 30 |  | 15min | 2000-06-09 09:00 | 2000-06-09 09:15 |  | 2000-06-09 08:00 | 2000-06-09 08:15 | 15min | 65.37d | start no earlier than 2000-06-09 08:00 | Claudio; François; Infographiste; Programmeur 1; Programmeur 2 | 1.25h | 500 | 500 |
| 200 | 4.1.1.1.1.31 | Reporting CAPS 31 |  | 15min | 2000-06-13 09:00 | 2000-06-13 09:15 |  | 2000-06-13 08:00 | 2000-06-13 08:15 | 15min | 64.5d | start no earlier than 2000-06-13 08:00 | Claudio; François; Infographiste; Programmeur 1; Programmeur 2 | 1.25h | 500 | 500 |
| 201 | 4.1.1.1.1.32 | Reporting CAPS 32 |  | 15min | 2000-06-14 09:00 | 2000-06-14 09:15 |  | 2000-06-14 08:00 | 2000-06-14 08:15 | 15min | 63.62d | start no earlier than 2000-06-14 08:00 | Claudio; François; Infographiste; Programmeur 1; Programmeur 2 | 1.25h | 500 | 500 |
| 202 | 4.1.1.1.1.33 | Reporting CAPS 33 |  | 15min | 2000-06-15 09:00 | 2000-06-15 09:15 |  | 2000-06-15 08:00 | 2000-06-15 08:15 | 15min | 62.75d | start no earlier than 2000-06-15 08:00 | Claudio; François; Infographiste; Programmeur 1; Programmeur 2 | 1.25h | 500 | 500 |
| 203 | 4.1.1.1.1.34 | Reporting CAPS 34 |  | 15min | 2000-06-16 09:00 | 2000-06-16 09:15 |  | 2000-06-16 08:00 | 2000-06-16 08:15 | 15min | 61.87d | start no earlier than 2000-06-16 08:00 | Claudio; François; Infographiste; Programmeur 1; Programmeur 2 | 1.25h | 500 | 500 |
| 204 | 4.1.1.1.1.35 | Reporting CAPS 35 |  | 15min | 2000-06-19 09:00 | 2000-06-19 09:15 |  | 2000-06-19 08:00 | 2000-06-19 08:15 | 15min | 61d | start no earlier than 2000-06-19 08:00 | Claudio; François; Infographiste; Programmeur 1; Programmeur 2 | 1.25h | 500 | 500 |
| 205 | 4.1.1.1.1.36 | Reporting CAPS 36 |  | 15min | 2000-06-20 09:00 | 2000-06-20 09:15 |  | 2000-06-20 08:00 | 2000-06-20 08:15 | 15min | 60.12d | start no earlier than 2000-06-20 08:00 | Claudio; François; Infographiste; Programmeur 1; Programmeur 2 | 1.25h | 500 | 500 |
| 206 | 4.1.1.1.1.37 | Reporting CAPS 37 |  | 15min | 2000-06-21 09:00 | 2000-06-21 09:15 |  | 2000-06-21 08:00 | 2000-06-21 08:15 | 15min | 59.25d | start no earlier than 2000-06-21 08:00 | Claudio; François; Infographiste; Programmeur 1; Programmeur 2 | 1.25h | 500 | 500 |
| 207 | 4.1.1.1.1.38 | Reporting CAPS 38 |  | 15min | 2000-06-22 09:00 | 2000-06-22 09:15 |  | 2000-06-22 08:00 | 2000-06-22 08:15 | 15min | 58.37d | start no earlier than 2000-06-22 08:00 | Claudio; François; Infographiste; Programmeur 1; Programmeur 2 | 1.25h | 500 | 500 |
| 208 | 4.1.1.1.1.39 | Reporting CAPS 39 |  | 15min | 2000-06-23 09:00 | 2000-06-23 09:15 |  | 2000-06-23 08:00 | 2000-06-23 08:15 | 15min | 57.5d | start no earlier than 2000-06-23 08:00 | Claudio; François; Infographiste; Programmeur 1; Programmeur 2 | 1.25h | 500 | 500 |
| 209 | 4.1.1.1.1.40 | Reporting CAPS 40 |  | 15min | 2000-06-26 09:00 | 2000-06-26 09:15 |  | 2000-06-26 08:00 | 2000-06-26 08:15 | 15min | 56.62d | start no earlier than 2000-06-26 08:00 | Claudio; François; Infographiste; Programmeur 1; Programmeur 2 | 1.25h | 500 | 500 |
| 210 | 4.1.1.1.1.41 | Reporting CAPS 41 |  | 15min | 2000-06-27 09:00 | 2000-06-27 09:15 |  | 2000-06-27 08:00 | 2000-06-27 08:15 | 15min | 55.75d | start no earlier than 2000-06-27 08:00 | Claudio; François; Infographiste; Programmeur 1; Programmeur 2 | 1.25h | 500 | 500 |
| 211 | 4.1.1.1.1.42 | Reporting CAPS 42 |  | 15min | 2000-06-28 09:00 | 2000-06-28 09:15 |  | 2000-06-28 08:00 | 2000-06-28 08:15 | 15min | 54.87d | start no earlier than 2000-06-28 08:00 | Claudio; François; Infographiste; Programmeur 1; Programmeur 2 | 1.25h | 500 | 500 |
| 212 | 4.1.1.1.1.43 | Reporting CAPS 43 |  | 15min | 2000-06-29 09:00 | 2000-06-29 09:15 |  | 2000-06-29 08:00 | 2000-06-29 08:15 | 15min | 54d | start no earlier than 2000-06-29 08:00 | Claudio; François; Infographiste; Programmeur 1; Programmeur 2 | 1.25h | 500 | 500 |
| 213 | 4.1.1.1.1.44 | Reporting CAPS 44 |  | 15min | 2000-06-30 09:00 | 2000-06-30 09:15 |  | 2000-06-30 08:00 | 2000-06-30 08:15 | 15min | 53.12d | start no earlier than 2000-06-30 08:00 | Claudio; François; Infographiste; Programmeur 1; Programmeur 2 | 1.25h | 500 | 500 |
| 214 | 4.1.1.1.1.45 | Reporting CAPS 45 |  | 15min | 2000-07-03 09:00 | 2000-07-03 09:15 |  | 2000-07-03 08:00 | 2000-07-03 08:15 | 15min | 52.25d | start no earlier than 2000-07-03 08:00 | Claudio; François; Infographiste; Programmeur 1; Programmeur 2 | 1.25h | 500 | 500 |
| 215 | 4.1.1.1.1.46 | Reporting CAPS 46 |  | 15min | 2000-07-04 09:00 | 2000-07-04 09:15 |  | 2000-07-04 08:00 | 2000-07-04 08:15 | 15min | 51.37d | start no earlier than 2000-07-04 08:00 | Claudio; François; Infographiste; Programmeur 1; Programmeur 2 | 1.25h | 500 | 500 |
| 216 | 4.1.1.1.1.47 | Reporting CAPS 47 |  | 15min | 2000-07-05 09:00 | 2000-07-05 09:15 |  | 2000-07-05 08:00 | 2000-07-05 08:15 | 15min | 50.5d | start no earlier than 2000-07-05 08:00 | Claudio; François; Infographiste; Programmeur 1; Programmeur 2 | 1.25h | 500 | 500 |
| 217 | 4.1.1.1.1.48 | Reporting CAPS 48 |  | 15min | 2000-07-06 09:00 | 2000-07-06 09:15 |  | 2000-07-06 08:00 | 2000-07-06 08:15 | 15min | 49.62d | start no earlier than 2000-07-06 08:00 | Claudio; François; Infographiste; Programmeur 1; Programmeur 2 | 1.25h | 500 | 500 |
| 218 | 4.1.1.1.1.49 | Reporting CAPS 49 |  | 15min | 2000-07-07 09:00 | 2000-07-07 09:15 |  | 2000-07-07 08:00 | 2000-07-07 08:15 | 15min | 48.75d | start no earlier than 2000-07-07 08:00 | Claudio; François; Infographiste; Programmeur 1; Programmeur 2 | 1.25h | 500 | 500 |
| 219 | 4.1.1.1.1.50 | Reporting CAPS 50 |  | 15min | 2000-07-10 09:00 | 2000-07-10 09:15 |  | 2000-07-10 08:00 | 2000-07-10 08:15 | 15min | 47.87d | start no earlier than 2000-07-10 08:00 | Claudio; François; Infographiste; Programmeur 1; Programmeur 2 | 1.25h | 500 | 500 |
| 220 | 4.1.1.1.1.51 | Reporting CAPS 51 |  | 15min | 2000-07-11 09:00 | 2000-07-11 09:15 |  | 2000-07-11 08:00 | 2000-07-11 08:15 | 15min | 47d | start no earlier than 2000-07-11 08:00 | Claudio; François; Infographiste; Programmeur 1; Programmeur 2 | 1.25h | 500 | 500 |

Notes:
- 166: Cette tâche contient toutes les tâches de pilotage, elle démarre au début de la réalisation et se termine à la fin de la réalisation

| ID | WBS | Task | Type | Duration | Start | Finish | Baseline start | Baseline finish | Baseline duration | Total slack | Constraint | Resources | Work | Cost | Baseline cost |
| --- | --- | --- | --- | --- | --- | --- | --- | --- | --- | --- | --- | --- | --- | --- | --- |
| 221 | 4.1.1.1.1.52 | Reporting CAPS 52 |  | 15min | 2000-07-12 09:00 | 2000-07-12 09:15 | 2000-07-12 08:00 | 2000-07-12 08:15 | 15min | 46.12d | start no earlier than 2000-07-12 08:00 | Claudio; François; Infographiste; Programmeur 1; Programmeur 2 | 1.25h | 500 | 500 |
| 222 | 4.1.1.1.1.53 | Reporting CAPS 53 |  | 15min | 2000-07-13 09:00 | 2000-07-13 09:15 | 2000-07-13 08:00 | 2000-07-13 08:15 | 15min | 45.25d | start no earlier than 2000-07-13 08:00 | Claudio; François; Infographiste; Programmeur 1; Programmeur 2 | 1.25h | 500 | 500 |
| 223 | 4.1.1.1.1.54 | Reporting CAPS 54 |  | 15min | 2000-07-14 09:00 | 2000-07-14 09:15 | 2000-07-14 08:00 | 2000-07-14 08:15 | 15min | 44.37d | start no earlier than 2000-07-14 08:00 | Claudio; François; Infographiste; Programmeur 1; Programmeur 2 | 1.25h | 500 | 500 |
| 224 | 4.1.1.1.1.55 | Reporting CAPS 55 |  | 15min | 2000-07-17 09:00 | 2000-07-17 09:15 | 2000-07-17 08:00 | 2000-07-17 08:15 | 15min | 43.5d | start no earlier than 2000-07-17 08:00 | Claudio; François; Infographiste; Programmeur 1; Programmeur 2 | 1.25h | 500 | 500 |
| 225 | 4.1.1.1.1.56 | Reporting CAPS 56 |  | 15min | 2000-07-18 09:00 | 2000-07-18 09:15 | 2000-07-18 08:00 | 2000-07-18 08:15 | 15min | 42.62d | start no earlier than 2000-07-18 08:00 | Claudio; François; Infographiste; Programmeur 1; Programmeur 2 | 1.25h | 500 | 500 |
| 226 | 4.1.1.1.1.57 | Reporting CAPS 57 |  | 15min | 2000-07-19 09:00 | 2000-07-19 09:15 | 2000-07-19 08:00 | 2000-07-19 08:15 | 15min | 41.75d | start no earlier than 2000-07-19 08:00 | Claudio; François; Infographiste; Programmeur 1; Programmeur 2 | 1.25h | 500 | 500 |
| 227 | 4.1.1.1.2 | **Reporting EFII** |  | 53.44d | 2000-04-20 09:00 | 2000-07-20 09:30 | 2000-04-20 08:00 | 2000-07-20 08:30 | 61.06d | 40.84d |  |  | 13h | 8,450 | 8,450 |
| 228 | 4.1.1.1.2.1 | Reporting EFII 1 |  | 30min | 2000-04-20 09:00 | 2000-04-20 09:30 | 2000-04-20 08:00 | 2000-04-20 08:30 | 30min | 94.21d | start no earlier than 2000-04-20 08:00 | Karen; Christophe | 1h | 650 | 650 |
| 229 | 4.1.1.1.2.2 | Reporting EFII 2 |  | 30min | 2000-04-27 09:00 | 2000-04-27 09:30 | 2000-04-27 08:00 | 2000-04-27 08:30 | 30min | 89.84d | start no earlier than 2000-04-27 08:00 | Karen; Christophe | 1h | 650 | 650 |
| 230 | 4.1.1.1.2.3 | Reporting EFII 3 |  | 30min | 2000-05-04 09:00 | 2000-05-04 09:30 | 2000-05-04 08:00 | 2000-05-04 08:30 | 30min | 86.34d | start no earlier than 2000-05-04 08:00 | Karen; Christophe | 1h | 650 | 650 |
| 231 | 4.1.1.1.2.4 | Reporting EFII 4 |  | 30min | 2000-05-11 09:00 | 2000-05-11 09:30 | 2000-05-11 08:00 | 2000-05-11 08:30 | 30min | 82.84d | start no earlier than 2000-05-11 08:00 | Karen; Christophe | 1h | 650 | 650 |
| 232 | 4.1.1.1.2.5 | Reporting EFII 5 |  | 30min | 2000-05-18 09:00 | 2000-05-18 09:30 | 2000-05-18 08:00 | 2000-05-18 08:30 | 30min | 78.46d | start no earlier than 2000-05-18 08:00 | Karen; Christophe | 1h | 650 | 650 |
| 233 | 4.1.1.1.2.6 | Reporting EFII 6 |  | 30min | 2000-05-25 09:00 | 2000-05-25 09:30 | 2000-05-25 08:00 | 2000-05-25 08:30 | 30min | 74.09d | start no earlier than 2000-05-25 08:00 | Karen; Christophe | 1h | 650 | 650 |
| 234 | 4.1.1.1.2.7 | Reporting EFII 7 |  | 30min | 2000-06-08 09:00 | 2000-06-08 09:30 | 2000-06-08 08:00 | 2000-06-08 08:30 | 30min | 66.21d | start no earlier than 2000-06-08 08:00 | Karen; Christophe | 1h | 650 | 650 |
| 235 | 4.1.1.1.2.8 | Reporting EFII 8 |  | 30min | 2000-06-15 09:00 | 2000-06-15 09:30 | 2000-06-15 08:00 | 2000-06-15 08:30 | 30min | 62.71d | start no earlier than 2000-06-15 08:00 | Karen; Christophe | 1h | 650 | 650 |
| 236 | 4.1.1.1.2.9 | Reporting EFII 9 |  | 30min | 2000-06-22 09:00 | 2000-06-22 09:30 | 2000-06-22 08:00 | 2000-06-22 08:30 | 30min | 58.34d | start no earlier than 2000-06-22 08:00 | Karen; Christophe | 1h | 650 | 650 |
| 237 | 4.1.1.1.2.10 | Reporting EFII 10 |  | 30min | 2000-06-29 09:00 | 2000-06-29 09:30 | 2000-06-29 08:00 | 2000-06-29 08:30 | 30min | 53.96d | start no earlier than 2000-06-29 08:00 | Karen; Christophe | 1h | 650 | 650 |
| 238 | 4.1.1.1.2.11 | Reporting EFII 11 |  | 30min | 2000-07-06 09:00 | 2000-07-06 09:30 | 2000-07-06 08:00 | 2000-07-06 08:30 | 30min | 49.59d | start no earlier than 2000-07-06 08:00 | Karen; Christophe | 1h | 650 | 650 |
| 239 | 4.1.1.1.2.12 | Reporting EFII 12 |  | 30min | 2000-07-13 09:00 | 2000-07-13 09:30 | 2000-07-13 08:00 | 2000-07-13 08:30 | 30min | 45.21d | start no earlier than 2000-07-13 08:00 | Karen; Christophe | 1h | 650 | 650 |
| 240 | 4.1.1.1.2.13 | Reporting EFII 13 |  | 30min | 2000-07-20 09:00 | 2000-07-20 09:30 | 2000-07-20 08:00 | 2000-07-20 08:30 | 30min | 40.84d | start no earlier than 2000-07-20 08:00 | Karen; Christophe | 1h | 650 | 650 |
| 241 | 4.1.1.1.3 | **Fiche de reporting** |  | 53.38d | 2000-04-20 08:00 | 2000-07-20 08:00 | 2000-04-20 08:00 | 2000-07-20 08:00 | 61d | 40.9d |  |  |  |  |  |
| 242 | 4.1.1.1.3.1 | Fiche de reporting 1 | milestone | 0d | 2000-04-20 08:00 | 2000-04-20 08:00 | 2000-04-20 08:00 | 2000-04-20 08:00 | 0d | 94.28d | start no earlier than 2000-04-20 08:00 |  |  |  |  |
| 243 | 4.1.1.1.3.2 | Fiche de reporting 2 | milestone | 0d | 2000-04-27 08:00 | 2000-04-27 08:00 | 2000-04-27 08:00 | 2000-04-27 08:00 | 0d | 89.9d | start no earlier than 2000-04-27 08:00 |  |  |  |  |
| 244 | 4.1.1.1.3.3 | Fiche de reporting 3 | milestone | 0d | 2000-05-04 08:00 | 2000-05-04 08:00 | 2000-05-04 08:00 | 2000-05-04 08:00 | 0d | 86.4d | start no earlier than 2000-05-04 08:00 |  |  |  |  |
| 245 | 4.1.1.1.3.4 | Fiche de reporting 4 | milestone | 0d | 2000-05-11 08:00 | 2000-05-11 08:00 | 2000-05-11 08:00 | 2000-05-11 08:00 | 0d | 82.9d | start no earlier than 2000-05-11 08:00 |  |  |  |  |
| 246 | 4.1.1.1.3.5 | Fiche de reporting 5 | milestone | 0d | 2000-05-18 08:00 | 2000-05-18 08:00 | 2000-05-18 08:00 | 2000-05-18 08:00 | 0d | 78.53d | start no earlier than 2000-05-18 08:00 |  |  |  |  |
| 247 | 4.1.1.1.3.6 | Fiche de reporting 6 | milestone | 0d | 2000-05-25 08:00 | 2000-05-25 08:00 | 2000-05-25 08:00 | 2000-05-25 08:00 | 0d | 74.15d | start no earlier than 2000-05-25 08:00 |  |  |  |  |
| 248 | 4.1.1.1.3.7 | Fiche de reporting 7 | milestone | 0d | 2000-06-01 08:00 | 2000-06-01 08:00 | 2000-06-01 08:00 | 2000-06-01 08:00 | 0d | 69.78d | start no earlier than 2000-06-01 08:00 |  |  |  |  |
| 249 | 4.1.1.1.3.8 | Fiche de reporting 8 | milestone | 0d | 2000-06-08 08:00 | 2000-06-08 08:00 | 2000-06-08 08:00 | 2000-06-08 08:00 | 0d | 66.28d | start no earlier than 2000-06-08 08:00 |  |  |  |  |
| 250 | 4.1.1.1.3.9 | Fiche de reporting 9 | milestone | 0d | 2000-06-15 08:00 | 2000-06-15 08:00 | 2000-06-15 08:00 | 2000-06-15 08:00 | 0d | 62.78d | start no earlier than 2000-06-15 08:00 |  |  |  |  |
| 251 | 4.1.1.1.3.10 | Fiche de reporting 10 | milestone | 0d | 2000-06-22 08:00 | 2000-06-22 08:00 | 2000-06-22 08:00 | 2000-06-22 08:00 | 0d | 58.4d | start no earlier than 2000-06-22 08:00 |  |  |  |  |
| 252 | 4.1.1.1.3.11 | Fiche de reporting 11 | milestone | 0d | 2000-06-29 08:00 | 2000-06-29 08:00 | 2000-06-29 08:00 | 2000-06-29 08:00 | 0d | 54.03d | start no earlier than 2000-06-29 08:00 |  |  |  |  |
| 253 | 4.1.1.1.3.12 | Fiche de reporting 12 | milestone | 0d | 2000-07-06 08:00 | 2000-07-06 08:00 | 2000-07-06 08:00 | 2000-07-06 08:00 | 0d | 49.65d | start no earlier than 2000-07-06 08:00 |  |  |  |  |
| 254 | 4.1.1.1.3.13 | Fiche de reporting 13 | milestone | 0d | 2000-07-13 08:00 | 2000-07-13 08:00 | 2000-07-13 08:00 | 2000-07-13 08:00 | 0d | 45.28d | start no earlier than 2000-07-13 08:00 |  |  |  |  |
| 255 | 4.1.1.1.3.14 | Fiche de reporting 14 | milestone | 0d | 2000-07-20 08:00 | 2000-07-20 08:00 | 2000-07-20 08:00 | 2000-07-20 08:00 | 0d | 40.9d | start no earlier than 2000-07-20 08:00 |  |  |  |  |

| ID | WBS | Task | Type | Duration | Start | Finish | Baseline start | Baseline finish | Baseline duration | Total slack | Constraint | Resources | Work | Cost | Baseline cost |
| --- | --- | --- | --- | --- | --- | --- | --- | --- | --- | --- | --- | --- | --- | --- | --- |
| 256 | 4.1.1.1.4 | **Reporting commanditaire** |  | 53.41d | 2000-04-21 09:00 | 2000-07-21 09:15 | 2000-04-21 08:00 | 2000-07-21 08:15 | 61.03d | 40d |  |  | 7h | 2,450 | 2,450 |
| 257 | 4.1.1.1.4.1 | Reporting commanditaire 1 |  | 15min | 2000-04-21 09:00 | 2000-04-21 09:15 | 2000-04-21 08:00 | 2000-04-21 08:15 | 15min | 93.37d | start no earlier than 2000-04-21 08:00 | Karen; Henri | 0.5h | 175 | 175 |
| 258 | 4.1.1.1.4.2 | Reporting commanditaire 2 |  | 15min | 2000-04-28 09:00 | 2000-04-28 09:15 | 2000-04-28 08:00 | 2000-04-28 08:15 | 15min | 89d | start no earlier than 2000-04-28 08:00 | Karen; Henri | 0.5h | 175 | 175 |
| 259 | 4.1.1.1.4.3 | Reporting commanditaire 3 |  | 15min | 2000-05-05 09:00 | 2000-05-05 09:15 | 2000-05-05 08:00 | 2000-05-05 08:15 | 15min | 85.5d | start no earlier than 2000-05-05 08:00 | Karen; Henri | 0.5h | 175 | 175 |
| 260 | 4.1.1.1.4.4 | Reporting commanditaire 4 |  | 15min | 2000-05-12 09:00 | 2000-05-12 09:15 | 2000-05-12 08:00 | 2000-05-12 08:15 | 15min | 82d | start no earlier than 2000-05-12 08:00 | Karen; Henri | 0.5h | 175 | 175 |
| 261 | 4.1.1.1.4.5 | Reporting commanditaire 5 |  | 15min | 2000-05-19 09:00 | 2000-05-19 09:15 | 2000-05-19 08:00 | 2000-05-19 08:15 | 15min | 77.62d | start no earlier than 2000-05-19 08:00 | Karen; Henri | 0.5h | 175 | 175 |
| 262 | 4.1.1.1.4.6 | Reporting commanditaire 6 |  | 15min | 2000-05-26 09:00 | 2000-05-26 09:15 | 2000-05-26 08:00 | 2000-05-26 08:15 | 15min | 73.25d | start no earlier than 2000-05-26 08:00 | Karen; Henri | 0.5h | 175 | 175 |
| 263 | 4.1.1.1.4.7 | Reporting commanditaire 7 |  | 15min | 2000-06-02 09:00 | 2000-06-02 09:15 | 2000-06-02 08:00 | 2000-06-02 08:15 | 15min | 69.75d | start no earlier than 2000-06-02 08:00 | Karen; Henri | 0.5h | 175 | 175 |
| 264 | 4.1.1.1.4.8 | Reporting commanditaire 8 |  | 15min | 2000-06-09 09:00 | 2000-06-09 09:15 | 2000-06-09 08:00 | 2000-06-09 08:15 | 15min | 65.37d | start no earlier than 2000-06-09 08:00 | Karen; Henri | 0.5h | 175 | 175 |
| 265 | 4.1.1.1.4.9 | Reporting commanditaire 9 |  | 15min | 2000-06-16 09:00 | 2000-06-16 09:15 | 2000-06-16 08:00 | 2000-06-16 08:15 | 15min | 61.87d | start no earlier than 2000-06-16 08:00 | Karen; Henri | 0.5h | 175 | 175 |
| 266 | 4.1.1.1.4.10 | Reporting commanditaire 10 |  | 15min | 2000-06-23 09:00 | 2000-06-23 09:15 | 2000-06-23 08:00 | 2000-06-23 08:15 | 15min | 57.5d | start no earlier than 2000-06-23 08:00 | Karen; Henri | 0.5h | 175 | 175 |
| 267 | 4.1.1.1.4.11 | Reporting commanditaire 11 |  | 15min | 2000-06-30 09:00 | 2000-06-30 09:15 | 2000-06-30 08:00 | 2000-06-30 08:15 | 15min | 53.12d | start no earlier than 2000-06-30 08:00 | Karen; Henri | 0.5h | 175 | 175 |
| 268 | 4.1.1.1.4.12 | Reporting commanditaire 12 |  | 15min | 2000-07-07 09:00 | 2000-07-07 09:15 | 2000-07-07 08:00 | 2000-07-07 08:15 | 15min | 48.75d | start no earlier than 2000-07-07 08:00 | Karen; Henri | 0.5h | 175 | 175 |
| 269 | 4.1.1.1.4.13 | Reporting commanditaire 13 |  | 15min | 2000-07-14 09:00 | 2000-07-14 09:15 | 2000-07-14 08:00 | 2000-07-14 08:15 | 15min | 44.37d | start no earlier than 2000-07-14 08:00 | Karen; Henri | 0.5h | 175 | 175 |
| 270 | 4.1.1.1.4.14 | Reporting commanditaire 14 |  | 15min | 2000-07-21 09:00 | 2000-07-21 09:15 | 2000-07-21 08:00 | 2000-07-21 08:15 | 15min | 40d | start no earlier than 2000-07-21 08:00 | Karen; Henri | 0.5h | 175 | 175 |
| 271 | 4.1.1.1.5 | **Réunion comité de pilotage** |  | 36.88d | 2000-05-02 09:00 | 2000-07-04 10:00 | 2000-05-02 08:00 | 2000-07-03 17:00 | 42d | 51.28d |  |  | 72h | 16,800 | 16,800 |
| 272 | 4.1.1.1.5.1 | Réunion comité de pilotage 1 |  | 1d | 2000-05-02 09:00 | 2000-05-03 10:00 | 2000-05-02 08:00 | 2000-05-02 17:00 | 1d | 87.15d | start no earlier than 2000-05-01 08:00 | Karen; Henri; Philippe | 24h | 5,600 | 5,600 |
| 273 | 4.1.1.1.5.2 | Réunion comité de pilotage 2 |  | 1d | 2000-06-05 09:00 | 2000-06-06 10:00 | 2000-06-05 08:00 | 2000-06-05 17:00 | 1d | 67.9d | start no earlier than 2000-06-05 08:00 | Karen; Henri; Philippe | 24h | 5,600 | 5,600 |
| 274 | 4.1.1.1.5.3 | Réunion comité de pilotage 3 |  | 1d | 2000-07-03 09:00 | 2000-07-04 10:00 | 2000-07-03 08:00 | 2000-07-03 17:00 | 1d | 51.28d | start no earlier than 2000-07-03 08:00 | Karen; Henri; Philippe | 24h | 5,600 | 5,600 |
| 275 | 4.1.1.1.6 | **Rapport flash** |  | 35.88d | 2000-05-01 08:00 | 2000-07-03 08:00 | 2000-05-01 08:00 | 2000-07-03 08:00 | 41d | 52.28d |  |  |  |  |  |
| 276 | 4.1.1.1.6.1 | Rapport flash 1 | milestone | 0d | 2000-05-01 08:00 | 2000-05-01 08:00 | 2000-05-01 08:00 | 2000-05-01 08:00 | 0d | 88.15d | start no earlier than 2000-05-01 08:00 |  |  |  |  |
| 277 | 4.1.1.1.6.2 | Rapport flash 2 | milestone | 0d | 2000-06-05 08:00 | 2000-06-05 08:00 | 2000-06-05 08:00 | 2000-06-05 08:00 | 0d | 68.9d | start no earlier than 2000-06-05 08:00 |  |  |  |  |
| 278 | 4.1.1.1.6.3 | Rapport flash 3 | milestone | 0d | 2000-07-03 08:00 | 2000-07-03 08:00 | 2000-07-03 08:00 | 2000-07-03 08:00 | 0d | 52.28d | start no earlier than 2000-07-03 08:00 |  |  |  |  |
| 279 | 4.1.1.1.7 | **Mettre à jour le planning** |  | 57.88d | 2000-04-17 09:00 | 2000-07-24 10:00 | 2000-04-17 08:00 | 2000-07-24 09:00 | 66.12d | 39.03d |  |  | 15h | 10,500 | 10,500 |
| 280 | 4.1.1.1.7.1 | Mettre à jour le planning 1 |  | 1h | 2000-04-17 09:00 | 2000-04-17 10:00 | 2000-04-17 08:00 | 2000-04-17 09:00 | 1h | 96.78d | start no earlier than 2000-04-17 08:00 | Karen | 1h | 700 | 700 |
| 281 | 4.1.1.1.7.2 | Mettre à jour le planning 2 |  | 1h | 2000-04-24 09:00 | 2000-04-24 10:00 | 2000-04-24 08:00 | 2000-04-24 09:00 | 1h | 92.4d | start no earlier than 2000-04-24 08:00 | Karen | 1h | 700 | 700 |
| 282 | 4.1.1.1.7.3 | Mettre à jour le planning 3 |  | 1h | 2000-05-02 09:00 | 2000-05-02 10:00 | 2000-05-02 08:00 | 2000-05-02 09:00 | 1h | 88.03d | start no earlier than 2000-05-01 08:00 | Karen | 1h | 700 | 700 |
| 283 | 4.1.1.1.7.4 | Mettre à jour le planning 4 |  | 1h | 2000-05-09 09:00 | 2000-05-09 10:00 | 2000-05-09 08:00 | 2000-05-09 09:00 | 1h | 84.53d | start no earlier than 2000-05-08 08:00 | Karen | 1h | 700 | 700 |
| 284 | 4.1.1.1.7.5 | Mettre à jour le planning 5 |  | 1h | 2000-05-15 09:00 | 2000-05-15 10:00 | 2000-05-15 08:00 | 2000-05-15 09:00 | 1h | 81.03d | start no earlier than 2000-05-15 08:00 | Karen | 1h | 700 | 700 |
| 285 | 4.1.1.1.7.6 | Mettre à jour le planning 6 |  | 1h | 2000-05-22 09:00 | 2000-05-22 10:00 | 2000-05-22 08:00 | 2000-05-22 09:00 | 1h | 76.65d | start no earlier than 2000-05-22 08:00 | Karen | 1h | 700 | 700 |
| 286 | 4.1.1.1.7.7 | Mettre à jour le planning 7 |  | 1h | 2000-05-29 09:00 | 2000-05-29 10:00 | 2000-05-29 08:00 | 2000-05-29 09:00 | 1h | 72.28d | start no earlier than 2000-05-29 08:00 | Karen | 1h | 700 | 700 |
| 287 | 4.1.1.1.7.8 | Mettre à jour le planning 8 |  | 1h | 2000-06-05 09:00 | 2000-06-05 10:00 | 2000-06-05 08:00 | 2000-06-05 09:00 | 1h | 68.78d | start no earlier than 2000-06-05 08:00 | Karen | 1h | 700 | 700 |
| 288 | 4.1.1.1.7.9 | Mettre à jour le planning 9 |  | 1h | 2000-06-13 09:00 | 2000-06-13 10:00 | 2000-06-13 08:00 | 2000-06-13 09:00 | 1h | 64.4d | start no earlier than 2000-06-12 08:00 | Karen | 1h | 700 | 700 |
| 289 | 4.1.1.1.7.10 | Mettre à jour le planning 10 |  | 1h | 2000-06-19 09:00 | 2000-06-19 10:00 | 2000-06-19 08:00 | 2000-06-19 09:00 | 1h | 60.9d | start no earlier than 2000-06-19 08:00 | Karen | 1h | 700 | 700 |
| 290 | 4.1.1.1.7.11 | Mettre à jour le planning 11 |  | 1h | 2000-06-26 09:00 | 2000-06-26 10:00 | 2000-06-26 08:00 | 2000-06-26 09:00 | 1h | 56.53d | start no earlier than 2000-06-26 08:00 | Karen | 1h | 700 | 700 |
| 291 | 4.1.1.1.7.12 | Mettre à jour le planning 12 |  | 1h | 2000-07-03 09:00 | 2000-07-03 10:00 | 2000-07-03 08:00 | 2000-07-03 09:00 | 1h | 52.15d | start no earlier than 2000-07-03 08:00 | Karen | 1h | 700 | 700 |
| 292 | 4.1.1.1.7.13 | Mettre à jour le planning 13 |  | 1h | 2000-07-10 09:00 | 2000-07-10 10:00 | 2000-07-10 08:00 | 2000-07-10 09:00 | 1h | 47.78d | start no earlier than 2000-07-10 08:00 | Karen | 1h | 700 | 700 |
| 293 | 4.1.1.1.7.14 | Mettre à jour le planning 14 |  | 1h | 2000-07-17 09:00 | 2000-07-17 10:00 | 2000-07-17 08:00 | 2000-07-17 09:00 | 1h | 43.4d | start no earlier than 2000-07-17 08:00 | Karen | 1h | 700 | 700 |
| 294 | 4.1.1.1.7.15 | Mettre à jour le planning 15 |  | 1h | 2000-07-24 09:00 | 2000-07-24 10:00 | 2000-07-24 08:00 | 2000-07-24 09:00 | 1h | 39.03d | start no earlier than 2000-07-24 08:00 | Karen | 1h | 700 | 700 |

| ID | WBS | Task | Type | Duration | Start | Finish | Predecessors | Baseline start | Baseline finish | Baseline duration | Total slack | Free slack | Constraint | Resources | Work | Cost | Baseline cost |
| --- | --- | --- | --- | --- | --- | --- | --- | --- | --- | --- | --- | --- | --- | --- | --- | --- | --- |
| 295 | 4.1.1.1.8 | **Planning détaillé de suivi** |  | 57.75d | 2000-04-17 08:00 | 2000-07-24 08:00 |  | 2000-04-17 08:00 | 2000-07-24 08:00 | 66d | 39.15d |  |  |  |  |  |  |
| 296 | 4.1.1.1.8.1 | Planning détaillé de suivi 1 | milestone | 0d | 2000-04-17 08:00 | 2000-04-17 08:00 |  | 2000-04-17 08:00 | 2000-04-17 08:00 | 0d | 96.9d |  | start no earlier than 2000-04-17 08:00 |  |  |  |  |
| 297 | 4.1.1.1.8.2 | Planning détaillé de suivi 2 | milestone | 0d | 2000-04-24 08:00 | 2000-04-24 08:00 |  | 2000-04-24 08:00 | 2000-04-24 08:00 | 0d | 92.53d |  | start no earlier than 2000-04-24 08:00 |  |  |  |  |
| 298 | 4.1.1.1.8.3 | Planning détaillé de suivi 3 | milestone | 0d | 2000-05-01 08:00 | 2000-05-01 08:00 |  | 2000-05-01 08:00 | 2000-05-01 08:00 | 0d | 88.15d |  | start no earlier than 2000-05-01 08:00 |  |  |  |  |
| 299 | 4.1.1.1.8.4 | Planning détaillé de suivi 4 | milestone | 0d | 2000-05-08 08:00 | 2000-05-08 08:00 |  | 2000-05-08 08:00 | 2000-05-08 08:00 | 0d | 84.65d |  | start no earlier than 2000-05-08 08:00 |  |  |  |  |
| 300 | 4.1.1.1.8.5 | Planning détaillé de suivi 5 | milestone | 0d | 2000-05-15 08:00 | 2000-05-15 08:00 |  | 2000-05-15 08:00 | 2000-05-15 08:00 | 0d | 81.15d |  | start no earlier than 2000-05-15 08:00 |  |  |  |  |
| 301 | 4.1.1.1.8.6 | Planning détaillé de suivi 6 | milestone | 0d | 2000-05-22 08:00 | 2000-05-22 08:00 |  | 2000-05-22 08:00 | 2000-05-22 08:00 | 0d | 76.78d |  | start no earlier than 2000-05-22 08:00 |  |  |  |  |
| 302 | 4.1.1.1.8.7 | Planning détaillé de suivi 7 | milestone | 0d | 2000-05-29 08:00 | 2000-05-29 08:00 |  | 2000-05-29 08:00 | 2000-05-29 08:00 | 0d | 72.4d |  | start no earlier than 2000-05-29 08:00 |  |  |  |  |
| 303 | 4.1.1.1.8.8 | Planning détaillé de suivi 8 | milestone | 0d | 2000-06-05 08:00 | 2000-06-05 08:00 |  | 2000-06-05 08:00 | 2000-06-05 08:00 | 0d | 68.9d |  | start no earlier than 2000-06-05 08:00 |  |  |  |  |
| 304 | 4.1.1.1.8.9 | Planning détaillé de suivi 9 | milestone | 0d | 2000-06-12 08:00 | 2000-06-12 08:00 |  | 2000-06-12 08:00 | 2000-06-12 08:00 | 0d | 64.53d |  | start no earlier than 2000-06-12 08:00 |  |  |  |  |
| 305 | 4.1.1.1.8.10 | Planning détaillé de suivi 10 | milestone | 0d | 2000-06-19 08:00 | 2000-06-19 08:00 |  | 2000-06-19 08:00 | 2000-06-19 08:00 | 0d | 61.03d |  | start no earlier than 2000-06-19 08:00 |  |  |  |  |
| 306 | 4.1.1.1.8.11 | Planning détaillé de suivi 11 | milestone | 0d | 2000-06-26 08:00 | 2000-06-26 08:00 |  | 2000-06-26 08:00 | 2000-06-26 08:00 | 0d | 56.65d |  | start no earlier than 2000-06-26 08:00 |  |  |  |  |
| 307 | 4.1.1.1.8.12 | Planning détaillé de suivi 12 | milestone | 0d | 2000-07-03 08:00 | 2000-07-03 08:00 |  | 2000-07-03 08:00 | 2000-07-03 08:00 | 0d | 52.28d |  | start no earlier than 2000-07-03 08:00 |  |  |  |  |
| 308 | 4.1.1.1.8.13 | Planning détaillé de suivi 13 | milestone | 0d | 2000-07-10 08:00 | 2000-07-10 08:00 |  | 2000-07-10 08:00 | 2000-07-10 08:00 | 0d | 47.9d |  | start no earlier than 2000-07-10 08:00 |  |  |  |  |
| 309 | 4.1.1.1.8.14 | Planning détaillé de suivi 14 | milestone | 0d | 2000-07-17 08:00 | 2000-07-17 08:00 |  | 2000-07-17 08:00 | 2000-07-17 08:00 | 0d | 43.53d |  | start no earlier than 2000-07-17 08:00 |  |  |  |  |
| 310 | 4.1.1.1.8.15 | Planning détaillé de suivi 15 | milestone | 0d | 2000-07-24 08:00 | 2000-07-24 08:00 |  | 2000-07-24 08:00 | 2000-07-24 08:00 | 0d | 39.15d |  | start no earlier than 2000-07-24 08:00 |  |  |  |  |
| 311 | 4.1.1.1.9 | **Mettre à jour la documentation** |  | 57.88d | 2000-04-18 09:00 | 2000-07-25 10:00 |  | 2000-04-18 08:00 | 2000-07-25 09:00 | 66.12d | 38.15d |  |  |  | 15h | 9,000 | 9,000 |
| 312 | 4.1.1.1.9.1 | Mettre à jour la documentation 1 |  | 1h | 2000-04-18 09:00 | 2000-04-18 10:00 |  | 2000-04-18 08:00 | 2000-04-18 09:00 | 1h | 95.9d |  | start no earlier than 2000-04-18 08:00 | Christophe | 1h | 600 | 600 |
| 313 | 4.1.1.1.9.2 | Mettre à jour la documentation 2 |  | 1h | 2000-04-25 09:00 | 2000-04-25 10:00 |  | 2000-04-25 08:00 | 2000-04-25 09:00 | 1h | 91.53d |  | start no earlier than 2000-04-25 08:00 | Christophe | 1h | 600 | 600 |
| 314 | 4.1.1.1.9.3 | Mettre à jour la documentation 3 |  | 1h | 2000-05-02 09:00 | 2000-05-02 10:00 |  | 2000-05-02 08:00 | 2000-05-02 09:00 | 1h | 88.03d |  | start no earlier than 2000-05-02 08:00 | Christophe | 1h | 600 | 600 |
| 315 | 4.1.1.1.9.4 | Mettre à jour la documentation 4 |  | 1h | 2000-05-09 09:00 | 2000-05-09 10:00 |  | 2000-05-09 08:00 | 2000-05-09 09:00 | 1h | 84.53d |  | start no earlier than 2000-05-09 08:00 | Christophe | 1h | 600 | 600 |
| 316 | 4.1.1.1.9.5 | Mettre à jour la documentation 5 |  | 1h | 2000-05-16 09:00 | 2000-05-16 10:00 |  | 2000-05-16 08:00 | 2000-05-16 09:00 | 1h | 80.15d |  | start no earlier than 2000-05-16 08:00 | Christophe | 1h | 600 | 600 |
| 317 | 4.1.1.1.9.6 | Mettre à jour la documentation 6 |  | 1h | 2000-05-23 09:00 | 2000-05-23 10:00 |  | 2000-05-23 08:00 | 2000-05-23 09:00 | 1h | 75.78d |  | start no earlier than 2000-05-23 08:00 | Christophe | 1h | 600 | 600 |
| 318 | 4.1.1.1.9.7 | Mettre à jour la documentation 7 |  | 1h | 2000-05-30 09:00 | 2000-05-30 10:00 |  | 2000-05-30 08:00 | 2000-05-30 09:00 | 1h | 71.4d |  | start no earlier than 2000-05-30 08:00 | Christophe | 1h | 600 | 600 |
| 319 | 4.1.1.1.9.8 | Mettre à jour la documentation 8 |  | 1h | 2000-06-06 09:00 | 2000-06-06 10:00 |  | 2000-06-06 08:00 | 2000-06-06 09:00 | 1h | 67.9d |  | start no earlier than 2000-06-06 08:00 | Christophe | 1h | 600 | 600 |
| 320 | 4.1.1.1.9.9 | Mettre à jour la documentation 9 |  | 1h | 2000-06-13 09:00 | 2000-06-13 10:00 |  | 2000-06-13 08:00 | 2000-06-13 09:00 | 1h | 64.4d |  | start no earlier than 2000-06-13 08:00 | Christophe | 1h | 600 | 600 |
| 321 | 4.1.1.1.9.10 | Mettre à jour la documentation 10 |  | 1h | 2000-06-20 09:00 | 2000-06-20 10:00 |  | 2000-06-20 08:00 | 2000-06-20 09:00 | 1h | 60.03d |  | start no earlier than 2000-06-20 08:00 | Christophe | 1h | 600 | 600 |
| 322 | 4.1.1.1.9.11 | Mettre à jour la documentation 11 |  | 1h | 2000-06-27 09:00 | 2000-06-27 10:00 |  | 2000-06-27 08:00 | 2000-06-27 09:00 | 1h | 55.65d |  | start no earlier than 2000-06-27 08:00 | Christophe | 1h | 600 | 600 |
| 323 | 4.1.1.1.9.12 | Mettre à jour la documentation 12 |  | 1h | 2000-07-04 09:00 | 2000-07-04 10:00 |  | 2000-07-04 08:00 | 2000-07-04 09:00 | 1h | 51.28d |  | start no earlier than 2000-07-04 08:00 | Christophe | 1h | 600 | 600 |
| 324 | 4.1.1.1.9.13 | Mettre à jour la documentation 13 |  | 1h | 2000-07-11 09:00 | 2000-07-11 10:00 |  | 2000-07-11 08:00 | 2000-07-11 09:00 | 1h | 46.9d |  | start no earlier than 2000-07-11 08:00 | Christophe | 1h | 600 | 600 |
| 325 | 4.1.1.1.9.14 | Mettre à jour la documentation 14 |  | 1h | 2000-07-18 09:00 | 2000-07-18 10:00 |  | 2000-07-18 08:00 | 2000-07-18 09:00 | 1h | 42.53d |  | start no earlier than 2000-07-18 08:00 | Christophe | 1h | 600 | 600 |
| 326 | 4.1.1.1.9.15 | Mettre à jour la documentation 15 |  | 1h | 2000-07-25 09:00 | 2000-07-25 10:00 |  | 2000-07-25 08:00 | 2000-07-25 09:00 | 1h | 38.15d |  | start no earlier than 2000-07-25 08:00 | Christophe | 1h | 600 | 600 |
| 327 | 4.1.1.1.10 | Faire un bilan intermédiaire |  | 1d | 2000-05-15 09:00 | 2000-05-16 10:00 |  | 2000-05-15 08:00 | 2000-05-15 17:00 | 1d | 80.15d | 0d | start no earlier than 2000-05-15 08:00 | Karen [50%]; Henri [50%] | 8h | 2,800 | 2,800 |
| 328 | 4.1.1.1.11 | Bilan intermédiaire | milestone | 0d | 2000-05-16 10:00 | 2000-05-16 10:00 | 327 | 2000-05-15 17:00 | 2000-05-15 17:00 | 0d | 80.15d |  |  |  |  |  |  |
| 329 | 4.1.1.1.12 | Préparer la communication presse |  | 5d | 2000-05-25 09:00 | 2000-06-02 16:00 |  | 2000-05-25 08:00 | 2000-05-31 17:00 | 5d | 69.15d |  | start no earlier than 2000-05-25 08:00 | Christophe [20%] | 8h | 4,800 | 4,800 |
| 330 | 4.1.1.1.13 | Envoyer communication presse |  | 1d | 2000-06-26 09:00 | 2000-06-27 10:00 |  | 2000-06-26 08:00 | 2000-06-26 17:00 | 1d | 55.65d | 51.65d | start no earlier than 2000-06-26 08:00 | Christophe [25%] | 2h | 1,200 | 1,200 |
| 331 | 4.1.1.1.14 | Communication presse | milestone | 0d | 2000-09-18 10:12 | 2000-09-18 10:12 | 164, 330 | 2000-08-30 09:12 | 2000-08-30 09:12 | 0d | 4d |  |  |  |  |  |  |
| 332 | 4.1.1.1.15 | Rédiger la communication clients |  | 1d | 2000-06-26 09:00 | 2000-06-27 10:00 |  | 2000-06-26 08:00 | 2000-06-26 17:00 | 1d | 55.65d |  | start no earlier than 2000-06-26 08:00 | Henri [50%] | 4h |  |  |
| 333 | 4.1.1.1.16 | Envoyer la communication clients |  | 1d | 2000-09-18 10:12 | 2000-09-19 11:12 | 164 | 2000-08-30 09:12 | 2000-08-31 09:12 | 1d | 3d | 0d |  | Henri | 8h |  |  |
| 334 | 4.1.1.1.17 | Communication clients | milestone | 0d | 2000-09-19 11:12 | 2000-09-19 11:12 | 333 | 2000-08-31 09:12 | 2000-08-31 09:12 | 0d | 3d |  |  |  |  |  |  |

| ID | WBS | Task | Type | Duration | Start | Finish | Predecessors | Baseline start | Baseline finish | Baseline duration | Total slack | Resources | Work | Cost | Baseline cost |
| --- | --- | --- | --- | --- | --- | --- | --- | --- | --- | --- | --- | --- | --- | --- | --- |
| 335 | 4.2 | **Faire le bilan du projet** |  | 4d | 2000-09-18 10:12 | 2000-09-22 16:12 |  | 2000-08-30 09:12 | 2000-09-05 09:12 | 4d | 0d |  | 35h | 19,050 | 19,050 |
| 336 | 4.2.1 | **Promotion** |  | 1d | 2000-09-18 10:12 | 2000-09-19 11:12 |  | 2000-08-30 09:12 | 2000-08-31 09:12 | 1d | 0d |  | 2h | 700 | 700 |
| 337 | 4.2.1.1 | Vendre le projet |  | 1d | 2000-09-18 10:12 | 2000-09-19 11:12 | 164 | 2000-08-30 09:12 | 2000-08-31 09:12 | 1d | 0d | Karen [12.5%]; Henri [12.5%] | 2h | 700 | 700 |
| 338 | 4.2.1.2 | Présentation de projet | milestone | 0d | 2000-09-19 11:12 | 2000-09-19 11:12 | 337 | 2000-08-31 09:12 | 2000-08-31 09:12 | 0d | 0d |  |  |  |  |
| 339 | 4.2.2 | **Désengagement** |  | 1d | 2000-09-19 11:12 | 2000-09-20 14:12 |  | 2000-08-31 09:12 | 2000-09-01 09:12 | 1d | 0d |  | 1h | 350 | 350 |
| 340 | 4.2.2.1 | Mettre un terme à l'engagement contractuel |  | 1d | 2000-09-19 11:12 | 2000-09-20 14:12 | 338 | 2000-08-31 09:12 | 2000-09-01 09:12 | 1d | 0d | Karen [6.2%]; Henri [6.2%] | 1h | 350 | 350 |
| 341 | 4.2.2.2 | Note de désengagement | milestone | 0d | 2000-09-20 14:12 | 2000-09-20 14:12 | 340 | 2000-09-01 09:12 | 2000-09-01 09:12 | 0d | 0d |  |  |  |  |
| 342 | 4.2.3 | **Capitalisation** |  | 2d | 2000-09-20 14:12 | 2000-09-22 16:12 |  | 2000-09-01 09:12 | 2000-09-05 09:12 | 2d | 0d |  | 32h | 18,000 | 18,000 |
| 343 | 4.2.3.1 | Organiser les réunions de débriefing |  | 1d | 2000-09-20 14:12 | 2000-09-21 15:12 | 341 | 2000-09-01 09:12 | 2000-09-04 09:12 | 1d | 0d | Karen [50%]; Christophe; Claudio; François | 28h | 15,600 | 15,600 |
| 344 | 4.2.3.2 | Bilan final de projet | milestone | 0d | 2000-09-21 15:12 | 2000-09-21 15:12 | 343 | 2000-09-04 09:12 | 2000-09-04 09:12 | 0d | 0d |  |  |  |  |
| 345 | 4.2.3.3 | Archiver les dossiers du projet |  | 1d | 2000-09-21 15:12 | 2000-09-22 16:12 | 344 | 2000-09-04 09:12 | 2000-09-05 09:12 | 1d | 0d | Christophe [50%] | 4h | 2,400 | 2,400 |
| 346 | 4.2.3.4 | Note d’archivage | milestone | 0d | 2000-09-22 16:12 | 2000-09-22 16:12 | 345 | 2000-09-05 09:12 | 2000-09-05 09:12 | 0d | 0d |  |  |  |  |
| 347 | 5 | Fin du projet | milestone | 0d | 2000-09-22 16:12 | 2000-09-22 16:12 | 346 | 2000-09-05 09:12 | 2000-09-05 09:12 | 0d | 0d |  |  |  |  |
